# Heavy Flavor Tracker

Schedule from MS Project, 2009-10-01 to 2015-09-30, costs in $, A marks actual dates.
Integrated Project Schedule

## Calendars

- Standard: Mon-Fri 08:00-12:00, 13:00-17:00; Sat-Sun off. Exceptions (off unless hours are given): 2010-11-25 to 2010-11-26, 2010-12-24 to 2010-12-25, 2010-12-31 to 2011-01-01, 2011-01-17, 2011-02-28, 2011-05-30, 2011-07-04, 2011-09-05, 2011-11-24 to 2011-11-25, 2011-12-24 to 2011-12-25, 2011-12-31 to 2012-01-01, 2012-01-16, 2012-02-27, 2012-05-28, 2012-07-04, 2012-09-03, 2012-11-22 to 2012-11-23, 2012-12-24 to 2012-12-25, 2012-12-31 to 2013-01-01, 2013-01-21, 2013-02-25, 2013-05-27, 2013-07-04, 2013-09-02, 2013-11-22, 2013-11-28, 2013-12-24 to 2013-12-25, 2013-12-31 to 2014-01-01, 2014-01-20, 2014-02-24, 2014-05-26, 2014-07-04, 2014-09-01, 2014-11-27 to 2014-11-28, 2014-12-24 to 2014-12-25, 2014-12-31 to 2015-01-01, 2015-01-19, 2015-02-23, 2015-05-25, 2015-07-04, 2015-09-07.

## Resources

| Resource | Group | Rate | Notes |
| --- | --- | --- | --- |
| LBL_Machinist Jr. | LBL | 106.36 | 10/19/09 based on E. Anderssons rates base R&D - construction rate does not have full burden - currently 81% of full burden at LBNL (R&D Rate) |
| LBL_CMM | LBL | 105.12 |  |
| LBL_Mech Tech 4 | LBL | 104.65 |  |
| LBL_Mech Eng Sr. | LBL | 144.96 |  |
| LBL_Electrical Designer | LBL | 105.83 |  |
| LBL_Material | LBL | 1163.57 | Purchase Cost $15,000 / Procurement Burden 9.5% $1,425 / Subtotal $16,425 / Less Purchase cost ($15,000) / Procurement Burden $1,425 / Fabrication Rate (applied to burden only) 31.1% $443 / Total $16,868 / Escalation Rates FY10 Labor 3.0%3.0%3.0%3.0%3.0% Supplies & Other Expenses (OMB) 1.6%1.8%2.0%2.1%2.1% Construction Projects (OECM) 1.6%1.8%2.0%2.1%2.1% |
| LBL_Travel | LBL | 1248.39 | TRAVEL Travel Costs $2,000 Travel Burden 15.8% 316 2,316 Less travel cost (2,000) Travel burden 316 Fabrication Rate (applied to burden only) 31.1%98 414 TOTAL TRAVEL $2,414 |
| LBL_Project Controls | LBL | 95.43 |  |
| LBL_Material_unburdened | LBL | 1000 |  |
| LBL_Shop R&D | LBL | 126 | 10/19/09 based on E. Anderssons rates base R&D - construction rate does not have full burden - currently 81% of full burden at LBNL (R&D Rate) |
| LBL_CMM R&D | LBL | 126 |  |
| LBL_M_Tech R&D | LBL | 117 |  |
| LBL_Engineer R&D | LBL | 150 |  |
| LBL_Designer R&D | LBL | 125 |  |
| LBL_Engineer Redirected | LBL | 116.48 |  |
| BNL Engineer Redirected - STAR | BNL | 125.15 |  |
| BNL M_Tech Redirected | BNL | 97.61 |  |
| LBL_Postdoc Contributed | LBL |  |  |
| LBL_Scientist Contributed | LBL |  |  |
| BNL Scientest Contributed | BNL |  |  |
| MIT Material | MIT | 1000 |  |
| MIT Mech Eng Project | MIT | 84.86 |  |
| MIT Mech Draft Project | MIT | 102.71 |  |
| MIT_IUCF Elec Eng Project | MIT | 134.52 |  |
| MIT Elec Eng Project | MIT | 80.74 |  |
| MIT Elec Draft Project | MIT | 102.71 |  |
| MIT Travel | MIT | 118 |  |
| MIT Tech Proj | MIT | 84.32 |  |
| MIT Tech Proj II | MIT | 102.71 |  |
| MIT Book Keeper | MIT | 16.83 |  |
| LBL_Mech Tech 3 | LBL | 71.15 |  |
| LBL_Mech Engineer | LBL | 84.48 |  |
| LBL_Elec Eng Sr | LBL | 136.59 |  |
| LBL_Elec Tech Sr. | LBL | 67.01 |  |
| LBL_Machinist Sr. | LBL | 118.94 |  |
| LBL_Elec Tech | LBL | 85.16 |  |
| BNL Scientist Sr. (Redirect) | BNL | 200.58 |  |
| BNL Elec. Eng Sr. (Redirect) | BNL | 163.66 |  |
| BNL Elec. Tech (Redirect) | BNL | 97.75 |  |
| BNL Mech. Sr. Designer (Redirect) | BNL | 127.94 |  |
| BNL Mech Tech (Redirect) | BNL | 97.75 |  |
| BNL Mech Tech | BNL | 97.75 |  |
| BNL Scheduler/Budget Specialist | BNL | 127.67 |  |
| BNL Project Controls Admin | BNL | 168.84 |  |
| BNL Mech Engineer | BNL | 163.66 |  |
| BNL Carpenter | BNL |  |  |
| BNL Electrician | BNL |  |  |
| BNL Rigger | BNL |  |  |
| BNL Welder | BNL |  |  |
| SUBATECH Engineer | SUB |  |  |
| BNL Travel | BNL | 1510 |  |
| BNL Material | BNL | 1000 |  |
| IUCF Elec Eng Project |  | 134.52 |  |
| BNL Elec. Tech (Contributed) | BNL |  |  |

## Schedule

| ID | WBS | Task | Type | Duration | Start | Finish | Predecessors | Complete | Remaining | Total slack | Free slack | Constraint | Resources | Work | Actual work | Cost | Actual cost | Participating Institutions |
| --- | --- | --- | --- | --- | --- | --- | --- | --- | --- | --- | --- | --- | --- | --- | --- | --- | --- | --- |
| 1 | 1 | **HFT** |  | 1516d? | 2009-10-01 A | 2015-09-30 |  | 1% | 1498.22d? | 0d |  |  |  | 83723.5h | 2351.2h | 12,002,358.04 | 280,261.85 |  |
| 2 | 1.1 | **Management** |  | 1493d? | 2009-11-03 | 2015-09-30 |  |  |  | 0d |  |  |  | 4918.32h |  | 983,324.68 |  |  |
| 3 | 1.1.1 | **Project Management** |  | 933d? | 2010-08-31 | 2014-05-15 |  |  |  | 345d |  |  |  | 4918.32h |  | 983,324.68 |  |  |
| 4 | 1.1.1.1 | Project Support (BNL) post CD 1 |  | 142d | 2010-08-31 | 2011-03-24 | 29 |  |  | 1136d |  |  | BNL Scientist Sr. (Redirect) [25%] | 284h |  | 56,696.6 |  | ܁* |
| 5 | 1.1.1.2 | Additional Project Support (BNL) Post CD 1 |  | 847d | 2011-01-03 | 2014-05-14 | 29FS+85d |  |  | 346d |  | start no earlier than 2011-01-03 | BNL Project Controls Admin [20%] | 813.12h |  | 140,843.13 |  | ܁* |
| 6 | 1.1.1.3 | Project Support (LBNL) post CD 1 |  | 142d | 2010-09-01 | 2011-03-25 | 319, 29 |  |  | 1135d |  |  | LBL_Project Controls [30%] | 340.8h |  | 32,375.62 |  | ܁- |
| 7 | 1.1.1.4 | Project Support (BNL) post CD 2/3 |  | 791d | 2011-03-24 | 2014-05-14 | 30 |  |  | 346d |  |  | BNL Scientist Sr. (Redirect) [25%] | 1582h |  | 330,235.97 |  | ܁* |
| 8 | 1.1.1.5 | Project Support (LBNL) post CD 2/3 |  | 791d | 2011-03-24 | 2014-05-14 | 30 |  |  | 346d |  |  | LBL_Project Controls [30%] | 1898.4h |  | 188,536.69 |  | ܁- |
| 9 | 1.1.1.6 | Project Support (BNL) Pre-Ops |  | 1d? | 2014-01-15 | 2014-01-15 | 33 |  |  | 429d |  |  |  |  |  |  |  | ܁* |
| 10 | 1.1.1.7 | Project Support (LBNL) Pre-Ops |  | 1d? | 2014-01-15 | 2014-01-15 | 33 |  |  | 429d |  |  |  |  |  |  |  | ܁- |
| 11 | 1.1.1.8 | Materials and Expenses (BNL) |  | 314d | 2010-08-31 | 2014-03-31 | 29 |  |  | 378d |  |  | BNL Material [500%] |  |  | 5,000 |  | ܁* |
| 12 | 1.1.1.9 | Travel (BNL) |  | 900d | 2010-08-31 | 2014-03-31 | 29 |  |  | 378d |  |  | BNL Travel [3200%] |  |  | 48,320 |  | ܁* |
| 13 | 1.1.1.10 | Travel (LBNL) |  | 933d | 2010-08-31 | 2014-05-15 | 29 |  |  | 345d |  |  | LBL_Travel [4800%] |  |  | 61,316.68 |  | ܁- |
| 14 | 1.1.1.11 | BNL Overhead for IST (MIT) Contract |  | 65d? | 2011-09-01 | 2012-09-01 |  |  |  | 769d |  | finish no earlier than 2012-09-01 | BNL Material [12000%] |  |  | 120,000 |  | ܁* |
| 15 | 1.1.2 | **Reviews/Meetings** |  | 1493d | 2009-11-03 | 2015-09-30 |  |  |  | 0d |  |  |  |  |  |  |  |  |
| 16 | 1.1.2.1 | CD-1 Review |  | 3d | 2009-11-03 | 2009-11-05 |  |  |  | 1490d |  | start no earlier than 2009-11-03 |  |  |  |  |  |  |
| 17 | 1.1.2.2 | CD-1 Approval | milestone | 0d | 2010-08-31 | 2010-08-31 |  |  |  | 31d | 0d | start no earlier than 2010-08-31 |  |  |  |  |  |  |
| 18 | 1.1.2.3 | Project Meeting (Face to Face) run through of cost and schedule |  | 2d | 2010-12-08 | 2010-12-09 | 17 |  |  | 1205d | 29d | start no earlier than 2010-12-08 |  |  |  |  |  |  |
| 19 | 1.1.2.4 | CD 2/3 Dry Run (BNL Presentations) |  | 2d | 2011-01-25 | 2011-01-26 | 18 |  |  | 1176d |  | start no earlier than 2011-01-25 |  |  |  |  |  |  |
| 20 | 1.1.2.5 | CD 2/3 Review |  | 2d | 2011-03-22 | 2011-03-23 |  |  |  | 264d | 0d | start no earlier than 2011-03-22 |  |  |  |  |  |  |
| 21 | 1.1.2.6 | CD 2/3 Approval | milestone | 0d | 2011-03-23 | 2011-03-23 | 20 |  |  | 264d | 0d |  |  |  |  |  |  |  |
| 22 | 1.1.2.7 | Annual DOE Review |  | 2d | 2011-09-13 | 2011-09-14 | 21FS+120d |  |  | 264d | 0d |  |  |  |  |  |  |  |
| 23 | 1.1.2.8 | Annual DOE Review |  | 2d | 2012-09-11 | 2012-09-12 | 22FS+251d |  |  | 264d | 0d |  |  |  |  |  |  |  |
| 24 | 1.1.2.9 | Annual DOE Review |  | 2d | 2013-09-10 | 2013-09-11 | 23FS+247d |  |  | 264d | 0d |  |  |  |  |  |  |  |
| 25 | 1.1.2.10 | Annual DOE Review |  | 2d | 2014-09-09 | 2014-09-10 | 24FS+247d |  |  | 264d |  |  |  |  |  |  |  |  |
| 26 | 1.1.2.11 | CD 4 | milestone | 0d | 2015-09-30 | 2015-09-30 |  |  |  | 0d |  | start no earlier than 2015-09-30 |  |  |  |  |  |  |

Notes:
- 12: For BNL people to travel to face to face meetings every other quarter outside BNL (per trip 3 people) / For DOE rev. Add 2 people once a year / (3 people x 2 trips) x 4 years = 24 / (2 people x 1 trip) x 4 years = 8
- 13: For LBNL people to travel to BNL for face to face meetings and CD 2/3 review. Assume 6 people every other quarter. / (6 people x 2 trips) x 4 years = 48

| ID | WBS | Task | Type | Duration | Start | Finish | Predecessors | Complete | Remaining | Total slack | Free slack | Constraint | Resources | Work | Actual work | Cost | Actual cost | Participating Institutions |
| --- | --- | --- | --- | --- | --- | --- | --- | --- | --- | --- | --- | --- | --- | --- | --- | --- | --- | --- |
| 27 | 1.1.3 | **Funding Milestones** |  | 917d | 2010-05-26 | 2014-01-15 |  |  |  | 413d |  |  |  |  |  |  |  |  |
| 28 | 1.1.3.1 | FY2010 R&D Funding (LBNL) | milestone | 0d | 2010-05-26 | 2010-05-26 |  |  |  | 1347d |  | start no earlier than 2010-05-26 |  |  |  |  |  |  |
| 29 | 1.1.3.2 | FY2010 MIE Funding | milestone | 0d | 2010-08-31 | 2010-08-31 |  |  |  | 344d | 0d | start no earlier than 2010-08-31 |  |  |  |  |  |  |
| 30 | 1.1.3.3 | FY2011 Funding | milestone | 0d | 2011-03-23 | 2011-03-23 | 29, 21 |  |  | 346d | 0d | start no earlier than 2011-02-28 |  |  |  |  |  |  |
| 31 | 1.1.3.4 | FY2012 Funding | milestone | 0d | 2012-01-16 | 2012-01-16 | 30 |  |  | 929d | 250d | start no earlier than 2012-01-16 |  |  |  |  |  |  |
| 32 | 1.1.3.5 | FY2013 Funding | milestone | 0d | 2013-01-15 | 2013-01-15 | 31 |  |  | 679d | 250d | start no earlier than 2013-01-15 |  |  |  |  |  |  |
| 33 | 1.1.3.6 | FY2014 Pre-Ops Funding | milestone | 0d | 2014-01-15 | 2014-01-15 | 32 |  |  | 429d | 0d | start no earlier than 2014-01-15 |  |  |  |  |  |  |
| 34 | 1.2 | **Pixel Detector (PXL)** |  | 1002d? | 2010-05-26 A | 2014-05-15 |  | 4% | 963.16d? | 345d |  |  |  | 47518.8h | 2112h | 6,131,964.57 | 280,000 | ܁- |
| 35 | 1.2.1 | **Pixel Mechanics** |  | 932d | 2010-08-31 | 2014-05-14 |  |  |  | 346d |  |  |  | 11428.4h |  | 1,504,821.14 |  | ܁- |
| 36 | 1.2.1.1 | **Module Support (Sector)** |  | 401d | 2011-05-04 | 2012-11-30 |  |  |  | 707d |  |  |  | 2182h |  | 302,800.54 |  | ܁- |
| 37 | 1.2.1.1.1 | **Sector Mechanical Prototypes (engineering Run)** |  | 70d | 2011-05-04 | 2011-08-11 |  |  |  | 901d |  |  |  | 346h |  | 44,189.34 |  | ܁- |
| 38 | 1.2.1.1.1.1 | Sector Tool |  | 10d | 2011-05-04 | 2011-05-17 |  |  |  | 901d | 0d | start no earlier than 2011-05-04 | LBL_Material [16%]; LBL_Machinist Jr.; LBL_Mech Tech 4 [13%]; LBL_Engineer Redirected [50%] | 66h |  | 7,607.04 |  | ܁- |
| 39 | 1.2.1.1.1.2 | Engineering Run Laminates |  | 20d | 2011-05-18 | 2011-06-15 | 38 |  |  | 1078d |  |  | LBL_Mech Tech 4 [50%] | 80h |  | 8,371.84 |  | ܁- |
| 40 | 1.2.1.1.1.3 | **Interface Parts (Prototype)** |  | 60d | 2011-05-18 | 2011-08-11 |  |  |  | 901d |  |  |  | 200h |  | 28,210.46 |  | ܁- |
| 41 | 1.2.1.1.1.3.1 | Prototype Dovetail |  | 3mo | 2011-05-18 | 2011-08-11 | 38 |  |  | 901d | 0d |  | LBL_Material [200%]; LBL_Machinist Sr. [41.7%] | 200h |  | 26,116.03 |  | ܁- |
| 42 | 1.2.1.1.1.3.2 | Prototype End Reinforcement (SLA) |  | 5d | 2011-05-18 | 2011-05-24 | 38 |  |  | 1093d |  |  | LBL_Material [180%] |  |  | 2,094.43 |  | ܁- |
| 43 | 1.2.1.1.2 | **Production Sectors** |  | 204d | 2011-08-01 | 2012-05-17 |  |  |  | 843d |  |  |  | 496h |  | 113,390.09 |  | ܁- |
| 44 | 1.2.1.1.2.1 | **Sector Laminates** |  | 73d | 2012-02-06 | 2012-05-17 |  |  |  | 728d |  |  |  | 96h |  | 57,227.99 |  | ܁- |
| 45 | 1.2.1.1.2.1.1 | M46J Procurement |  | 5d | 2012-02-06 | 2012-02-10 |  |  |  | 728d | 0d | start no earlier than 2012-02-06 | LBL_Material [3800%]; LBL_Mech Tech 4 [40%] | 16h |  | 46,824.73 |  | ܁- |
| 46 | 1.2.1.1.2.1.2 | Sector Lamination |  | 5.6w | 2012-04-10 | 2012-05-17 | 45FS+8w |  |  | 728d | 0d |  | LBL_Mech Tech 4 [35.7%]; LBL_Material [150%] | 80h |  | 10,403.26 |  | ܁- |
| 47 | 1.2.1.1.2.2 | **Interface Parts** |  | 125d | 2011-08-01 | 2012-01-26 |  |  |  | 922d |  |  |  | 400h |  | 56,162.1 |  | ܁- |
| 48 | 1.2.1.1.2.2.1 | Dovetail |  | 12w | 2011-08-01 | 2011-10-24 |  |  |  | 922d | 0d | start no earlier than 2011-08-01 | LBL_Material [200%]; LBL_Machinist Sr. [41.7%] | 200h |  | 26,318.75 |  | ܁- |
| 49 | 1.2.1.1.2.2.2 | End Reinforcement (SLA) |  | 5d | 2011-10-25 | 2011-10-31 | 48 |  |  | 982d |  |  | LBL_Material [125%] |  |  | 1,483.56 |  | ܁- |
| 50 | 1.2.1.1.2.2.3 | Dovetail Batch 2 |  | 12w | 2011-10-25 | 2012-01-19 | 48 |  |  | 922d | 0d |  | LBL_Material [200%]; LBL_Machinist Sr. [41.7%] | 200h |  | 26,876.24 |  | ܁- |
| 51 | 1.2.1.1.2.2.4 | End Reinforcement (SLA) Batch 2 |  | 5d | 2012-01-20 | 2012-01-26 | 50 |  |  | 922d |  |  | LBL_Material [125%] |  |  | 1,483.56 |  | ܁- |

Notes:
- 51: Sector Survey - Lines 122-126

| ID | WBS | Task | Type | Duration | Start | Finish | Predecessors | Total slack | Free slack | Constraint | Resources | Work | Cost | Participating Institutions |
| --- | --- | --- | --- | --- | --- | --- | --- | --- | --- | --- | --- | --- | --- | --- |
| 52 | 1.2.1.1.3 | **Sector Assembly** |  | 301d | 2011-08-12 | 2012-10-17 |  | 712d |  |  |  | 660h | 71,050.39 | ܁- |
| 53 | 1.2.1.1.3.1 | **Mechanical Sector Assemblies** |  | 235d | 2011-08-12 | 2012-07-16 |  | 728d |  |  |  | 180h | 19,330.13 | ܁- |
| 54 | 1.2.1.1.3.1.1 | **Sector Component Assembly** |  | 235d | 2011-08-12 | 2012-07-16 |  | 728d |  |  |  | 180h | 19,330.13 | ܁- |
| 55 | 1.2.1.1.3.1.1.1 | Bonded Assembly Tool (Iteration) |  | 16h | 2011-08-12 | 2011-08-15 | 41 | 901d | 0d |  | LBL_Material [12%]; LBL_Machinist Jr.; LBL_Mech Tech 4 [50%] | 24h | 2,678.54 | ܁- |
| 56 | 1.2.1.1.3.1.1.2 | Bonded Assembly (Engineering Run Full Complement) |  | 1mo | 2011-08-16 | 2011-09-13 | 55 | 901d | 0d |  | LBL_Mech Tech 4 [32.5%] | 52h | 5,441.7 | ܁- |
| 57 | 1.2.1.1.3.1.1.3 | Bonded Assembly Production 1st copy |  | 2mo | 2012-05-18 | 2012-07-16 | 56, 46 | 728d | 21d |  | LBL_Mech Tech 4 [32.5%] | 104h | 11,209.89 | ܁- |
| 58 | 1.2.1.1.3.2 | **Electrical Sector Assemblies** |  | 279d | 2011-09-14 | 2012-10-17 |  | 712d |  |  |  | 480h | 51,720.26 | ܁- |
| 59 | 1.2.1.1.3.2.1 | Ladders Ready for Sector Mounting | milestone | 0d | 2012-06-26 | 2012-06-26 |  | 707d | 0d | start no earlier than 2012-06-26 |  |  |  | ܁- |
| 60 | 1.2.1.1.3.2.2 | **Engineering Run Sector Assemblies** |  | 40d | 2011-09-14 | 2011-11-08 |  | 951d |  |  |  | 160h | 17,060.14 | ܁- |
| 61 | 1.2.1.1.3.2.2.1 | Ladder Mounting Engineering Run |  | 2w | 2011-09-14 | 2011-09-27 | 56 | 951d | 0d |  | LBL_Mech Tech 4 [60%] | 48h | 5,023.1 | ܁- |
| 62 | 1.2.1.1.3.2.2.2 | Ladder Mounting Engineering Run Full Complement |  | 6w | 2011-09-28 | 2011-11-08 | 61 | 951d | 0d |  | LBL_Mech Tech 4 [46.7%] | 112h | 12,037.03 | ܁- |
| 63 | 1.2.1.1.3.2.3 | **Production Sector Assemblies** |  | 80d | 2012-06-26 | 2012-10-17 |  | 707d |  |  |  | 320h | 34,660.13 | ܁- |
| 64 | 1.2.1.1.3.2.3.1 | Production Sectors First Copy |  | 2mo | 2012-06-26 | 2012-08-21 | 57SS+5d, 59 | 707d | 0d |  | LBL_Mech Tech 4 [50%] | 160h | 17,245.99 | ܁- |
| 65 | 1.2.1.1.3.2.3.2 | Production Sectors Second Copy |  | 2mo | 2012-08-22 | 2012-10-17 | 64 | 707d | 0d |  | LBL_Mech Tech 4 [50%] | 160h | 17,414.14 | ܁- |
| 66 | 1.2.1.1.4 | **Sector Mount And Survey** |  | 269d | 2011-11-09 | 2012-11-30 |  | 707d |  |  |  | 680h | 74,170.71 | ܁- |
| 67 | 1.2.1.1.4.1 | Sector Mount and Survey Eng Run |  | 2w | 2011-11-09 | 2011-11-22 | 62 | 951d | 0d |  | LBL_Mech Tech 4 [75%]; LBL_CMM [50%] | 100h | 10,798.26 | ܁- |
| 68 | 1.2.1.1.4.2 | Sector Mount and Survey Eng Run Full Complement |  | 3w | 2011-11-23 | 2011-12-15 | 67 | 951d |  |  | LBL_Mech Tech 4 [93.3%]; LBL_CMM [23.3%] | 140h | 15,103.91 | ܁- |
| 69 | 1.2.1.1.4.3 | Sector Mount and Survey 2013 Install |  | 6w | 2012-08-22 | 2012-10-03 | 64 | 717d | 10d |  | LBL_Mech Tech 4 [66.7%]; LBL_CMM [25%] | 220h | 23,813.75 | ܁- |
| 70 | 1.2.1.1.4.4 | Sector Mount and Survey Spare |  | 6w | 2012-10-18 | 2012-11-30 | 69, 65 | 707d |  |  | LBL_Mech Tech 4 [66.7%]; LBL_CMM [25%] | 220h | 24,454.79 | ܁- |
| 71 | 1.2.1.2 | **D-Tube and Kinematic Mounts** |  | 479d | 2010-09-01 | 2012-07-23 |  | 798d |  |  |  | 1572h | 201,944.28 | ܁- |
| 72 | 1.2.1.2.1 | **Prototype D-Tube** |  | 208d | 2010-09-01 | 2011-06-28 |  | 1069d |  |  |  | 780h | 94,490.98 | ܁- |
| 73 | 1.2.1.2.1.1 | **Tooling D-Tube Shell** |  | 38.88d | 2010-09-01 | 2010-10-25 |  | 1203.12d |  |  |  | 200h | 26,264.5 | ܁- |
| 74 | 1.2.1.2.1.1.1 | **Half Shell Lamination** |  | 16.88d | 2010-10-01 | 2010-10-25 |  | 1183.12d |  |  |  | 120h | 17,182.26 | ܁- |
| 75 | 1.2.1.2.1.1.1.1 | Welded Tube Assembly/Machine |  | 60h | 2010-10-01 | 2010-10-12 |  | 1183.12d | 0d | start no earlier than 2010-10-01 | LBL_Material [150%]; LBL_Machinist Sr. | 60h | 8,882.02 | ܁- |
| 76 | 1.2.1.2.1.1.1.2 | Trim Fixture |  | 75h | 2010-10-12 | 2010-10-25 | 75 | 1183.12d | 0d |  | LBL_Material; LBL_Machinist Sr. [80%] | 60h | 8,300.24 | ܁- |

| ID | WBS | Task | Duration | Start | Finish | Predecessors | Total slack | Free slack | Constraint | Resources | Work | Cost | Participating Institutions |
| --- | --- | --- | --- | --- | --- | --- | --- | --- | --- | --- | --- | --- | --- |
| 77 | 1.2.1.2.1.1.2 | **Half Shell Bond** | 11d | 2010-09-01 | 2010-09-15 |  | 1231d |  |  |  | 80h | 9,082.24 | ܁- |
| 78 | 1.2.1.2.1.1.2.1 | Assembly Jig (w/out Kinematic Mounts) | 24h | 2010-09-01 | 2010-09-03 |  | 1231d | 0d | start no earlier than 2010-09-01 | LBL_Material [64%]; LBL_Machinist Jr. [66.7%]; LBL_Mech Tech 4 | 40h | 4,822.08 | ܁- |
| 79 | 1.2.1.2.1.1.2.2 | Assembly Jig (w/ Kinematic Mounts) | 64h | 2010-09-06 | 2010-09-15 | 78 | 1231d | 47.88d |  | LBL_Material [16%]; LBL_Machinist Jr. [25%]; LBL_Mech Tech 4 [50%] | 40h | 4,260.16 | ܁- |
| 80 | 1.2.1.2.1.2 | **D-Tube Laminate Fabrication** | 149.12d | 2010-10-25 | 2011-05-31 |  | 1069d |  |  |  | 136h | 15,395.7 | ܁- |
| 81 | 1.2.1.2.1.2.1 | Half Shell Insertion Test Bed | 4w | 2010-10-25 | 2010-11-22 | 76 | 1183.12d | 0d |  | LBL_Material [50%]; LBL_Mech Tech 4 [55%] | 88h | 9,790.81 | ܁- |
| 82 | 1.2.1.2.1.2.2 | Half Shell Engineering Run | 2w | 2011-05-17 | 2011-05-31 |  | 1069d | 0d | start no earlier than 2011-05-17 | LBL_Material [50%]; LBL_Mech Tech 4 [60%] | 48h | 5,604.89 | ܁- |
| 83 | 1.2.1.2.1.3 | **Prototype Kinematic Mounts** | 105d | 2011-01-04 | 2011-06-02 |  | 1077d |  |  |  | 200h | 27,279.6 | ܁- |
| 84 | 1.2.1.2.1.3.1 | Kinematic Mount Prototype (1/2 Detector) | 2w | 2011-01-04 | 2011-01-18 |  | 1122d | 0d | start no earlier than 2011-01-04 | LBL_Material; LBL_Machinist Sr. [50%] | 40h | 5,921.35 | ܁- |
| 85 | 1.2.1.2.1.3.2 | Kinematic Mount (Insertion Test Bed) | 4w | 2011-02-02 | 2011-03-02 | 84FS+2w | 1122d | 0d |  | LBL_Material; LBL_Machinist Sr. [50%] | 80h | 10,679.13 | ܁- |
| 86 | 1.2.1.2.1.3.3 | Kinematic Mount Prototype (Engineering Run) | 4w | 2011-05-05 | 2011-06-02 | 85, 109 | 1077d | 8d |  | LBL_Material; LBL_Machinist Sr. [50%] | 80h | 10,679.13 | ܁- |
| 87 | 1.2.1.2.1.4 | **D-Tube Bonded Assembly (w/out mounts)** | 149.12d | 2010-11-22 | 2011-06-28 |  | 1069d |  |  |  | 244h | 25,551.17 | ܁- |
| 88 | 1.2.1.2.1.4.1 | Tool Assembly and Survey | 3w | 2010-11-22 | 2010-12-15 | 79, 81 | 1183.12d | 0d |  | LBL_Mech Tech 4 [33.3%]; LBL_CMM [3.3%] | 44h | 4,606.41 | ܁- |
| 89 | 1.2.1.2.1.4.2 | Prototype D-Tube Assembly Insertion Test Bed | 2w | 2010-12-15 | 2010-12-30 | 88 | 1183.12d | 41.12d |  | LBL_Mech Tech 4 [60%] | 48h | 5,023.1 | ܁- |
| 90 | 1.2.1.2.1.4.3 | Kinematic Mount Bonded Assembly (Insertion Test Bed) | 2w | 2011-03-03 | 2011-03-16 | 89, 85 | 1142d |  |  | LBL_Mech Tech 4 [30%]; LBL_CMM [20%] | 40h | 4,193.5 | ܁- |
| 91 | 1.2.1.2.1.4.4 | Prototype D-Tube Assembly (Engineering Run) | 2w | 2011-06-01 | 2011-06-14 | 82, 109 | 1069d | 0d |  | LBL_Mech Tech 4 [60%] | 48h | 5,023.1 | ܁- |
| 92 | 1.2.1.2.1.4.5 | Kinematic Mount Bonded Assembly (Engineering Run) | 2w | 2011-06-15 | 2011-06-28 | 86, 91 | 1069d |  |  | LBL_Mech Tech 4 [60%]; LBL_CMM [20%] | 64h | 6,705.05 | ܁- |
| 93 | 1.2.1.2.2 | **Production D-Tube and Kinematic Mounts** | 121d | 2012-02-01 | 2012-07-23 |  | 798d |  |  |  | 792h | 107,453.31 | ܁- |
| 94 | 1.2.1.2.2.1 | **D-Tube Laminates Production** | 11d | 2012-02-01 | 2012-02-15 |  | 798d |  |  |  | 104h | 22,015.75 | ܁- |
| 95 | 1.2.1.2.2.1.1 | Procurement | 8h | 2012-02-01 | 2012-02-01 |  | 798d | 0d | start no earlier than 2012-02-01 | LBL_Material [1000%]; LBL_Mech Tech 4 | 8h | 12,730.75 | ܁- |
| 96 | 1.2.1.2.2.1.2 | Production Half Shell | 10d | 2012-02-02 | 2012-02-15 | 95 | 798d | 0d |  | LBL_Material [50%]; LBL_Mech Tech 4 [60%]; LBL_Mech Tech 3 [60%] | 96h | 9,284.99 | ܁- |
| 97 | 1.2.1.2.2.2 | **Interface Parts (Duct and Dovetail Plate)** | 60d | 2012-02-16 | 2012-05-10 |  | 798d |  |  |  | 240h | 37,117.55 | ܁- |
| 98 | 1.2.1.2.2.2.1 | 3" Duct | 5d | 2012-02-16 | 2012-02-22 | 96 | 798d | 0d |  | LBL_Material [500%] |  | 5,934.23 | ܁- |
| 99 | 1.2.1.2.2.2.2 | Dovetail Plate | 4w | 2012-02-23 | 2012-03-22 | 98 | 798d | 0d |  | LBL_Material [50%]; LBL_Machinist Sr. [50%] | 80h | 10,394.44 | ܁- |
| 100 | 1.2.1.2.2.2.3 | Kinematic Mount 1st Copy | 7w | 2012-03-23 | 2012-05-10 | 99 | 798d | 0d |  | LBL_Material; LBL_Machinist Sr. [57.1%] | 160h | 20,788.88 | ܁- |

| ID | WBS | Task | Type | Duration | Start | Finish | Predecessors | Total slack | Free slack | Constraint | Resources | Work | Cost | Participating Institutions |
| --- | --- | --- | --- | --- | --- | --- | --- | --- | --- | --- | --- | --- | --- | --- |
| 101 | 1.2.1.2.2.3 | **D-Tube Bonded Assembly** |  | 110d | 2012-02-16 | 2012-07-23 |  | 798d |  |  |  | 448h | 48,320.01 | ܁- |
| 102 | 1.2.1.2.2.3.1 | Production D-Tube Assembly |  | 9w | 2012-02-16 | 2012-04-19 | 96 | 863d |  |  | LBL_Mech Tech 4 [53.3%] | 192h | 20,695.19 | ܁- |
| 103 | 1.2.1.2.2.3.2 | Kinematic Mount Bonded Assembly |  | 10w | 2012-05-11 | 2012-07-23 | 100 | 798d |  |  | LBL_Mech Tech 4 [48%]; LBL_CMM [16%] | 256h | 27,624.82 | ܁- |
| 104 | 1.2.1.3 | **Insertion Mechanism and Internal Service Supports** |  | 336d | 2010-12-01 | 2012-03-29 |  | 878d |  |  |  | 2044h | 273,893.08 | ܁- |
| 105 | 1.2.1.3.1 | Pixel Insertion Testing Complete | milestone | 0d | 2011-05-04 | 2011-05-04 | 109 | 1107d |  |  |  |  |  | ܁- |
| 106 | 1.2.1.3.2 | **Insertion Test Bed** |  | 107d | 2010-12-01 | 2011-05-04 |  | 1001.75d |  |  |  | 496h | 62,780.07 | ܁- |
| 107 | 1.2.1.3.2.1 | Test Bed Fabrication |  | 6w | 2010-12-01 | 2011-01-13 |  | 1008.75d | 0d | start no earlier than 2010-12-01 | LBL_Material [750%]; LBL_Machinist Jr. [16.7%]; LBL_Mech Tech 4 [33.3%]; LBL_CMM [10%] | 144h | 23,875.88 | ܁- |
| 108 | 1.2.1.3.2.2 | Test Bed Assembly |  | 10w | 2011-01-14 | 2011-03-28 | 107 | 1008.75d | 7d |  | LBL_Machinist Jr. [12%]; LBL_Mech Tech 4 [66.7%]; LBL_CMM [20%]; LBL_Material [400%] | 192h | 24,840.15 | ܁- |
| 109 | 1.2.1.3.2.3 | Insertion Testing |  | 4w | 2011-04-07 | 2011-05-04 | 108, 118, 112 | 1001.75d | 0d |  | LBL_Mech Tech 4 [50%]; LBL_Mech Tech 3 [50%] | 160h | 14,064.03 | ܁- |
| 110 | 1.2.1.3.3 | **Prototype Insertion Mechanism** |  | 35d | 2011-01-14 | 2011-03-07 |  | 1023.75d |  |  |  | 88h | 20,253.05 | ܁- |
| 111 | 1.2.1.3.3.1 | Hardware (Bearings, Fasteners et-al) |  | 4w | 2011-01-14 | 2011-02-11 | 107 | 1023.75d | 0d |  | LBL_Material [500%]; LBL_Mech Tech 4 [10%] | 16h | 7,492.24 | ܁- |
| 112 | 1.2.1.3.3.2 | Hinge and Transfer Mechanism |  | 3w | 2011-02-14 | 2011-03-07 | 111 | 1023.75d | 22d |  | LBL_Material [400%]; LBL_Machinist Sr. [33.3%]; LBL_Mech Tech 4 [26.7%] | 72h | 12,760.81 | ܁- |
| 113 | 1.2.1.3.4 | **Low Mass Cart Prototype** |  | 130d | 2011-01-04 | 2011-07-08 |  | 1001.75d |  |  |  | 532h | 71,392.85 | ܁- |
| 114 | 1.2.1.3.4.1 | **Cart Prototype Fabrication (1/2 Detector)** |  | 65d | 2011-01-04 | 2011-04-06 |  | 1001.75d |  |  |  | 284h | 39,801.84 | ܁- |
| 115 | 1.2.1.3.4.1.1 | Cart Component Fabrication |  | 4w | 2011-01-04 | 2011-02-01 |  | 1001.75d | 0d | start no earlier than 2011-01-04 | LBL_Material [300%]; LBL_Machinist Jr. [50%] | 80h | 11,999.35 | ܁- |
| 116 | 1.2.1.3.4.1.2 | Intermediate Support Fabrication |  | 1w | 2011-02-02 | 2011-02-08 | 115 | 1001.75d | 0d |  | LBL_Material; LBL_Mech Tech 4 [120%] | 48h | 6,186.68 | ܁- |
| 117 | 1.2.1.3.4.1.3 | Bond Tooling Fabrication |  | 4w | 2011-02-09 | 2011-03-09 | 116 | 1001.75d | 0d |  | LBL_Material; LBL_Machinist Jr. [13%]; LBL_Mech Tech 4 [40%] | 72h | 8,711.84 | ܁- |
| 118 | 1.2.1.3.4.1.4 | Bulkhead Kinematic Mockup |  | 4w | 2011-03-10 | 2011-04-06 | 117 | 1001.75d | 0d |  | LBL_Material [350%]; LBL_Machinist Jr. [15%]; LBL_Mech Tech 4 [37.5%] | 84h | 12,903.98 | ܁- |
| 119 | 1.2.1.3.4.2 | **Cart Fabrication (Engineering Run)** |  | 45d | 2011-05-05 | 2011-07-08 |  | 1001.75d |  |  |  | 248h | 31,591.01 | ܁- |
| 120 | 1.2.1.3.4.2.1 | Cart Component Fabrication |  | 4w | 2011-05-05 | 2011-06-02 | 109 | 1001.75d | 0d |  | LBL_Material [300%]; LBL_Machinist Jr. [50%] | 80h | 11,999.35 | ܁- |
| 121 | 1.2.1.3.4.2.2 | Intermediate Support Fabrication |  | 1w | 2011-06-03 | 2011-06-09 | 120 | 1001.75d | 0d |  | LBL_Material; LBL_Mech Tech 4 [120%] | 48h | 6,186.68 | ܁- |
| 122 | 1.2.1.3.4.2.3 | Bulkhead Prototype Fabrication (Engineering Run) |  | 4w | 2011-06-10 | 2011-07-08 | 121 | 1001.75d | 0d |  | LBL_Material [64%]; LBL_Machinist Jr. [37.5%]; LBL_Mech Tech 4 [37.5%] | 120h | 13,404.99 | ܁- |
| 123 | 1.2.1.3.5 | **Production Insertion Mechanism** |  | 92d | 2011-10-04 | 2012-02-13 |  | 815d |  |  |  | 320h | 44,268.52 | ܁- |
| 124 | 1.2.1.3.5.1 | **Cart Fabrication (First Unit)** |  | 30d | 2011-10-04 | 2011-11-14 |  | 815d |  |  |  | 160h | 22,134.26 | ܁- |
| 125 | 1.2.1.3.5.1.1 | Cart Rail Rider Fabrication |  | 80h | 2011-10-04 | 2011-10-17 |  | 815d | 0d | start no earlier than 2011-10-04 | LBL_Material; LBL_Machinist Jr. [50%] | 40h | 5,568.79 | ܁- |
| 126 | 1.2.1.3.5.1.2 | Card Cage Fabrication |  | 80h | 2011-10-18 | 2011-10-31 | 125 | 815d | 0d |  | LBL_Material [200%]; LBL_Machinist Jr. [50%] | 40h | 6,755.63 | ܁- |
| 127 | 1.2.1.3.5.1.3 | Intermediate Support Fabrication |  | 48h | 2011-11-01 | 2011-11-08 | 126 | 815d | 0d |  | LBL_Material; LBL_Mech Tech 4 | 48h | 6,360.64 | ܁- |
| 128 | 1.2.1.3.5.1.4 | Bonded Assembly of 1/2 cart |  | 32h | 2011-11-09 | 2011-11-14 | 127 | 815d | 0d |  | LBL_Mech Tech 4 | 32h | 3,449.2 | ܁- |

| ID | WBS | Task | Type | Duration | Start | Finish | Predecessors | Total slack | Free slack | Constraint | Resources | Work | Cost | Participating Institutions |
| --- | --- | --- | --- | --- | --- | --- | --- | --- | --- | --- | --- | --- | --- | --- |
| 129 | 1.2.1.3.5.2 | **Cart Fabrication (Second Unit)** |  | 30d | 2012-01-02 | 2012-02-13 |  | 878d |  |  |  | 160h | 22,134.26 | ܁- |
| 130 | 1.2.1.3.5.2.1 | Cart Rail Rider Fabrication |  | 80h | 2012-01-02 | 2012-01-13 | 136 | 878d | 0d |  | LBL_Material; LBL_Machinist Jr. [50%] | 40h | 5,568.79 | ܁- |
| 131 | 1.2.1.3.5.2.2 | Card Cage Fabrication |  | 80h | 2012-01-17 | 2012-01-30 | 130 | 878d | 0d |  | LBL_Material [200%]; LBL_Machinist Jr. [50%] | 40h | 6,755.63 | ܁- |
| 132 | 1.2.1.3.5.2.3 | Intermediate Support Fabrication |  | 48h | 2012-01-31 | 2012-02-07 | 131 | 878d | 0d |  | LBL_Material; LBL_Mech Tech 4 | 48h | 6,360.64 | ܁- |
| 133 | 1.2.1.3.5.2.4 | Bonded Assembly of 1/2 cart |  | 32h | 2012-02-08 | 2012-02-13 | 132 | 878d | 0d |  | LBL_Mech Tech 4 | 32h | 3,449.2 | ܁- |
| 134 | 1.2.1.3.6 | **Production Patch Panel Bulkhead** |  | 94d | 2011-11-15 | 2012-03-29 |  | 878d |  |  |  | 608h | 75,198.59 | ܁- |
| 135 | 1.2.1.3.6.1 | Hardware (Bearings, Fasteners et-al) |  | 16h | 2011-11-15 | 2011-11-16 | 128 | 878d | 0d |  | LBL_Material [250%]; LBL_Mech Tech 4 | 16h | 4,691.71 | ܁- |
| 136 | 1.2.1.3.6.2 | Bulkhead Fabrication (1st Copy) |  | 240h | 2011-11-17 | 2011-12-30 | 135 | 878d | 0d |  | LBL_Material [150%]; LBL_Machinist Jr. [20%]; LBL_Mech Tech 4 | 288h | 32,907.58 | ܁- |
| 137 | 1.2.1.3.6.3 | Hardware (Bearings, Fasteners et-al) |  | 16h | 2012-02-14 | 2012-02-15 | 133 | 878d | 0d |  | LBL_Material [250%]; LBL_Mech Tech 4 | 16h | 4,691.71 | ܁- |
| 138 | 1.2.1.3.6.4 | Bulkhead Fabrication (2nd Copy) |  | 240h | 2012-02-16 | 2012-03-29 | 137 | 878d |  |  | LBL_Material [150%]; LBL_Machinist Jr. [20%]; LBL_Mech Tech 4 | 288h | 32,907.58 | ܁- |
| 139 | 1.2.1.4 | PXL Engineering Effort (post CD 1) |  | 142d | 2010-08-31 | 2011-03-24 | 29 | 1136d |  |  | LBL_Mech Eng Sr. [50%] | 568h | 81,950.09 | ܁- |
| 140 | 1.2.1.5 | PXL Engineering Effort (post CD 2/3) |  | 791d | 2011-03-24 | 2014-05-14 | 20 | 346d |  |  | LBL_Mech Eng Sr. [50%]; LBL_Mech Engineer [30%] | 5062.4h | 644,233.16 | ܁- |
| 141 | 1.2.2 | **Pixel Electronics** |  | 933d? | 2010-08-31 | 2014-05-15 |  | 345d |  |  |  | 26667.8h | 3,261,122 | ܁- |
| 142 | 1.2.2.1 | PXL Redirected Effort (post CD 1) |  | 142d | 2010-08-31 | 2011-03-24 | 29 | 345d | 0d |  | LBL_Engineer Redirected | 1136h | 130,068.44 | ܁- |
| 143 | 1.2.2.2 | PXL Redirected Effort (post CD 2/3) |  | 791d | 2011-03-25 | 2014-05-15 | 30, 142 | 345d |  | finish no earlier than 2014-05-15 | LBL_Engineer Redirected | 6328h | 767,109.94 | ܁- |
| 144 | 1.2.2.3 | **Phase-2 Sensor** |  | 407d | 2010-08-31 | 2012-04-09 |  | 828d |  |  |  | 1820h | 169,992.56 |  |
| 145 | 1.2.2.3.1 | **Proto Det Production** |  | 407d | 2010-08-31 | 2012-04-09 |  | 828d |  |  |  | 1820h | 169,992.56 |  |
| 146 | 1.2.2.3.1.1 | Probe testing station development |  | 80d | 2010-08-31 | 2010-12-22 | 29 | 828d | 0d |  | LBL_Machinist Sr. [8.8%]; LBL_Scientist Contributed [6.2%]; LBL_Elec Eng Sr [2.5%]; LBL_Postdoc Contributed [31.2%]; LBL_Mech Tech 4 [8.8%]; LBL_Material [1010%] | 368h | 26,275.79 |  |
| 147 | 1.2.2.3.1.2 | Phase-2 design Validation (beam tests) |  | 100d | 2011-03-02 | 2011-07-21 | 146SS+20d | 1053d |  | start no earlier than 2011-03-02 | LBL_Material [1520%]; LBL_Machinist Sr. [8%]; LBL_Elec Eng Sr [5%]; LBL_Postdoc Contributed [56%]; LBL_Mech Tech 4 [9%] | 624h | 38,296.95 | ܁- |
| 148 | 1.2.2.3.1.3 | Probe test Ph-2 development |  | 40d | 2010-12-23 | 2011-02-21 | 146, 192 | 828d | 67d |  | LBL_Material [300%]; LBL_Postdoc Contributed [25%]; LBL_Scientist Contributed [12.5%] | 120h | 3,490.72 |  |
| 149 | 1.2.2.3.1.4 | Proto Det Sensor Order |  | 1d | 2011-05-27 | 2011-05-27 | 148, 160SS+30d | 761d | 0d |  | LBL_Material [3600%]; LBL_Postdoc Contributed | 8h | 41,888.66 |  |
| 150 | 1.2.2.3.1.5 | Proto Det Sensor Receive | milestone | 0d | 2011-08-02 | 2011-08-02 | 149FS+45d | 779d | 18d |  |  |  |  |  |
| 151 | 1.2.2.3.1.6 | Proto Det Sensor Testing and Validation |  | 63d | 2011-05-31 | 2011-08-26 | 148, 149, 195 | 761d | 0d |  | LBL_Material; LBL_Scientist Contributed [7.9%]; LBL_Postdoc Contributed [15.9%] | 120h | 1,163.57 |  |
| 152 | 1.2.2.3.1.7 | Proto Det Dicing and Thinning |  | 15d | 2011-08-29 | 2011-09-19 | 151, 150 | 761d | 81d |  | LBL_Material [1640%]; LBL_Postdoc Contributed [60%] | 72h | 19,082.61 |  |
| 153 | 1.2.2.3.1.8 | Proto Det Production Probe Testing |  | 60d | 2012-01-13 | 2012-04-09 | 152 | 680d | 0d | start no earlier than 2012-01-13 | LBL_Material [875%]; LBL_Machinist Sr. [8.3%]; LBL_Elec Eng Sr [25%]; LBL_Postdoc Contributed [78.3%]; LBL_Elec Tech Sr. [8.3%]; LBL_Mech Tech 4 [33.3%] | 508h | 39,794.23 |  |

| ID | WBS | Task | Type | Duration | Start | Finish | Predecessors | Total slack | Free slack | Constraint | Resources | Work | Cost |
| --- | --- | --- | --- | --- | --- | --- | --- | --- | --- | --- | --- | --- | --- |
| 154 | 1.2.2.4 | **PXL Sensor** |  | 511d | 2010-12-07 | 2012-12-12 |  | 528.88d |  |  |  | 2669.85h | 869,704.38 |
| 155 | 1.2.2.4.1 | PXL sensor review |  | 5d | 2010-12-07 | 2010-12-13 |  | 534.88d | 0d | start no earlier than 2010-12-07 | LBL_Travel [150%]; LBL_Scientist Contributed; LBL_Postdoc Contributed | 80h | 1,872.58 |
| 156 | 1.2.2.4.2 | **PXL Sensor Prototype** |  | 334d | 2010-12-22 | 2012-04-17 |  | 528.88d |  |  |  | 1345.85h | 408,646.52 |
| 157 | 1.2.2.4.2.1 | Latch Up testing |  | 78d | 2010-12-22 | 2011-04-14 | 155 | 528.88d | 0d | start no earlier than 2010-12-22 | LBL_Material [250%]; LBL_Postdoc Contributed [36.3%]; LBL_Elec Tech Sr. [7%] | 160h | 4,517.22 |
| 158 | 1.2.2.4.2.2 | PXL Final Sensor Prototype 1 Order |  | 1d | 2011-01-04 | 2011-01-04 | 155FS+13d | 553.88d | 0d |  | LBL_Material [14410%] |  | 167,671.01 |
| 159 | 1.2.2.4.2.3 | PXL Final Sensor Prototype 1 Receive | milestone | 0d | 2011-03-10 | 2011-03-10 | 158FS+45d | 553.88d | 25d |  |  |  |  |
| 160 | 1.2.2.4.2.4 | PXL Prototype 1 Test |  | 90d | 2011-04-15 | 2011-08-22 | 193, 157, 159 | 528.88d | 0d |  | LBL_Material [2640%]; LBL_Machinist Sr. [2.8%]; LBL_Elec Eng Sr [9.4%]; LBL_Postdoc Contributed [101.1%]; LBL_Elec Tech Sr. [38.9%]; LBL_Mech Tech 4 [2.8%] | 1116h | 63,241.51 |
| 161 | 1.2.2.4.2.5 | Respin Sensor Design 2 |  | 100d | 2011-08-23 | 2012-01-12 | 160, 157 | 528.88d | 0d |  | LBL_Postdoc Contributed [5%] | 40h |  |
| 162 | 1.2.2.4.2.6 | PXL Final Sensor Prototype 2 Order |  | 1d | 2012-01-13 | 2012-01-13 | 161 | 528.88d | 0d |  | LBL_Material [14410%] |  | 171,024.43 |
| 163 | 1.2.2.4.2.7 | PXL Final Sensor Prototype 2 Receive | milestone | 0d | 2012-03-20 | 2012-03-20 | 162FS+45d | 528.88d | 0d |  |  |  |  |
| 164 | 1.2.2.4.2.8 | PXL Final Sensor Prototype 2 Test |  | 20d | 2012-03-21 | 2012-04-17 | 163, 195 | 528.88d | 0d |  | LBL_Material [150%]; LBL_Postdoc Contributed [14.9%]; LBL_Elec Tech Sr. [3.7%] | 29.85h | 2,192.34 |
| 165 | 1.2.2.4.3 | **PXL Sensor Production** |  | 166d | 2012-04-18 | 2012-12-12 |  | 528.88d |  |  |  | 1244h | 459,185.28 |
| 166 | 1.2.2.4.3.1 | PXL Final Sensor Order |  | 1d | 2012-04-18 | 2012-04-18 | 164 | 528.88d | 0d |  | LBL_Material [26880%] |  | 319,024.07 |
| 167 | 1.2.2.4.3.2 | PXL Final Sensor Receive | milestone | 0d | 2012-06-21 | 2012-06-21 | 166FS+45d | 528.88d | 0d |  |  |  |  |
| 168 | 1.2.2.4.3.3 | PXL Testing and Validation |  | 20d | 2012-06-22 | 2012-07-20 | 167 | 528.88d | 0d |  | LBL_Material [150%]; LBL_Postdoc Contributed [50%]; LBL_Elec Tech Sr. [12.5%] | 100h | 3,160.71 |
| 169 | 1.2.2.4.3.4 | PXL Production Dicing and Thinning |  | 20d | 2012-07-23 | 2012-08-17 | 167, 168 | 528.88d | 0d |  | LBL_Material [4020%]; LBL_Postdoc Contributed [15%]; LBL_Mech Tech 4 [10%] | 40h | 49,435.79 |
| 170 | 1.2.2.4.3.5 | PXL Probe Testing |  | 90d | 2012-08-03 | 2012-12-12 | 169SS+10d | 528.88d | 0d |  | LBL_Material [1260%]; LBL_Machinist Sr. [8.9%]; LBL_Elec Eng Sr [33.9%]; LBL_Postdoc Contributed [58.3%]; LBL_Mech Engineer; LBL_Mech Eng Sr.; LBL_Elec Tech Sr. [41.1%]; LBL_Mech Tech 4 [11.1%] | 1104h | 87,564.72 |
| 171 | 1.2.2.5 | **Ladder Cable** |  | 415d | 2010-11-10 | 2012-07-02 |  | 581.88d |  |  |  | 2148h | 134,357.12 |
| 172 | 1.2.2.5.1 | **Infrastructure Test Cable** |  | 113d | 2010-11-10 | 2011-04-25 |  | 603.88d |  |  |  | 392h | 17,593.42 |
| 173 | 1.2.2.5.1.1 | Cable prototype - infrastructure |  | 113d | 2010-11-10 | 2011-04-25 | 192 | 603.88d | 22d |  | LBL_Material [370%]; LBL_Elec Eng Sr [6.8%]; LBL_Postdoc Contributed [47.2%]; LBL_Elec Tech Sr. [8.6%] | 392h | 17,593.42 |
| 174 | 1.2.2.5.2 | **Prototype Ladder Cable (FR-4)** |  | 100d | 2011-05-26 | 2011-10-17 |  | 581.88d |  |  |  | 384h | 23,136.19 |
| 175 | 1.2.2.5.2.1 | Cable prototype - FR4/Cu |  | 100d | 2011-05-26 | 2011-10-17 | 173 | 581.88d | 0d | start no earlier than 2011-05-26 | LBL_Material [670%]; LBL_Elec Eng Sr [5%]; LBL_Postdoc Contributed [37.5%]; LBL_Elec Tech Sr. [37.5%] | 384h | 23,136.19 |
| 176 | 1.2.2.5.3 | **Ladder Cable (Kapton + Cu conductor)** |  | 80d | 2011-10-18 | 2012-02-09 |  | 581.88d |  |  |  | 404h | 30,496.74 |
| 177 | 1.2.2.5.3.1 | PH-1 Cable Prototype - Kapton/Cu |  | 80d | 2011-10-18 | 2012-02-09 | 175 | 581.88d | 0d |  | LBL_Material [1020%]; LBL_Elec Eng Sr [10%]; LBL_Postdoc Contributed [31.9%]; LBL_Elec Tech Sr. [21.2%] | 404h | 30,496.74 |

| ID | WBS | Task | Type | Duration | Start | Finish | Predecessors | Total slack | Free slack | Constraint | Resources | Work | Cost | Participating Institutions |
| --- | --- | --- | --- | --- | --- | --- | --- | --- | --- | --- | --- | --- | --- | --- |
| 178 | 1.2.2.5.4 | **Ladder Cable PXL sensor** |  | 100d | 2012-02-10 | 2012-07-02 |  | 581.88d |  |  |  | 968h | 63,130.77 |  |
| 179 | 1.2.2.5.4.1 | PXL Cable Prototype - Kapton/Cu |  | 50d | 2012-02-10 | 2012-04-20 | 155, 173, 177 | 581.88d | 0d |  | LBL_Material [400%]; LBL_Elec Eng Sr [22%]; LBL_Postdoc Contributed [42%]; LBL_Elec Tech Sr. [20%] | 336h | 22,649.52 |  |
| 180 | 1.2.2.5.4.2 | PXL Cable Prototype - Kapton/AI |  | 50d | 2012-04-23 | 2012-07-02 | 179 | 581.88d | 0d |  | LBL_Material [870%]; LBL_Elec Eng Sr [32%]; LBL_Postdoc Contributed [82%]; LBL_Elec Tech Sr. [44%] | 632h | 40,481.26 |  |
| 181 | 1.2.2.6 | **Proto Det Ladder Assembly** |  | 125d? | 2012-04-10 | 2012-10-04 | 177 | 680d |  |  |  | 2198h | 161,119.32 |  |
| 182 | 1.2.2.6.1 | **Ladder Mechanical/Electrical prototypes** |  | 125d? | 2012-04-10 | 2012-10-04 |  | 680d |  |  |  | 2198h | 161,119.32 |  |
| 183 | 1.2.2.6.1.1 | Proto Det Ladder Production |  | 31d | 2012-04-10 | 2012-05-22 | 153, 177 | 680d | 0d |  |  |  |  |  |
| 184 | 1.2.2.6.1.2 | Proto Det Ladder production - Mech prototypes |  | 39d | 2012-04-10 | 2012-06-04 | 183SS | 746d | 0d |  | LBL_Material [510%]; LBL_Machinist Sr. [35.9%]; LBL_Scientist Contributed [51.3%]; LBL_Postdoc Contributed [59%]; LBL_Mech Tech 4 [59%] | 640h | 39,607.23 |  |
| 185 | 1.2.2.6.1.3 | Proto Det Ladder production - Elec prototypes |  | 5d | 2012-04-10 | 2012-04-16 | 183SS | 780d | 34d |  | LBL_Material; LBL_Machinist Sr. [60%]; LBL_Elec Eng Sr [40%]; LBL_Postdoc Contributed; LBL_Elec Tech Sr. | 120h | 9,139.01 |  |
| 186 | 1.2.2.6.1.4 | Proto Det Ladder production - Assembly |  | 85d | 2012-06-04 | 2012-10-03 | 183SS, 184, 185 | 746d | 0d |  | LBL_Material [2350%]; LBL_Machinist Sr. [1.2%]; LBL_Scientist Contributed [11.8%]; LBL_Elec Eng Sr [1.8%]; LBL_Postdoc Contributed [45.9%]; LBL_Mech Engineer; LBL_Mech Eng Sr.; LBL_Elec Tech Sr.; LBL_Mech Tech 4 [27.9%] | 1284h | 98,206.95 |  |
| 187 | 1.2.2.6.1.5 | First Ladders ready for sector assembly | milestone | 1d? | 2012-06-26 | 2012-06-26 | 186SS+15d | 746d | 0d |  |  |  |  |  |
| 188 | 1.2.2.6.1.6 | Sector fabrication and metrology |  | 70d | 2012-06-27 | 2012-10-04 | 183SS+15d, 187 | 746d |  |  |  |  |  |  |
| 189 | 1.2.2.6.1.7 | Sector/Detector Testing |  | 45d | 2012-06-14 | 2012-08-16 | 183FS+15d | 680d | 10d |  | LBL_Material [500%]; LBL_Machinist Sr. [8.9%]; LBL_Scientist Contributed [8.9%]; LBL_Postdoc Contributed [13.9%]; LBL_Mech Tech 4 [11.1%] | 154h | 14,166.13 |  |
| 190 | 1.2.2.7 | **Read-out Electronics** |  | 606d | 2010-09-02 | 2013-01-29 |  | 583.88d |  |  |  | 5689.9h | 603,509.06 |  |
| 191 | 1.2.2.7.1 | **RDO Board** |  | 467d | 2010-09-02 | 2012-07-06 |  | 583.88d |  |  |  | 3212h | 238,797.1 |  |
| 192 | 1.2.2.7.1.1 | RDO Development - individual sensor RDO PH-2 |  | 9d | 2010-10-28 | 2010-11-09 | 194 | 603.88d | 0d |  | LBL_Material [500%]; LBL_Elec Eng Sr [11.1%]; LBL_Postdoc Contributed | 80h | 6,910.58 |  |
| 193 | 1.2.2.7.1.2 | RDO Development - Individual sensors RDO - PXL sensor |  | 60d | 2010-10-28 | 2011-01-26 | 194 | 583.88d | 55d |  | LBL_Elec Eng Sr [29.2%]; LBL_Postdoc Contributed [54.2%] | 400h | 19,122.36 | ܁- |
| 194 | 1.2.2.7.1.3 | RDO Motherboard Prototype Test |  | 40d | 2010-09-02 | 2010-10-27 |  | 583.88d | 0d | start no earlier than 2010-09-02 | LBL_Elec Eng Sr [32.5%]; LBL_Postdoc Contributed [62.5%] | 304h | 13,987.97 | ܁- |
| 195 | 1.2.2.7.1.4 | RDO development - ladder RDO - PH-2 |  | 93d | 2010-11-10 | 2011-03-28 | 192 | 777.88d | 44d |  | LBL_Elec Eng Sr [21.5%]; LBL_Postdoc Contributed [45.7%] | 500h | 21,854.13 | ܁- |
| 196 | 1.2.2.7.1.5 | RDO Development - Ladder RDO - PXL sensor |  | 63d | 2011-08-25 | 2011-11-22 | 155FS+20d | 966d |  | start no earlier than 2011-08-25 | LBL_Elec Eng Sr [51.6%]; LBL_Postdoc Contributed [99.2%] | 760h | 36,138.66 | ܁- |
| 197 | 1.2.2.7.1.6 | RDO V-6 MB design |  | 10d | 2011-01-03 | 2011-01-31 | 194 | 780.67d | 0d | start no earlier than 2011-01-03 | LBL_Material [700%]; LBL_Elec Eng Sr; LBL_Postdoc Contributed | 160h | 19,072.08 | ܁- |
| 198 | 1.2.2.7.1.7 | RDO V-6 MB fabricate |  | 10d | 2011-02-01 | 2011-02-14 | 197 | 780.67d | 96d |  | LBL_Material [3000%]; LBL_Elec Eng Sr [10%]; LBL_Postdoc Contributed; LBL_Elec Tech Sr. | 168h | 41,360.87 | ܁- |
| 199 | 1.2.2.7.1.8 | RDO V-6 MB test |  | 75d | 2011-07-01 | 2011-10-17 | 198 | 684.67d | 0d | start no earlier than 2011-07-01 | LBL_Elec Eng Sr [22.7%]; LBL_Postdoc Contributed [40%] | 376h | 18,657.74 | ܁- |
| 200 | 1.2.2.7.1.9 | (iteration) RDO V-6 MB design |  | 45d | 2011-11-08 | 2012-01-11 | 199FS+15d | 684.67d | 0d |  | LBL_Material [500%]; LBL_Postdoc Contributed [37%] | 80h | 5,934.23 | ܁- |
| 201 | 1.2.2.7.1.10 | (iteration) RDO V-6 MB fabricate |  | 58.33d | 2012-01-12 | 2012-04-05 | 200 | 684.67d | 24.67d |  | LBL_Material [3000%]; LBL_Elec Eng Sr [2.9%]; LBL_Postdoc Contributed [28.6%]; LBL_Elec Tech Sr. [28.6%] | 168h | 42,252.62 | ܁- |
| 202 | 1.2.2.7.1.11 | (iteration) RDO V-6 MB test |  | 40d | 2012-05-10 | 2012-07-06 | 201 | 660d | 0d | start no earlier than 2012-05-10 | LBL_Elec Eng Sr [30%]; LBL_Postdoc Contributed [37.5%] | 216h | 13,505.85 | ܁- |

| ID | WBS | Task | Type | Duration | Start | Finish | Predecessors | Total slack | Free slack | Constraint | Resources | Work | Cost | Participating Institutions |
| --- | --- | --- | --- | --- | --- | --- | --- | --- | --- | --- | --- | --- | --- | --- |
| 203 | 1.2.2.7.2 | **RDO production (Proto Det)** |  | 142d | 2012-02-10 | 2012-08-30 |  | 660d |  |  |  | 612h | 134,811.95 | ܁- |
| 204 | 1.2.2.7.2.1 | RDO production (Proto Det) - RDO Board production |  | 39d | 2012-07-06 | 2012-08-30 | 202 | 660d | 0d |  | LBL_Material [6800%]; LBL_Machinist Sr. [5.1%]; LBL_Elec Eng Sr [2.6%]; LBL_Postdoc Contributed [37.2%]; LBL_Mech Engineer; LBL_Elec Tech Sr. [56.4%]; LBL_Mech Tech 4 [5.1%] | 332h | 97,663.68 | ܁- |
| 205 | 1.2.2.7.2.2 | RDO production (Proto Det) - Motherboard Testing |  | 5d | 2012-02-10 | 2012-02-16 | 177 | 769d | 0d |  | LBL_Postdoc Contributed | 40h |  | ܁- |
| 206 | 1.2.2.7.2.3 | RDO production (Proto Det) - PCs |  | 41d | 2012-02-10 | 2012-04-09 | 177 | 706d | 0d |  | LBL_Material [2650%]; LBL_Postdoc Contributed [24.4%] | 80h | 31,451.41 | ܁- |
| 207 | 1.2.2.7.2.4 | RDO production (Proto Det) - Control PCs |  | 60d | 2012-04-03 | 2012-06-26 | 206FS-5d | 706d | 0d |  | LBL_Material [480%]; LBL_Postdoc Contributed [33.3%] | 160h | 5,696.86 | ܁- |
| 208 | 1.2.2.7.3 | **RDO production final system** |  | 151d | 2012-04-10 | 2012-11-09 | 195 | 660d | 66.12d |  |  | 540h | 136,422.97 |  |
| 209 | 1.2.2.7.3.1 | RDO production final system - Motherboard |  | 40d | 2012-08-31 | 2012-10-26 | 204 | 670d |  |  | LBL_Material [7800%]; LBL_Postdoc Contributed [18.8%] | 60h | 93,545.97 |  |
| 210 | 1.2.2.7.3.2 | RDO production final system - firmware and software |  | 50d | 2012-08-31 | 2012-11-09 | 204 | 660d |  |  | LBL_Elec Eng Sr [10%]; LBL_Postdoc Contributed [50%] | 240h | 5,728.73 |  |
| 211 | 1.2.2.7.3.3 | RDO production final system - PCs |  | 41d | 2012-04-10 | 2012-06-06 | 206 | 770d |  |  | LBL_Material [2650%]; LBL_Postdoc Contributed [24.4%] | 80h | 31,451.41 |  |
| 212 | 1.2.2.7.3.4 | RDO production final system - Control PC system |  | 50d | 2012-06-27 | 2012-09-06 | 207 | 706d |  |  | LBL_Material [480%]; LBL_Postdoc Contributed [40%] | 160h | 5,696.86 |  |
| 213 | 1.2.2.7.4 | **Mass Termination Board** |  | 301d | 2011-02-09 | 2012-04-16 |  | 766d |  |  |  | 829.9h | 73,656.13 | ܁- |
| 214 | 1.2.2.7.4.1 | (iteration) MTB design/fab |  | 83.33d | 2011-02-09 | 2011-06-08 |  | 940.67d | 171.67d | start no earlier than 2011-02-09 | LBL_Material [1653%]; LBL_Postdoc Contributed [36%]; LBL_Elec Tech Sr. [48.5%] | 338h | 32,234.17 | ܁- |
| 215 | 1.2.2.7.4.2 | RDO production (Proto Det) - Mass termination testing |  | 22d | 2012-02-10 | 2012-03-13 | 214, 205SS | 769d | 3d |  | LBL_Postdoc Contributed [98.8%] | 173.9h |  |  |
| 216 | 1.2.2.7.4.3 | RDO Production - (Proto Det) Mass Termination Boards |  | 10d | 2012-03-05 | 2012-03-16 |  | 766d | 0d | start no earlier than 2012-03-03 | LBL_Postdoc Contributed [40%]; LBL_Material [780%]; LBL_Elec Tech | 92h | 14,520.31 |  |
| 217 | 1.2.2.7.4.4 | RDO production final system - Mass Termination Board |  | 21d | 2012-03-19 | 2012-04-16 | 215, 216 | 766d | 96d |  | LBL_Material [1278%]; LBL_Postdoc Contributed [33.3%]; LBL_Elec Tech Sr. [101.2%] | 226h | 26,901.65 |  |
| 218 | 1.2.2.7.5 | **Install Proto Det** |  | 100d | 2012-08-31 | 2013-01-29 |  | 670d |  |  |  | 496h | 19,820.92 |  |
| 219 | 1.2.2.7.5.1 | Installation of Proto Det |  | 100d | 2012-08-31 | 2013-01-29 | 312, 313, 314, 204, 205, 206, 207, 310, 298, 217, 189 | 670d |  |  | LBL_Material [700%]; LBL_Machinist Sr. [3.3%]; LBL_Scientist Contributed [38.3%]; LBL_Postdoc Contributed [36.7%]; LBL_Elec Tech Sr. [20%]; LBL_Mech Tech 4 [5%] | 496h | 19,820.92 |  |
| 220 | 1.2.2.8 | **PXL Sensor Ladder Production** |  | 283.12d | 2012-07-03 | 2013-08-20 |  | 528.88d |  |  |  | 4678h | 425,261.19 |  |
| 221 | 1.2.2.8.1 | PXL Cable Production - Kapton/AI |  | 60d | 2012-07-03 | 2012-09-26 | 180 | 581.88d | 53d |  | LBL_Material [4000%]; LBL_Postdoc Contributed [6.2%]; LBL_Elec Tech Sr. [20.8%] | 130h | 54,376.03 |  |
| 222 | 1.2.2.8.2 | PXL Ladder Production |  | 6d | 2012-12-13 | 2012-12-20 | 170, 221 | 528.88d | 0d |  | LBL_Material [400%]; LBL_Machinist Sr. [16.7%]; LBL_Scientist Contributed [50%]; LBL_Postdoc Contributed; LBL_Elec Tech Sr. [33.3%]; LBL_Mech Tech 4 [50%] | 120h | 9,658.57 |  |
| 223 | 1.2.2.8.3 | PXL Ladder Production - Mech |  | 10d | 2012-12-13 | 2012-12-28 | 222SS | 529d | 0.12d |  | LBL_Material [600%]; LBL_Machinist Sr. [60%]; LBL_Scientist Contributed; LBL_Postdoc Contributed [50%]; LBL_Mech Tech 4 [70%] | 224h | 19,544.82 |  |
| 224 | 1.2.2.8.4 | PXL Ladder Production - Elec |  | 5d | 2012-12-13 | 2013-01-02 | 222SS | 528.88d | 0d |  | LBL_Material [250%]; LBL_Postdoc Contributed | 40h | 3,029.42 |  |
| 225 | 1.2.2.8.5 | PXL Ladder Production - Assembly |  | 160d | 2013-01-02 | 2013-08-20 | 222SS, 223, 224 | 528.88d | 0d |  | LBL_Material [4750%]; LBL_Machinist Sr. [0.6%]; LBL_Scientist Contributed [9.4%]; LBL_Elec Eng Sr [0.3%]; LBL_Postdoc Contributed [35%]; LBL_Mech Engineer [1.9%]; LBL_Elec Tech Sr. [201.7%]; LBL_Mech Tech 4 [38.9%] | 3684h | 300,149.33 |  |
| 226 | 1.2.2.8.6 | First Ladders Ready for Sector Fabrication | milestone | 1d | 2013-01-24 | 2013-01-25 | 225SS+15d | 593.88d | 0d |  |  |  |  |  |
| 227 | 1.2.2.8.7 | Sector/Detector Testing |  | 20d | 2013-02-21 | 2013-03-22 | 208, 222SS+20d, 226SS+20d | 593.88d | 0d |  | LBL_Material [1000%]; LBL_Machinist Sr. [57.1%]; LBL_Scientist Contributed [57.1%]; LBL_Postdoc Contributed [89.3%]; LBL_Mech Tech 4 [71.4%] | 440h | 36,343.01 |  |
| 228 | 1.2.2.8.8 | PXL Detector to BNL | milestone | 0d | 2013-04-19 | 2013-04-19 | 227SS+40d, 312, 313, 314, 299, 300, 301 | 593.88d | 0d |  |  |  |  |  |
| 229 | 1.2.2.8.9 | Test and Install PXL at STAR |  | 20d | 2013-04-19 | 2013-05-17 | 228 | 593.88d | 65d |  | LBL_Elec Tech Sr.; LBL_Postdoc Contributed [12.5%]; LBL_Elec Eng Sr | 40h | 2,159.99 |  |
| 230 | 1.2.2.8.10 | Deliver 2nd Detector + Spare Ladders | milestone | 0d | 2013-08-20 | 2013-08-20 | 163, 227, 225, 229 | 528.88d |  |  |  |  |  |  |

| ID | WBS | Task | Duration | Start | Finish | Predecessors | Total slack | Free slack | Constraint | Resources | Work | Cost | Participating Institutions |
| --- | --- | --- | --- | --- | --- | --- | --- | --- | --- | --- | --- | --- | --- |
| 231 | 1.2.3 | **Detector Assembly** | 464d | 2011-01-14 | 2012-11-09 |  | 720d |  |  |  | 1662h | 240,385.07 | ܁- |
| 232 | 1.2.3.1 | **Final Assembly** | 464d | 2011-01-14 | 2012-11-09 |  | 720d |  |  |  | 1662h | 240,385.07 | ܁- |
| 233 | 1.2.3.1.1 | **Detector Half Enclosure** | 357d | 2011-01-14 | 2012-06-11 |  | 827d |  |  |  | 472h | 84,365.19 | ܁- |
| 234 | 1.2.3.1.1.1 | **Detector Half Enclosure (Engineering)** | 15d | 2011-01-14 | 2011-02-04 |  | 1169d |  |  |  | 184h | 30,534.97 | ܁- |
| 235 | 1.2.3.1.1.1.1 | Rail Assembly Hardware | 1w | 2011-01-14 | 2011-01-21 | 107 | 1169d | 0d |  | LBL_Material [320%]; LBL_Mech Tech 4 [40%] | 16h | 5,397.8 | ܁- |
| 236 | 1.2.3.1.1.1.2 | ITEM 80/20 Hardware | 2w | 2011-01-24 | 2011-02-04 | 235 | 1169d |  |  | LBL_Material [480%]; LBL_Machinist Jr.; LBL_Mech Tech 4 [50%] | 72h | 13,174.52 | ܁- |
| 237 | 1.2.3.1.1.1.3 | Covers/Ducting | 2w | 2011-01-24 | 2011-02-04 | 235 | 1169d |  |  | LBL_Material [160%]; LBL_Machinist Jr. [40%]; LBL_Mech Tech 4 [80%] | 96h | 11,962.64 | ܁- |
| 238 | 1.2.3.1.1.2 | **Detector Half Enclosure (Production)** | 50d | 2012-04-02 | 2012-06-11 |  | 720d |  |  |  | 288h | 53,830.22 | ܁- |
| 239 | 1.2.3.1.1.2.1 | Rail Assembly Hardware | 2w | 2012-04-02 | 2012-04-13 | 128 | 720d | 0d | start no earlier than 2012-04-02 | LBL_Material [320%]; LBL_Mech Tech 4 [50%] | 40h | 8,109.4 | ܁- |
| 240 | 1.2.3.1.1.2.2 | ITEM 80/20 Hardware | 2w | 2012-04-16 | 2012-04-27 | 239 | 857d |  |  | LBL_Material [480%]; LBL_Mech Tech 4 [50%] | 40h | 10,008.36 | ܁- |
| 241 | 1.2.3.1.1.2.3 | Covers/Ducting | 2w | 2012-04-16 | 2012-04-27 | 239 | 720d | 0d |  | LBL_Material [160%]; LBL_Mech Tech 4 [80%] | 64h | 8,797.35 | ܁- |
| 242 | 1.2.3.1.1.2.4 | Rail Assembly Hardware 2nd Copy | 2w | 2012-04-30 | 2012-05-11 | 241 | 720d | 0d |  | LBL_Material [320%]; LBL_Mech Tech 4 [50%] | 40h | 8,109.4 | ܁- |
| 243 | 1.2.3.1.1.2.5 | ITEM 80/20 Hardware 2nd Copy | 2w | 2012-05-14 | 2012-05-25 | 242 | 720d | 0d |  | LBL_Material [480%]; LBL_Mech Tech 4 [50%] | 40h | 10,008.36 | ܁- |
| 244 | 1.2.3.1.1.2.6 | Covers/Ducting 2nd Copy | 2w | 2012-05-29 | 2012-06-11 | 243 | 720d | 0d |  | LBL_Material [160%]; LBL_Mech Tech 4 [80%] | 64h | 8,797.35 | ܁- |
| 245 | 1.2.3.1.2 | **Half Detector Assembly** | 342d | 2011-07-11 | 2012-11-09 |  | 720d |  |  |  | 1190h | 156,019.89 | ܁- |
| 246 | 1.2.3.1.2.1 | **Detector Assembly (Engineering)** | 60.25d | 2011-07-11 | 2011-10-04 |  | 1001.75d |  |  |  | 414h | 50,085.38 | ܁- |
| 247 | 1.2.3.1.2.1.1 | Handling Fixtures | 2mo | 2011-07-11 | 2011-09-02 | 122 | 1001.75d | 0d |  | LBL_Material [120%]; LBL_Machinist Jr.; LBL_Mech Tech 4 [50%] | 220h | 24,521.44 | ܁- |
| 248 | 1.2.3.1.2.1.2 | D-Tube (w/sectors) Mount on Hinges | 2w | 2011-09-06 | 2011-09-19 | 247 | 1012d |  |  | LBL_Mech Tech 4 [80%] | 64h | 6,697.47 | ܁- |
| 249 | 1.2.3.1.2.1.3 | Card Cage Assembly (and Termination) | 2w | 2011-09-06 | 2011-09-19 | 247 | 1012d |  |  | LBL_Mech Tech 4 [80%] | 64h | 6,697.47 | ܁- |
| 250 | 1.2.3.1.2.1.4 | Bulkhead Assembly | 2w | 2011-09-06 | 2011-09-19 | 247 | 1001.75d | 0d |  | LBL_Mech Tech 4 [40%] | 32h | 3,348.74 | ܁- |
| 251 | 1.2.3.1.2.1.5 | **Engineering Run Shipping** | 10.25d | 2011-09-20 | 2011-10-04 |  | 1001.75d |  |  |  | 34h | 8,820.26 | ܁- |
| 252 | 1.2.3.1.2.1.5.1 | Box Fab | 10h | 2011-09-20 | 2011-09-21 | 250 | 1001.75d | 0d |  | LBL_Mech Tech 4; LBL_Material | 10h | 2,210.05 | ܁- |
| 253 | 1.2.3.1.2.1.5.2 | Packing | 16h | 2011-09-21 | 2011-09-23 | 252 | 1001.75d | 0d |  | LBL_Mech Tech 4; LBL_Machinist Jr.; LBL_Material [50%] | 24h | 3,107.02 | ܁- |
| 254 | 1.2.3.1.2.1.5.3 | Shipping Cost | 7d | 2011-09-23 | 2011-10-04 | 253 | 1001.75d |  |  | LBL_Material [300%] |  | 3,503.19 | ܁- |

| ID | WBS | Task | Duration | Start | Finish | Predecessors | Total slack | Free slack | Constraint | Resources | Work | Cost | Participating Institutions |
| --- | --- | --- | --- | --- | --- | --- | --- | --- | --- | --- | --- | --- | --- |
| 255 | 1.2.3.1.2.2 | **Detector Assembly (Production)** | 107d | 2012-06-12 | 2012-11-09 |  | 720d |  |  |  | 776h | 105,934.51 | ܁- |
| 256 | 1.2.3.1.2.2.1 | D-Tube (w/Sectors) Mount on Hinges | 128h | 2012-06-12 | 2012-07-03 | 244 | 720d | 0d |  | LBL_Mech Tech 4 | 128h | 13,796.79 | ܁- |
| 257 | 1.2.3.1.2.2.2 | Card Cage Assembly (and Termination) | 128h | 2012-07-05 | 2012-07-26 | 256 | 720d | 0d |  | LBL_Mech Tech 4 | 128h | 13,796.79 | ܁- |
| 258 | 1.2.3.1.2.2.3 | Bulkhead Assembly | 64h | 2012-07-27 | 2012-08-07 | 257 | 720d | 0d |  | LBL_Mech Tech 4 | 64h | 6,898.4 | ܁- |
| 259 | 1.2.3.1.2.2.4 | **Final Production (1) Shipping** | 13.5d | 2012-08-08 | 2012-08-27 | 258 | 720d | 0d |  |  | 68h | 18,039.33 | ܁- |
| 260 | 1.2.3.1.2.2.4.1 | Box Fab | 20h | 2012-08-08 | 2012-08-10 | 258 | 720d | 0d |  | LBL_Mech Tech 4; LBL_Material [200%] | 20h | 4,529.44 | ܁- |
| 261 | 1.2.3.1.2.2.4.2 | Packing | 32h | 2012-08-10 | 2012-08-16 | 260 | 720d | 0d |  | LBL_Mech Tech 4; LBL_Machinist Jr.; LBL_Material | 48h | 6,388.82 | ܁- |
| 262 | 1.2.3.1.2.2.4.3 | Shipping Cost | 7d | 2012-08-16 | 2012-08-27 | 261 | 720d |  |  | LBL_Material [600%] |  | 7,121.07 | ܁- |
| 263 | 1.2.3.1.2.2.5 | D-Tube (w/Sectors) Mount on Hinges Spare | 128h | 2012-08-27 | 2012-09-19 | 259 | 720d | 0d |  | LBL_Mech Tech 4 | 128h | 13,796.79 | ܁- |
| 264 | 1.2.3.1.2.2.6 | Card Cage Assembly (and Termination) Spare | 128h | 2012-09-19 | 2012-10-11 | 263 | 720d | 0d |  | LBL_Mech Tech 4 | 128h | 14,016.68 | ܁- |
| 265 | 1.2.3.1.2.2.7 | Bulkhead Assembly Spare | 64h | 2012-10-11 | 2012-10-23 | 264 | 720d | 0d |  | LBL_Mech Tech 4 | 64h | 7,105.35 | ܁- |
| 266 | 1.2.3.1.2.2.8 | **Final Production (2) Shipping** | 13.5d | 2012-10-23 | 2012-11-09 |  | 720d |  |  |  | 68h | 18,484.38 | ܁- |
| 267 | 1.2.3.1.2.2.8.1 | Box Fab | 20h | 2012-10-23 | 2012-10-25 | 265 | 720d | 0d |  | LBL_Mech Tech 4; LBL_Material [200%] | 20h | 4,643.96 | ܁- |
| 268 | 1.2.3.1.2.2.8.2 | Packing | 32h | 2012-10-26 | 2012-10-31 | 267 | 720d | 0d |  | LBL_Mech Tech 4; LBL_Machinist Jr.; LBL_Material | 48h | 6,569.8 | ܁- |
| 269 | 1.2.3.1.2.2.8.3 | Shipping Cost | 7d | 2012-11-01 | 2012-11-09 | 268 | 720d |  |  | LBL_Material [600%] |  | 7,270.62 | ܁- |
| 270 | 1.2.4 | **Infrastructure** | 583d | 2011-03-01 | 2013-06-19 |  | 571d |  |  |  | 5648.7h | 845,636.36 | ܁- |
| 271 | 1.2.4.1 | **Installation** | 583d | 2011-03-01 | 2013-06-19 |  | 571d |  |  |  | 872h | 124,340.58 | ܁- |
| 272 | 1.2.4.1.1 | **Pixel Installation In-Situ** | 583d | 2011-03-01 | 2013-06-19 |  | 571d |  |  |  | 872h | 124,340.58 | ܁- |
| 273 | 1.2.4.1.1.1 | **Work Platform** | 73d | 2011-03-01 | 2011-06-10 |  | 1081d |  |  |  | 384h | 64,056.67 | ܁- |
| 274 | 1.2.4.1.1.1.1 | **Installation Platforms (In-Situ)** | 73d | 2011-03-01 | 2011-06-10 |  | 1081d |  |  |  | 384h | 64,056.67 | ܁- |
| 275 | 1.2.4.1.1.1.1.1 | Integration into STAR | 2mo | 2011-03-01 | 2011-04-25 |  | 1081d | 0d | start no earlier than 2011-03-01 | BNL Mech. Sr. Designer (Redirect) [37.5%] | 120h | 15,352.36 |  |
| 276 | 1.2.4.1.1.1.1.2 | Fabrication | 160h | 2011-04-26 | 2011-05-23 | 275 | 1081d | 0d |  | LBL_Material [1600%]; LBL_Machinist Jr. [50%]; LBL_Mech Tech 4 | 160h | 35,497.65 |  |
| 277 | 1.2.4.1.1.1.1.3 | Hardware | 24h | 2011-05-24 | 2011-05-26 | 276 | 1081d | 0d |  | LBL_Material [200%]; BNL Mech. Sr. Designer (Redirect) | 24h | 5,397.62 |  |
| 278 | 1.2.4.1.1.1.1.4 | Installation into STAR | 80h | 2011-05-27 | 2011-06-10 | 277 | 1081d |  |  | BNL M_Tech Redirected | 80h | 7,809.05 |  |

| ID | WBS | Task | Duration | Start | Finish | Predecessors | Total slack | Free slack | Constraint | Resources | Work | Cost | Participating Institutions |
| --- | --- | --- | --- | --- | --- | --- | --- | --- | --- | --- | --- | --- | --- |
| 279 | 1.2.4.1.1.2 | **Detector Installation** | 581d | 2011-03-01 | 2013-06-17 |  | 573d |  |  |  | 360h | 45,422.13 | ܁- |
| 280 | 1.2.4.1.1.2.1 | **Pixel Insertion (In-Situ)** | 581d | 2011-03-01 | 2013-06-17 |  | 573d |  |  |  | 360h | 45,422.13 | ܁- |
| 281 | 1.2.4.1.1.2.1.1 | Hardware (Bearings, Fasteners et-al) | 16h | 2011-03-01 | 2011-03-02 | 275SS | 1114d | 0d | start no earlier than 2010-06-01 | LBL_Material [200%] |  | 2,327.15 |  |
| 282 | 1.2.4.1.1.2.1.2 | Installation (Engineering Run) | 2w | 2011-03-03 | 2011-03-16 | 281 | 1114d | 0d |  | LBL_Mech Tech 4 [50%]; BNL Mech Tech (Redirect) [50%] | 80h | 8,095.8 |  |
| 283 | 1.2.4.1.1.2.1.3 | Modifications | 1mo | 2011-03-17 | 2011-04-13 | 282 | 1114d | 0d |  | LBL_Material; LBL_Machinist Jr.; LBL_Mech Tech 4 [37.5%] | 100h | 11,696.77 |  |
| 284 | 1.2.4.1.1.2.1.4 | Hardware (Bearings, Fasteners et-al) | 16h | 2011-03-03 | 2011-03-04 | 281 | 1150d |  |  | LBL_Material [200%] |  | 2,327.15 |  |
| 285 | 1.2.4.1.1.2.1.5 | Installation (2013) | 2w | 2013-05-20 | 2013-06-03 |  | 571d | 0d | finish no earlier than 2013-06-03 | LBL_Mech Tech 4 [50%]; BNL Mech Tech (Redirect) [50%] | 80h | 8,588.83 |  |
| 286 | 1.2.4.1.1.2.1.6 | Modifications | 2w | 2013-06-04 | 2013-06-17 | 285 | 571d | 0d |  | LBL_Material; LBL_Machinist Jr.; LBL_Mech Tech 4 [75%] | 100h | 12,386.43 |  |
| 287 | 1.2.4.1.1.3 | **Service Termination** | 551d | 2011-04-14 | 2013-06-19 |  | 571d |  |  |  | 128h | 14,861.78 | ܁- |
| 288 | 1.2.4.1.1.3.1 | Design Effort As-Built Services | 24h | 2011-04-14 | 2011-04-18 | 283 | 1114d | 0d |  | BNL Mech. Sr. Designer (Redirect) | 24h | 3,070.47 |  |
| 289 | 1.2.4.1.1.3.2 | Service Termination (Engineering) | 16h | 2011-04-19 | 2011-04-20 | 288 | 1114d | 0d |  | BNL Mech Tech (Redirect); BNL Mech. Sr. Designer (Redirect); LBL_Mech Tech 4 | 48h | 5,285.3 |  |
| 290 | 1.2.4.1.1.3.3 | Design Effort As-Built Services (Final) | 24h | 2011-04-21 | 2011-04-25 | 289 | 1114d |  |  | BNL Mech. Sr. Designer (Redirect) | 24h | 3,070.47 |  |
| 291 | 1.2.4.1.1.3.4 | Service Termination (2013) | 16h | 2013-06-18 | 2013-06-19 | 286 | 571d |  |  | LBL_Mech Tech 4; BNL Mech Tech (Redirect) | 32h | 3,435.53 |  |
| 292 | 1.2.4.2 | Internal Cables (Engineering) | 6d | 2012-01-11 | 2012-01-19 |  | 927d |  | start no earlier than 2012-01-11 | LBL_Material [3560%]; LBL_Machinist Sr. [5.2%]; LBL_Mech Tech 4 [83.3%]; LBL_Postdoc Contributed [77.1%]; LBL_Elec Eng Sr [91.7%] | 123.5h | 53,059.66 |  |
| 293 | 1.2.4.3 | Internal Cables (Production) | 52d | 2012-10-10 | 2012-12-26 |  | 691d |  | start no earlier than 2012-10-10 | LBL_Material [3726%]; LBL_Machinist Sr. [1%]; LBL_Mech Tech 4; LBL_Postdoc Contributed [38%]; LBL_Elec Eng Sr [7%] | 606.4h | 95,982.49 |  |
| 294 | 1.2.4.4 | **External Cables** | 131d | 2011-08-02 | 2012-02-06 |  | 915d |  |  |  | 1080.8h | 81,582.18 |  |
| 295 | 1.2.4.4.1 | Type 1 (Bulkhead to RDO Crate) | 100d | 2011-08-02 | 2011-12-22 |  | 915d |  | start no earlier than 2011-08-02 | LBL_Material [83%]; LBL_Machinist Sr. [0.3%]; LBL_Mech Tech 4 [60.2%]; LBL_Postdoc Contributed [38.8%]; LBL_Elec Eng Sr [1.7%] | 807.2h | 54,365.91 |  |
| 296 | 1.2.4.4.2 | Type 2 (RDO to PS) | 31d | 2011-12-23 | 2012-02-06 | 295 | 915d |  | start no earlier than 2010-10-08 | LBL_Material [190%]; LBL_Mech Tech 4 [32.3%]; LBL_Postdoc Contributed [32.3%]; LBL_Elec Eng Sr [12.9%] | 192h | 15,379.95 |  |
| 297 | 1.2.4.4.3 | Data Control Fibers | 19d | 2011-12-08 | 2012-01-03 |  | 938d |  | start no earlier than 2011-12-08 | LBL_Material [466%]; LBL_Machinist Sr. [24.3%]; LBL_Postdoc Contributed [30.3%]; LBL_Elec Eng Sr [8.3%] | 81.6h | 11,836.31 |  |
| 298 | 1.2.4.5 | **Testing Cables (External)** | 191d | 2011-12-01 | 2012-08-29 |  | 671d | 1d |  |  | 566h | 94,411.63 |  |
| 299 | 1.2.4.5.1 | Type 1 (Bulkhead to RDO Crate) | 60d | 2012-06-06 | 2012-08-29 |  | 671d | 157.12d | start no earlier than 2012-06-06 | LBL_Material [3046%]; LBL_Machinist Sr. [69%]; LBL_Postdoc Contributed [26.7%]; LBL_Elec Eng Sr [3.5%] | 448h | 79,094.69 |  |
| 300 | 1.2.4.5.2 | Type 2 (RDO to PS) | 18d | 2011-12-01 | 2011-12-26 |  | 844d | 330.12d | start no earlier than 2011-12-01 | LBL_Material [140%]; LBL_Mech Tech 4 [38.9%]; LBL_Postdoc Contributed [27.8%]; LBL_Elec Eng Sr [5.6%] | 104h | 8,823.17 |  |
| 301 | 1.2.4.5.3 | Data Control Fibers | 5d | 2012-01-05 | 2012-01-11 |  | 832d | 318.12d | start no earlier than 2012-01-05 | LBL_Material [420%]; LBL_Mech Tech 4 [35%] | 14h | 6,493.78 |  |
| 302 | 1.2.4.6 | **Cooling Services** | 437d | 2011-04-08 | 2012-12-28 |  | 689d |  |  |  | 720h | 93,963.91 |  |
| 303 | 1.2.4.6.1 | Internal Ducting (Engineering) | 17d | 2011-04-08 | 2011-05-02 |  | 1035d | 346d | start no earlier than 2011-04-08 | LBL_Elec Eng Sr [41.2%] | 56h | 7,648.94 |  |
| 304 | 1.2.4.6.2 | Internal Ducting (Production) | 40d | 2012-09-12 | 2012-11-06 | 303 | 689d | 0d | start no earlier than 2012-09-12 | LBL_Material [450%]; LBL_Machinist Sr. [17.5%]; LBL_Mech Tech 4 [47.5%]; LBL_Postdoc Contributed [2.5%]; LBL_Elec Eng Sr [35%] | 328h | 45,207.52 |  |
| 305 | 1.2.4.6.3 | External Ducting | 18d | 2011-12-15 | 2012-01-09 |  | 900d | 211d | start no earlier than 2011-12-15 | LBL_Material [250%]; LBL_Mech Tech 4 [38.9%]; LBL_Postdoc Contributed [5.6%]; LBL_Elec Eng Sr [38.9%] | 120h | 16,881.62 |  |
| 306 | 1.2.4.6.4 | Test Ducting | 34d | 2012-11-07 | 2012-12-28 | 304, 305 | 689d |  | start no earlier than 2011-05-12 | LBL_Material [202%]; LBL_Machinist Sr. [5.9%]; LBL_Mech Tech 4 [30.9%]; LBL_Postdoc Contributed [16.2%]; LBL_Elec Eng Sr [26.5%] | 216h | 24,225.82 |  |

| ID | WBS | Task | Duration | Start | Finish | Predecessors | Complete | Total slack | Free slack | Constraint | Deadline | Resources | Work | Actual work | Cost | Actual cost | Participating Institutions |
| --- | --- | --- | --- | --- | --- | --- | --- | --- | --- | --- | --- | --- | --- | --- | --- | --- | --- |
| 307 | 1.2.4.7 | **Rack Equipment** | 201d | 2011-08-02 | 2012-05-15 |  |  | 745d |  |  |  |  | 1680h |  | 302,295.92 |  |  |
| 308 | 1.2.4.7.1 | RDO Crate Prototype | 21d | 2012-01-03 | 2012-02-01 |  |  | 745d | 0d | start no earlier than 2012-01-03 |  | LBL_Material [350%]; LBL_Machinist Sr. [23.8%]; LBL_Mech Tech 4 [50%]; LBL_Postdoc Contributed [47.6%]; LBL_Elec Eng Sr [33.3%] | 260h |  | 25,987.03 |  |  |
| 309 | 1.2.4.7.2 | RDO Crate Production | 43d | 2012-02-02 | 2012-04-03 | 308 |  | 745d | 0d |  |  | LBL_Material [5120%]; LBL_Machinist Sr. [41.9%]; LBL_Mech Tech 4 [27.9%]; LBL_Elec Eng Sr [7%] | 264h |  | 92,132.38 |  |  |
| 310 | 1.2.4.7.3 | Power Supplies | 40d | 2011-12-01 | 2012-01-26 |  |  | 806d | 0d | start no earlier than 2011-12-01 |  | LBL_Material [640%]; LBL_Mech Tech 4 [2.5%]; LBL_Postdoc Contributed [27.5%]; LBL_Elec Eng Sr [16.2%] | 148h |  | 15,773.78 |  |  |
| 311 | 1.2.4.7.4 | Cooling Plant | 60d | 2011-08-02 | 2011-10-25 |  |  | 852d | 0d | start no earlier than 2011-08-02 |  | LBL_Material [4700%]; LBL_Machinist Sr. [3.3%]; LBL_Mech Tech 4 [33.3%]; LBL_Postdoc Contributed [58.3%]; LBL_Elec Eng Sr [48.3%] | 608h |  | 105,761 |  |  |
| 312 | 1.2.4.7.5 | Test RDO | 30d | 2012-04-04 | 2012-05-15 | 309 |  | 745d | 75d |  |  | LBL_Material [200%]; LBL_Postdoc Contributed [10%]; LBL_Elec Eng Sr [10%] | 48h |  | 5,750.15 |  |  |
| 313 | 1.2.4.7.6 | Test Power Supplies | 16d | 2012-01-27 | 2012-02-17 | 310 |  | 806d | 136d | start no earlier than 2011-07-30 |  | LBL_Material [450%]; LBL_Mech Tech 4 [6.2%]; LBL_Postdoc Contributed [25%]; LBL_Elec Eng Sr [12.5%] | 56h |  | 8,454.08 |  |  |
| 314 | 1.2.4.7.7 | Test Cooling Plant | 34d | 2011-10-26 | 2011-12-14 | 311 |  | 852d | 182d | start no earlier than 2011-05-12 |  | LBL_Material [1250%]; LBL_Mech Tech 4 [64.7%]; LBL_Postdoc Contributed [5.9%]; LBL_Elec Eng Sr [38.2%] | 296h |  | 48,437.5 |  |  |
| 315 | 1.2.5 | **FY10 R&D Efforts** | 70d | 2010-05-26 A | 2010-08-31 A | 28 | 100% |  |  |  |  |  | 2112h | 2112h | 280,000 | 280,000 | ܁- |
| 316 | 1.2.5.1 | Mechanical Efforts: Fabricate and Assemble parts for testing PXL Insertion Mechanism | 70d | 2010-05-26 A | 2010-08-31 A | 28 | 100% |  |  | start no earlier than 2010-05-26 |  | LBL_M_Tech R&D [61.1%]; LBL_Material [870%] | 342h | 342h | 50,000 | 50,000 | ܁- |
| 317 | 1.2.5.2 | Electronics Efforts: PCB Procurement, Probe Testing, RDO | 70d | 2010-05-26 A | 2010-08-31 A | 316SS | 100% |  |  |  |  | LBL_Material [1570%]; LBL_Engineer R&D [28.6%]; LBL_M_Tech R&D | 230h | 230h | 50,000 | 50,000 | ܁- |
| 318 | 1.2.5.3 | Integration Efforts: Inner Support Structure | 70d | 2010-05-26 A | 2010-08-31 A | 317SS | 100% |  |  |  |  | LBL_Engineer R&D [80.4%]; LBL_M_Tech R&D [80.4%] | 900h | 900h | 120,000 | 120,000 | ܁- |
| 319 | 1.2.5.4 | PM Support: Prep of CD-2 Documentation | 70d | 2010-05-26 A | 2010-08-31 A | 28 | 100% |  |  |  |  | LBL_Project Controls [114.3%] | 640h | 640h | 60,000 | 60,000 | ܁- |
| 320 | 1.3 | **Intermediate Silicon Tracker (IST)** | 806d? | 2010-08-31 | 2013-11-07 |  |  | 31d |  |  |  |  | 16382.6h |  | 2,547,242.82 |  | ܁. |
| 321 | 1.3.1 | **Mechanics** | 484d? | 2010-11-01 | 2012-09-28 |  |  | 31d |  |  |  |  | 2656.16h |  | 607,613.72 |  | ܁. |
| 322 | 1.3.1.1 | **Mechanical Design** | 402d? | 2010-11-01 | 2012-06-04 |  |  | 832d |  |  |  |  | 881.6h |  | 79,790.18 |  | ܁. |
| 323 | 1.3.1.1.1 | Support structure (Jim 100%, Jason 100%) | 25d | 2011-10-03 | 2011-11-04 |  |  | 978d |  | start no earlier than 2011-10-03 |  | MIT Mech Eng Project; MIT Mech Draft Project | 400h |  | 38,024 |  | ܁. |
| 324 | 1.3.1.1.2 | Cooling system (Jim/Jason 100%) | 2.2mo | 2012-04-03 | 2012-06-04 |  |  | 832d |  | start no earlier than 2012-04-03 |  | MIT Mech Eng Project | 352h |  | 30,768.32 |  | ܁. |
| 325 | 1.3.1.1.3 | Ladder (Jim/Jason 20%) | 4.05mo? | 2010-11-01 | 2011-03-01 |  |  | 1153d |  | start no earlier than 2010-11-01 |  | MIT Mech Eng Project [20%] | 129.6h |  | 10,997.86 |  | ܁. |
| 326 | 1.3.1.2 | **Mechanical Procurement/Fabrication** | 484d? | 2010-11-01 | 2012-09-28 |  |  | 31d |  |  |  |  | 1774.56h |  | 527,823.54 |  |  |
| 327 | 1.3.1.2.1 | **Lamination prototype testing** | 41d? | 2010-11-01 | 2010-12-30 |  |  | 31d |  |  |  |  | 40h |  | 4,969.6 |  | ܁- |
| 328 | 1.3.1.2.1.1 | **Tooling** | 10d | 2010-11-01 | 2010-11-12 |  |  | 31d |  |  |  |  | 16h |  | 1,876.26 |  | ܁- |
| 329 | 1.3.1.2.1.1.1 | Material | 10d | 2010-11-01 | 2010-11-12 | 476 |  | 31d | 0d |  |  | LBL_Material [15%] |  |  | 174.54 |  |  |
| 330 | 1.3.1.2.1.1.2 | Labor | 80h | 2010-11-01 | 2010-11-12 | 329SS |  | 31d |  |  | 2010-12-30 | LBL_Machinist Jr. [20%] | 16h |  | 1,701.72 |  |  |

Notes:
- 322: Design of all mechanical parts. Note that labor is in a separate task, so not included here. / Text14: Design of the layer support structure and the cooling system. Note that labor is in a separate task, so not included here.
- 323: The design of the support crowns will take place at MIT/Bates. / Text14: The design of the support crowns will take place at MIT/Bates.
- 324: Cooling system design will take place at MIT/Bates with advice from LBNL. / Text14: Cooling system design will take place at MIT/Bates with advice from LBNL.
- 325: The ladder design will be a close collaboration of MIT/Bates and LBNL. / Text14: The ladder design will be a close collaboration of MIT/Bates and LBNL.
- 326: Procurement of off-the-shelf components. Fabrication of non-standard items will take place at MIT, BNL and LBNL. / Text14: Procurement of off-the-shelf components for the cooling system. Fabrication of support structure, ladders and non standard item of the cooling system. Fabrication will take place at MIT, BNL and LBNL.
- 328: Text14: Design of a 50 cm long prototype ladder. This design will be largely based on the existing ATLAS upgrade stave designs.

| ID | WBS | Task | Duration | Start | Finish | Predecessors | Total slack | Free slack | Deadline | Resources | Work | Cost | Participating Institutions |
| --- | --- | --- | --- | --- | --- | --- | --- | --- | --- | --- | --- | --- | --- |
| 331 | 1.3.1.2.1.2 | **Lamination testing** | 30d | 2010-11-15 | 2010-12-29 |  | 1193d |  |  |  | 24h | 2,860.62 | ܁- |
| 332 | 1.3.1.2.1.2.1 | Material | 30d | 2010-11-15 | 2010-12-29 | 329 | 1193d | 0d |  | LBL_Material [30%] |  | 349.07 |  |
| 333 | 1.3.1.2.1.2.2 | Labor | 30d | 2010-11-15 | 2010-12-29 | 332SS | 1194d |  |  | LBL_Mech Tech 4 [10%] | 24h | 2,511.55 |  |
| 334 | 1.3.1.2.1.3 | Shipping | 11d? | 2010-12-15 | 2010-12-30 | 332FS-10d | 1193d | 0d |  | LBL_Material [20%] |  | 232.71 |  |
| 335 | 1.3.1.2.2 | **Lamination prototype ladder** | 41d? | 2010-11-01 | 2010-12-30 |  | 31d |  |  |  | 120h | 15,610.41 | ܁- |
| 336 | 1.3.1.2.2.1 | **Tooling** | 10d | 2010-11-01 | 2010-11-12 |  | 31d |  |  |  | 40h | 4,678.71 | ܁- |
| 337 | 1.3.1.2.2.1.1 | Material | 10d | 2010-11-01 | 2010-11-12 | 476 | 31d | 0d |  | LBL_Material [40%] |  | 465.43 |  |
| 338 | 1.3.1.2.2.1.2 | Labor | 80h | 2010-11-01 | 2010-11-12 | 337SS | 31d |  | 2010-12-30 | LBL_Machinist Jr. [20%]; LBL_Mech Tech 4 [30%] | 40h | 4,213.28 |  |
| 339 | 1.3.1.2.2.2 | **Fabrication** | 30d? | 2010-11-15 | 2010-12-29 |  | 1030d |  |  |  | 80h | 10,698.99 | ܁- |
| 340 | 1.3.1.2.2.2.1 | Material | 30d | 2010-11-15 | 2010-12-29 | 337 | 1030d | 0d |  | LBL_Material [200%] |  | 2,327.15 |  |
| 341 | 1.3.1.2.2.2.2 | Labor | 30d? | 2010-11-15 | 2010-12-29 | 340SS | 1194d |  |  | LBL_Mech Tech 4 [33.3%] | 80h | 8,371.84 |  |
| 342 | 1.3.1.2.2.3 | Shipping | 11d? | 2010-12-15 | 2010-12-30 | 334SS | 1193d |  |  | LBL_Material [20%] |  | 232.71 |  |
| 343 | 1.3.1.2.3 | **Production prototype ladder** | 63d? | 2011-02-01 | 2011-04-29 |  | 1030d |  |  |  | 322.56h | 39,755.41 | ܁- |
| 344 | 1.3.1.2.3.1 | **Tooling** | 63d | 2011-02-01 | 2011-04-29 |  | 1030d |  |  |  | 80.64h | 10,322.05 | ܁- |
| 345 | 1.3.1.2.3.1.1 | Material | 63d | 2011-02-01 | 2011-04-29 | 340FS+21d | 1030d | 0d |  | LBL_Material [150%] |  | 1,745.36 |  |
| 346 | 1.3.1.2.3.1.2 | Labor | 504h | 2011-02-01 | 2011-04-29 | 345SS | 1110d |  |  | LBL_Machinist Jr. [16%] | 80.64h | 8,576.69 |  |
| 347 | 1.3.1.2.3.2 | **Tooling Prep/Assy** | 63d | 2011-02-01 | 2011-04-29 |  | 1030d |  |  |  | 25.2h | 2,811.67 | ܁- |
| 348 | 1.3.1.2.3.2.1 | Material | 63d | 2011-02-01 | 2011-04-29 | 345SS | 1030d | 0d |  | LBL_Material [15%] |  | 174.54 |  |
| 349 | 1.3.1.2.3.2.2 | Labor | 504h | 2011-02-01 | 2011-04-29 | 348SS | 1110d |  |  | LBL_Mech Tech 4 [5%] | 25.2h | 2,637.13 |  |
| 350 | 1.3.1.2.3.3 | **Tooling Iter/Mods** | 63d | 2011-02-01 | 2011-04-29 |  | 1030d |  |  |  | 40.32h | 4,219.41 | ܁- |
| 351 | 1.3.1.2.3.3.1 | Material | 63d | 2011-02-01 | 2011-04-29 | 348SS | 1030d | 0d |  |  |  |  |  |
| 352 | 1.3.1.2.3.3.2 | Labor | 504h | 2011-02-01 | 2011-04-29 | 351SS | 1110d |  |  | LBL_Mech Tech 4 [8%] | 40.32h | 4,219.41 |  |
| 353 | 1.3.1.2.3.4 | **Component fabrication** | 63d | 2011-02-01 | 2011-04-29 |  | 1030d |  |  |  | 80.64h | 10,834.9 | ܁- |
| 354 | 1.3.1.2.3.4.1 | Material | 63d | 2011-02-01 | 2011-04-29 | 351SS | 1030d | 0d |  | LBL_Material [200%] |  | 2,327.15 |  |
| 355 | 1.3.1.2.3.4.2 | Labor | 504h | 2011-02-01 | 2011-04-29 | 354SS | 1110d |  |  | LBL_Machinist Jr. [8%]; LBL_Mech Tech 4 [8%] | 80.64h | 8,507.75 |  |

Notes:
- 331: Text14: Design of a 50 cm long prototype ladder. This design will be largely based on the existing ATLAS upgrade stave designs.
- 336: Text14: Design of a 50 cm long prototype ladder. This design will be largely based on the existing ATLAS upgrade stave designs.
- 339: Text14: Design of a 50 cm long prototype ladder. This design will be largely based on the existing ATLAS upgrade stave designs.
- 344: Text14: Design of a 50 cm long prototype ladder. This design will be largely based on the existing ATLAS upgrade stave designs.
- 347: Text14: Design of a 50 cm long prototype ladder. This design will be largely based on the existing ATLAS upgrade stave designs.
- 350: Text14: Design of a 50 cm long prototype ladder. This design will be largely based on the existing ATLAS upgrade stave designs.
- 353: Text14: Design of a 50 cm long prototype ladder. This design will be largely based on the existing ATLAS upgrade stave designs.

| ID | WBS | Task | Duration | Start | Finish | Predecessors | Total slack | Free slack | Constraint | Resources | Work | Cost | Participating Institutions | Text3 | Text4 | Text6 | Text7 | Text8 | Text9 | Text10 | Text11 |
| --- | --- | --- | --- | --- | --- | --- | --- | --- | --- | --- | --- | --- | --- | --- | --- | --- | --- | --- | --- | --- | --- |
| 356 | 1.3.1.2.3.5 | **Face-Sheets** | 63d | 2011-02-01 | 2011-04-29 |  | 1030d |  |  |  | 30.24h | 3,896.34 | ܁- |  |  |  |  |  |  |  |  |
| 357 | 1.3.1.2.3.5.1 | Material | 63d | 2011-02-01 | 2011-04-29 | 354SS | 1030d | 0d |  | LBL_Material [50%] |  | 581.79 |  |  |  |  |  |  |  |  |  |
| 358 | 1.3.1.2.3.5.2 | Labor | 63d | 2011-02-01 | 2011-04-29 | 357SS | 1110d |  |  | LBL_Mech Tech 4 [6%] | 30.24h | 3,314.56 |  |  |  |  |  |  |  |  |  |
| 359 | 1.3.1.2.3.6 | **Ladder Assembly** | 63d | 2011-02-01 | 2011-04-29 |  | 1030d |  |  |  | 50.4h | 5,506.97 | ܁- |  |  |  |  |  |  |  |  |
| 360 | 1.3.1.2.3.6.1 | Material | 63d | 2011-02-01 | 2011-04-29 | 357SS | 1030d | 0d |  | LBL_Material [20%] |  | 232.71 |  |  |  |  |  |  |  |  |  |
| 361 | 1.3.1.2.3.6.2 | Labor | 504h | 2011-02-01 | 2011-04-29 | 360SS | 1110d |  |  | LBL_Mech Tech 4 [10%] | 50.4h | 5,274.26 |  |  |  |  |  |  |  |  |  |
| 362 | 1.3.1.2.3.7 | **Ladder Mechanical Test/Survey** | 63d | 2011-02-01 | 2011-04-29 |  | 1030d |  |  |  | 15.12h | 1,582.28 | ܁- |  |  |  |  |  |  |  |  |
| 363 | 1.3.1.2.3.7.1 | Material | 63d | 2011-02-01 | 2011-04-29 | 360SS | 1030d | 0d |  |  |  |  |  |  |  |  |  |  |  |  |  |
| 364 | 1.3.1.2.3.7.2 | Labor | 504h | 2011-02-01 | 2011-04-29 | 363SS | 1110d |  |  | LBL_Mech Tech 4 [3%] | 15.12h | 1,582.28 |  |  |  |  |  |  |  |  |  |
| 365 | 1.3.1.2.3.8 | Shipping | 11d? | 2011-04-15 | 2011-04-29 | 345FS-11d, 348FS-11d, 351FS-11d, 354FS-11d, 357FS-11d, 360FS-11d, 363FS-11d | 1030d | 0d |  | LBL_Material [50%] |  | 581.79 | ܁- |  |  |  |  |  |  |  |  |
| 366 | 1.3.1.2.4 | Support structure | 50d | 2010-11-05 | 2011-01-20 | 367SS+2d | 1180d |  |  | MIT Material [5000%] |  | 50,000 | ܁. | More than one iteration to meet requirements | none | none | schedule | low | low | low | scheduling slack |
| 367 | 1.3.1.2.5 | Support structure production (Jim/Jason 100%) | 50d | 2010-11-03 | 2011-01-18 | 476FS+2d | 1180d | 0d |  | MIT Mech Eng Project | 400h | 33,944 | ܁. |  |  |  |  |  |  |  |  |
| 368 | 1.3.1.2.6 | Cooling system | 3mo | 2012-06-04 | 2012-08-27 |  | 767d | 0d | start no earlier than 2012-06-04 | MIT Material [5000%] |  | 50,000 | ܁. |  |  |  |  |  |  |  |  |
| 369 | 1.3.1.2.7 | Cooling system production (Jim/Jason 25%, STAR Ops) | 3.3mo | 2012-06-04 | 2012-09-05 | 368SS | 767d |  |  | MIT Mech Eng Project [25%] | 132h | 11,538.12 | ܁. |  |  |  |  |  |  |  |  |
| 370 | 1.3.1.2.8 | Ladders | 12.65mo? | 2011-10-03 | 2012-09-28 |  | 750d | 0d | finish no earlier than 2012-09-28 | MIT Material [25600%] |  | 256,000 |  | Failure to produce all ladders in time | none | none | schedule | moderate | low | low | scheduling slack |
| 371 | 1.3.1.2.9 | Technical assistance (Dale 50%) | 190d? | 2011-10-03 | 2012-06-29 | 370SS | 813d |  |  | MIT Tech Proj [50%] | 760h | 66,006 | ܁. |  |  |  |  |  |  |  |  |
| 372 | 1.3.2 | **Electronics** | 627d? | 2010-10-01 | 2013-03-29 |  | 628d |  |  |  | 1038.4h | 1,228,485.84 | ܁. |  |  |  |  |  |  |  |  |
| 373 | 1.3.2.1 | **Electrical Design and Requirements** | 315d? | 2010-10-01 | 2011-12-30 |  | 936d |  |  |  | 198.4h | 18,198.24 |  |  |  |  |  |  |  |  |  |
| 374 | 1.3.2.1.1 | Sensors | 8.2w? | 2010-11-01 | 2010-12-30 | 476 | 1172d | 0d |  |  |  |  |  |  |  |  |  |  |  |  |  |
| 375 | 1.3.2.1.2 | Readout Chips | 4.2w | 2010-10-01 | 2010-10-29 |  | 1234d |  | finish no earlier than 2010-10-29 |  |  |  |  |  |  |  |  |  |  |  |  |
| 376 | 1.3.2.1.3 | Flex hybrid (Ben 20%, Bob 20%) | 12.4w | 2010-11-01 | 2011-02-01 | 374SS | 1172d | 0d |  | MIT Elec Eng Project [20%]; MIT Elec Draft Project [20%] | 198.4h | 18,198.24 | ܁. |  |  |  |  |  |  |  |  |
| 377 | 1.3.2.1.4 | **Readout system** | 315d? | 2010-10-01 | 2011-12-30 |  | 936d |  |  |  |  |  |  |  |  |  |  |  |  |  |  |
| 378 | 1.3.2.1.4.1 | Crates | 3.3mo? | 2010-10-01 | 2011-01-06 |  | 936d | 0d | start no earlier than 2010-10-01 |  |  |  |  |  |  |  |  |  |  |  |  |
| 379 | 1.3.2.1.4.2 | Data transmitters | 3.3mo? | 2010-10-01 | 2011-01-06 | 378SS | 940d | 439d |  |  |  |  |  |  |  |  |  |  |  |  |  |
| 380 | 1.3.2.1.4.3 | APV Readout Modules | 3.3mo? | 2010-10-01 | 2011-01-06 | 378SS | 940d | 439d |  |  |  |  |  |  |  |  |  |  |  |  |  |
| 381 | 1.3.2.1.4.4 | APV Readout Controllers | 3.3mo? | 2010-10-01 | 2011-01-06 | 378SS | 940d | 439d |  |  |  |  |  |  |  |  |  |  |  |  |  |
| 382 | 1.3.2.1.4.5 | Bias voltage supplies | 13.2w | 2010-10-01 | 2011-01-06 | 378SS | 940d | 439d |  |  |  |  |  |  |  |  |  |  |  |  |  |
| 383 | 1.3.2.1.4.6 | Transition boxes | 63w | 2010-10-01 | 2011-12-30 | 378SS | 940d |  |  |  |  |  |  |  |  |  |  |  |  |  |  |

Notes:
- 356: Text14: Design of a 50 cm long prototype ladder. This design will be largely based on the existing ATLAS upgrade stave designs.
- 359: Text14: Design of a 50 cm long prototype ladder. This design will be largely based on the existing ATLAS upgrade stave designs.
- 362: Text14: Design of a 50 cm long prototype ladder. This design will be largely based on the existing ATLAS upgrade stave designs.
- 366: The support structure connects the 24 ladders to the MSC. The ladders are supported at their 2 ends. These end supports each consist of 2 halfs which will be glued to the MSC. The ladders will click into these supports, being fixed on one side and able to thermally expand on the other side. The support structures will probably be produced by rapid prototyping. / Text14: The support structure connects the 24 ladders to the MSC. The ladders are supported at their 2 ends. These end supports each consist of 2 halfs which will be glued to the MSC. The ladders will click into these supports, being fixed on one side and able to
- 367: The production of the support crowns will take place at a rapid prototyping facility under supervision of MIT/Bates. / Text14: The production of the support crowns will take place at a rapid prototyping facility under supervision of MIT/Bates.
- 368: Text14: Procure the commercially available cooling unit. Fabricate the cooling ductwork from cooling unit to the individual ladders. This includes also monitoring devices for flow, pressure, temperature, etc.
- 369: Cooling unit procurement will take place under supervision of MIT/Bates. Production of ducting, monitoring, etc. will take place at MIT, MIT/Bates and BNL. / Text14: Cooling unit procurement will take place under supervision of MIT/Bates. Production of ducting, monitoring, etc. will take place at MIT, MIT/Bates and BNL.
- 370: Ladder fabrication at the LBNL carbon-fiber facility. Ladders will be very similar to the ATLAS upgrade staves which are also produced at the same facility. Ladders consist of a carbon-fiber honeycomb core laminated between carbon-fiber skins. The edges will be reinforced with thermally conducting foam which will also be used to embed the two cooling tubes. / Text14: Ladder fabrication at the LBNL carbon-fiber facility. Ladders will be very similar to the ATLAS upgrade staves which are also produced at the same facility. Ladders consist of a carbon-fiber honeycomb core laminated between carbon-fiber skins.
- 373: Defining the requirements of all electrical components and making designs according to those requirements. / Text14: Defining the requirements of all electrical components and making designs according to those requirements.
- 374: The optimal silicon pad sensor geometry will be defined by the expected maximum occupancies and double hit probabilities, within the contraint of a maximum number of channels that can be read out. / Text14: The optimal silicon pad sensor geometry will be defined by the expected maximum occupancies and double hit probabilities, within the contraint of a maximum number of channels that can be read out.
- 375: Designing new readout chips is outside of the available resources of the project. The requirements for number of channels, readout speed, dead time, radiation hardness, etc., has already lead to a choice of an existing readout chip. This chip will be widely used for STAR upgrades, leading to a unified readout scheme. / Text14: Designing new readout chips is outside of the available resources of the project. The requirements for number of channels, readout speed, dead time, radiation hardness, etc., has already lead to a choice of an existing readout chip. This chip will be wide
- 376: All labor costs except for the initial development of the APV readout system. / Text14: All labor costs except for the initial development of the APV readout system.
- 377: The readout system follows closely the design of the STAR FGT, to minimize the design effort an identical readout system is preferred. The FGT and IST have agreed upon the maximum number of APV readout chips that will be read out per readout module (ARM). The current IST readout system will consist of 2 crates, 26 ARM's and 6 ARC's. The ARM's will provide low voltage to the readout chips, the bias voltage logistics is still under investigation. / Text14: The readout system follows closely the design of the STAR FGT, to minimize the design effort an identical readout system is preferred. The FGT and IST have agreed upon the maximum number of APV readout chips that will be read out per readout module (ARM).
- 378: The readout crates will be Wiener MPOD crates with modified backplanes. Since there will be no low voltage or high voltage units in this crate there will be no need for a crate controller. Three ARC's and 18 ARM's will reside in one crate. / Text14: The readout crates will be Wiener MPOD crates with modified backplanes. Since there will be no low voltage or high voltage units in this crate there will be no need for a crate controller. Three ARC's and 18 ARM's will reside in one crate.
- 379: SIU's are the standard STAR data transmitters for upgrades and will also be used in this system. They reside on the ARC's and provide a standardized fiber link connection to the DAQ. These units are commercially available and already in use for the STAR TPC. No further development needed. / Text14: SIU's are the standard STAR data transmitters for upgrades and will also be used in this system. They reside on the ARC's and provide a standardized fiber link connection to the DAQ. These units are commercially available and already in use for the STAR T
- 380: The APV Reaout Modules (ARM) will read out 2 cables carrying 12 APV readout chips signals each. The ARM will also provide the voltages and control signals necessary to operate the attached APV readout chips. Six ARM's communicate with 1 ARC over a modified backplane. The ARM's will already be in use in the FGT well before they go in production for the IST, i.e. any problems should have been identified and resolved already. / Text14: The APV Reaout Modules (ARM) will read out 2 cables carrying 12 APV readout chips signals each. The ARM will also provide the voltages and control signals necessary to operate the attached APV readout chips. Six ARM's communicate with 1 ARC over a modifie
- 381: Each APV Readout Controller (ARC) will read out 6 ARM's and send the data over the SIU fiber link to the DAQ. The ARC also interfaces the DAQ to the slow control functions of the readout system. / Text14: Each APV Readout Controller (ARC) will read out 6 ARM's and send the data over the SIU fiber link to the DAQ. The ARC also interfaces the DAQ to the slow control functions of the readout system.
- 382: Each bias voltage supply will feed 6 ladders, so 4 supplies plus 1 spare are needed. Six ladders have 36 silicon pad sensors. Assuming a maximum of 100uA per sensor, each bias supply should be able to deliver 3.6mA. Each IST module will have its own bias regulation, so there will be some losses there too. A standard linear 250V supply delivering about 100mA should be sufficient. / Text14: Each bias voltage supply will feed 6 ladders, so 4 supplies plus 1 spare are needed. Six ladders have 36 silicon pad sensors. Assuming a maximum of 100uA per sensor, each bias supply should be able to deliver 3.6mA. Each IST module will have its own bias
- 383: Each bias voltage supply will feed 6 ladders, so 4 supplies plus 1 spare are needed. Six ladders have 36 silicon pad sensors. Assuming a maximum of 100uA per sensor, each bias supply should be able to deliver 3.6mA. Each IST module will have its own bias regulation, so there will be some losses there too. A standard linear 250V supply delivering about 100mA should be sufficient. / Text14: Each bias voltage supply will feed 6 ladders, so 4 supplies plus 1 spare are needed. Six ladders have 36 silicon pad sensors. Assuming a maximum of 100uA per sensor, each bias supply should be able to deliver 3.6mA. Each IST module will have its own bias

| ID | WBS | Task | Duration | Start | Finish | Predecessors | Total slack | Free slack | Constraint | Resources | Work | Cost | Participating Institutions | Text3 | Text4 | Text6 | Text7 | Text8 | Text9 | Text10 | Text11 |
| --- | --- | --- | --- | --- | --- | --- | --- | --- | --- | --- | --- | --- | --- | --- | --- | --- | --- | --- | --- | --- | --- |
| 384 | 1.3.2.1.5 | **DAQ** | 66d? | 2010-10-01 | 2011-01-06 |  | 936d |  |  |  |  |  |  |  |  |  |  |  |  |  |  |
| 385 | 1.3.2.1.5.1 | Fibers | 3.3mo? | 2010-10-01 | 2011-01-06 |  | 936d | 0d | start no earlier than 2010-10-01 |  |  |  |  |  |  |  |  |  |  |  |  |
| 386 | 1.3.2.1.5.2 | Data receivers | 3.3mo? | 2010-10-01 | 2011-01-06 | 385SS | 940d | 439d |  |  |  |  |  |  |  |  |  |  |  |  |  |
| 387 | 1.3.2.1.5.3 | Computers | 3.3mo? | 2010-10-01 | 2011-01-06 | 385SS | 940d | 439d |  |  |  |  |  |  |  |  |  |  |  |  |  |
| 388 | 1.3.2.1.6 | Slow Controls | 66d | 2010-10-01 | 2011-01-06 | 378SS, 385SS | 936d | 186d |  |  |  |  |  |  |  |  |  |  |  |  |  |
| 389 | 1.3.2.2 | **Electrical Prototypes Production** | 360d? | 2010-10-01 | 2012-03-06 |  | 895d |  |  |  | 80h | 264,761.6 | ܁. |  |  |  |  |  |  |  |  |
| 390 | 1.3.2.2.1 | Prototype sensor drawings and masks | 2.2mo? | 2010-10-01 | 2010-12-03 |  | 1147d | 0d | start no earlier than 2010-10-01 | MIT Material [6800%] |  | 68,000 | ܁. | Design problems leading to multiple iterations | none | none | schedule | low | low | low | scheduling slack |
| 391 | 1.3.2.2.2 | Prototype sensors production | 64d | 2010-12-06 | 2011-03-09 | 390 | 1147d |  |  | MIT Material [4400%] |  | 44,000 | ܁. | Failure to function according to specifications | none | $80k NRE + $32k prototypes | cost/schedule | moderate | low | low | scheduling slack,reliable vendor |
| 392 | 1.3.2.2.3 | Prototype sensor drawings and masks respin | 2.2mo? | 2011-10-03 | 2011-12-05 |  | 895d | 0d | start no earlier than 2011-10-03 | MIT Material [6800%] |  | 68,000 | ܁. | Design problems leading to multiple iterations | none | none | schedule | low | low | low | scheduling slack |
| 393 | 1.3.2.2.4 | Prototype sensors production respin | 64d | 2011-12-06 | 2012-03-06 | 392 | 895d |  |  | MIT Material [4400%] |  | 44,000 | ܁. | Failure to function according to specifications | none | $80k NRE + $32k prototypes | cost/schedule | moderate | low | low | scheduling slack,reliable vendor |
| 394 | 1.3.2.2.5 | Prototype flex hybrid production | 131d | 2010-10-04 | 2011-04-12 |  | 1123d |  | start no earlier than 2010-10-04 | MIT Material [3000%] |  | 30,000 | ܁. | Failure to function according to specifications | none | $5k | cost/schedule | low | low | low | scheduling slack, less prototypes |
| 395 | 1.3.2.2.6 | Prototype readout system labor | 41d? | 2010-11-01 | 2010-12-30 | 376SS | 1193d |  |  | MIT_IUCF Elec Eng Project [24.4%] | 80h | 10,761.6 |  |  |  |  |  |  |  |  |  |
| 396 | 1.3.2.3 | **Electrical Procurement/Fabrication** | 627d? | 2010-10-01 | 2013-03-29 |  | 628d |  |  |  | 760h | 945,526 | ܁. |  |  |  |  |  |  |  |  |
| 397 | 1.3.2.3.1 | Sensors procurement | 12.65mo | 2011-10-03 | 2012-09-28 |  | 750d | 0d | finish no earlier than 2012-09-28 | MIT Material [33500%] |  | 335,000 | ܁. | Production problems | none | none | schedule | moderate | low | low | reliable vendor, stage batch production |
| 398 | 1.3.2.3.2 | Readout Chips | 50.4w? | 2010-10-01 | 2011-09-30 |  | 943d | 194d | finish no earlier than 2011-09-30 | MIT Material [2880%] |  | 28,800 | ܁. |  |  |  |  |  |  |  |  |
| 399 | 1.3.2.3.3 | Flex hybrid procurement | 50.6w | 2011-10-03 | 2012-09-28 | 397SS | 501d | 0d |  | MIT Material [19180%] |  | 191,800 | ܁. | Production problems | none | none | schedule | moderate | low | low | scheduling slack by producing early |
| 400 | 1.3.2.3.4 | **Cables** | 122d? | 2012-10-01 | 2013-03-29 |  | 501d |  |  |  |  | 58,600 | ܁. |  |  |  |  |  |  |  |  |
| 401 | 1.3.2.3.4.1 | Signal cables inside field cage | 24.4w | 2012-10-01 | 2013-03-29 | 399 | 501d | 0d |  | MIT Material [820%] |  | 8,200 | ܁. | Production problems | none | none | schedule | low | low | low | conservative design, produce early |
| 402 | 1.3.2.3.4.2 | Signal cables outside field cage | 6.1mo? | 2012-10-01 | 2013-03-29 | 401SS | 501d | 0d |  | MIT Material [4200%] |  | 42,000 | ܁. | Production problems | none | none | schedule | low | low | low | conservative design, produce early |
| 403 | 1.3.2.3.4.3 | Bias voltage cables outside field cage | 6.1mo? | 2012-10-01 | 2013-03-29 | 401SS | 501d | 0d |  | MIT Material [840%] |  | 8,400 | ܁. | Production problems | none | none | schedule | low | low | low | conservative design, produce early |
| 404 | 1.3.2.3.5 | Transition boxes (labor included) | 6mo? | 2012-01-02 | 2012-06-20 |  | 750d | 0d | start no earlier than 2012-01-02 | MIT Material [2400%] |  | 24,000 | ܁. | Fabrication problems | none | none | schedule | low | low | low | conservative design, produce early |
| 405 | 1.3.2.3.6 | **Readout system** | 122d | 2012-10-01 | 2013-03-29 |  | 501d |  |  |  |  | 206,600 | ܁. |  |  |  |  |  |  |  | Problems straightened out by FGT |
| 406 | 1.3.2.3.6.1 | Crates | 6.1mo | 2012-10-01 | 2013-03-29 | 378 | 501d | 0d | finish no earlier than 2013-03-29 | MIT Material [3600%] |  | 36,000 | ܁. |  |  |  |  |  |  |  |  |
| 407 | 1.3.2.3.6.2 | Data transmitters | 6.1mo | 2012-10-01 | 2013-03-29 | 379, 406SS | 501d | 0d |  | MIT Material [560%] |  | 5,600 | ܁. |  |  |  |  |  |  |  |  |
| 408 | 1.3.2.3.6.3 | APV Readout Modules | 6.1mo | 2012-10-01 | 2013-03-29 | 380, 406SS | 501d | 0d |  | MIT Material [12000%] |  | 120,000 | ܁. |  |  |  |  |  |  |  |  |
| 409 | 1.3.2.3.6.4 | APV Readout Controllers | 6.1mo | 2012-10-01 | 2013-03-29 | 381, 406SS | 501d | 0d |  | MIT Material [2000%] |  | 20,000 | ܁. |  |  |  |  |  |  |  |  |
| 410 | 1.3.2.3.6.5 | Bias voltage supplies | 6.1mo | 2012-10-01 | 2013-03-29 | 382, 406SS | 501d | 0d |  | MIT Material [2500%] |  | 25,000 | ܁. |  |  |  |  |  |  |  |  |

Notes:
- 384: DAQ is everything downstream from the actual readout system. / Text14: DAQ is everything downstream from the actual readout system.
- 385: Same fibers already in use for the STAR TPC. No development needed. / Text14: Same fibers already in use for the STAR TPC. No development needed.
- 386: These data receivers are commercially available CERNTECH D-RORC cards which accept signals from 2 SIU's.These are the same D-RORC units already in use for the STAR TPC. No further development needed. / Text14: These data receivers are commercially available CERNTECH D-RORC cards which accept signals from 2 SIU's.These are the same D-RORC units already in use for the STAR TPC. No further development needed.
- 387: Standard rack mounted servers. Same as used for all STAR upgrades. No further development needed. / Text14: Standard rack mounted servers. Same as used for all STAR upgrades. No further development needed.
- 388: The slow controls system of the IST will interface to the existing STAR EPIC's system. It will control the APV readout system, the bias voltage supplies and the cooling system. The interfaces to EPIC's still need to be defined. / Text14: The slow controls system of the IST will interface to the existing STAR EPIC's system. It will control the APV readout system, the bias voltage supplies and the cooling system. The interfaces to EPIC's still need to be defined.
- 389: This task describes the production of the silicon sensors and the kapton flex hybrid/cable. / Text14: This task describes the prototype production of the silicon sensors and the kapton flex hybrid/cable.
- 390: The initial design of the sensors will be done by an MIT physicist. The mask design will be done by the vendor in close collaboration with the MIT physicist. / Text14: The initial design of the sensors will be done by an MIT physicist. The mask design will be done by the vendor in close collaboration with the MIT physicist.
- 391: The slow controls system of the IST will interface to the existing STAR EPIC's system. It will control the APV readout system, the bias voltage supplies and the cooling system. The interfaces to EPIC's still need to be defined. / Text14: The slow controls system of the IST will interface to the existing STAR EPIC's system. It will control the APV readout system, the bias voltage supplies and the cooling system. The interfaces to EPIC's still need to be defined.
- 392: The initial design of the sensors will be done by an MIT physicist. The mask design will be done by the vendor in close collaboration with the MIT physicist. / Text14: The initial design of the sensors will be done by an MIT physicist. The mask design will be done by the vendor in close collaboration with the MIT physicist.
- 393: The slow controls system of the IST will interface to the existing STAR EPIC's system. It will control the APV readout system, the bias voltage supplies and the cooling system. The interfaces to EPIC's still need to be defined. / Text14: The slow controls system of the IST will interface to the existing STAR EPIC's system. It will control the APV readout system, the bias voltage supplies and the cooling system. The interfaces to EPIC's still need to be defined.
- 394: Text14: The flex hybrid prototype will prove if this thin kapton hybrid-cable solution is feasible. If yields permit then the resulting prototypes will also be used to prototype a full ladder.
- 396: Most of these items can come out in 'batches', only at the end of the task everything should be in our hands. / Text14: Most of these items can come out in 'batches', only at the end of the task everything should be in our hands. This task envelops sensors production, readout chips procurement and hybrid production.
- 397: The sensor production lead time is expected to be 6 months. However, to flatten the cost and to be able to test in between batched, this production will probably be smeared out over a longer period of time. / Text14: The sensor production lead time is expected to be 6 months. However, to flatten the cost and to be able to test in between batched, this production will probably be smeared out over a longer period of time.
- 398: The APV chips are not being produced anymore. Since they are critical for both the FGT and the IST project all necessary chips have been secured before the start of these projects. / Text14: The APV chips are not being produced anymore. Since they are critical for both the FGT and the IST project all necessary chips have been secured before the start of these projects.
- 399: Production of the kapton flex hybrid/cable will probably proceed in several steps to flatten the funding. / Text14: Production of the kapton flex hybrid/cable will probably proceed in several steps to flatten the funding.
- 400: All cables are commercially available items. / Text14: These cables connect the flex cables to the transition boxes and the transition boxes to the readout system. Data, control signals, supply and bias voltages go over these cables. All cables are commercially available items.
- 401: The signal cables inside the field cage connect the kapton flex cable with the transition boxes outside of the field cage. These cables are not running withing any active detection areas and can be made from standard copper stock. / Text14: The signal cables inside the field cage connect the kapton flex cable with the transition boxes outside of the field cage. These cables are not running withing any active detection areas and can be made from standard copper stock.
- 402: The signal cables outside of the field cage connect the transition boxes with the actual readout system residing on the STAR electronics platform. Standard copper stock cable. / Text14: The signal cables outside of the field cage connect the transition boxes with the actual readout system residing on the STAR electronics platform. Standard copper stock cable.
- 403: The bias voltage cables connect the bias voltage supplies with the transition boxes which contain the individual regulators for the modules. Standard HV cable. / Text14: The bias voltage cables connect the bias voltage supplies with the transition boxes which contain the individual regulators for the modules. Standard HV cable.
- 404: The transition boxes act as a place of connection between the cables inside of the field cage and the cables running to the readout crates on the platform. They also contain the individual HV regulators for the IST modules. These boxes will reuse the mechanics which was used for the now defunct STAR SVT. / Text14: The transition boxes act as a place of connection between the cables inside of the field cage and the cables running to the readout crates on the platform. They also contain the individual HV regulators for the IST modules. Mechanics exists already.
- 405: The readout system consists of 2 crates of readout modules and controllers sending the processed data over data transmitters to the DAQ. The Bias Voltage supplies supply the operating voltage for the silicon sensors. / Text14: The readout system consists of 2 crates of readout modules and controllers sending the processed data over data transmitters to the DAQ. The Bias Voltage supplies supply the operating voltage for the silicon sensors.

| ID | WBS | Task | Duration | Start | Finish | Predecessors | Total slack | Free slack | Constraint | Resources | Work | Cost | Text11 | Participating Institutions |
| --- | --- | --- | --- | --- | --- | --- | --- | --- | --- | --- | --- | --- | --- | --- |
| 411 | 1.3.2.3.7 | **DAQ** | 122d | 2012-10-01 | 2013-03-29 |  | 501d |  |  |  |  | 23,900 | Problems straightened out by FGT | ܁. |
| 412 | 1.3.2.3.7.1 | Fibers | 6.1mo | 2012-10-01 | 2013-03-29 | 385 | 501d | 0d | finish no earlier than 2013-03-29 | MIT Material [800%] |  | 8,000 |  | ܁. |
| 413 | 1.3.2.3.7.2 | Data receivers | 6.1mo | 2012-10-01 | 2013-03-29 | 386, 412SS | 501d | 0d |  | MIT Material [720%] |  | 7,200 |  | ܁. |
| 414 | 1.3.2.3.7.3 | Computers | 6.1mo | 2012-10-01 | 2013-03-29 | 387, 412SS | 501d | 0d |  | MIT Material [870%] |  | 8,700 |  | ܁. |
| 415 | 1.3.2.3.8 | Slow Controls | 253d | 2011-10-03 | 2012-09-28 | 388 | 750d | 0d | finish no earlier than 2012-09-28 | MIT Material [1082%] |  | 10,820 |  | ܁. |
| 416 | 1.3.2.3.9 | Technical assistance (Dale 50%) | 190d? | 2011-10-03 | 2012-06-29 | 415SS | 813d |  |  | MIT Tech Proj [50%] | 760h | 66,006 |  |  |
| 417 | 1.3.3 | **Assembly and testing** | 627d? | 2011-05-02 | 2013-10-23 |  | 483d |  |  |  | 6424h | 605,739.42 |  | ܁. |
| 418 | 1.3.3.1 | **Prototypes** | 80d | 2011-05-02 | 2011-08-23 |  | 1030d |  |  |  | 160h | 13,491.2 |  |  |
| 419 | 1.3.3.1.1 | Module assembly | 1.05mo | 2011-05-02 | 2011-05-31 | 365 | 1030d | 0d | start no earlier than 2011-05-02 |  |  |  |  |  |
| 420 | 1.3.3.1.2 | Module testing (Grad,Gerrit) | 3.5mo | 2011-05-16 | 2011-08-23 | 419SS+2w | 1030d |  |  |  |  |  |  |  |
| 421 | 1.3.3.1.3 | Labor (Dale 100%) | 1mo | 2011-05-02 | 2011-05-27 | 419SS | 1090d |  |  | MIT Tech Proj | 160h | 13,491.2 |  |  |
| 422 | 1.3.3.2 | **Component Testing** | 439d? | 2012-01-02 | 2013-09-27 |  | 486d |  |  |  | 1116.8h | 120,419.94 |  | ܁. |
| 423 | 1.3.3.2.1 | Sensors Testing | 9.85mo | 2012-03-20 | 2012-12-28 |  | 522d | 36d | start no earlier than 2012-03-20 |  |  |  |  | ܁. |
| 424 | 1.3.3.2.2 | Readout Chips | 3mo | 2012-07-09 | 2012-10-01 | 398 | 749d |  | finish no earlier than 2012-10-01 |  |  |  |  | ܁. |
| 425 | 1.3.3.2.3 | Ladders Testing | 12.55mo? | 2012-01-02 | 2012-12-28 |  | 689d | 190d | finish no earlier than 2012-12-28 |  |  |  |  | ܁. |
| 426 | 1.3.3.2.4 | Flex Hybrids Testing | 12.55mo? | 2012-01-02 | 2012-12-28 |  | 486d | 0d | start no earlier than 2012-01-02 |  |  |  |  | ܁. |
| 427 | 1.3.3.2.5 | Labor (Gerrit, PostDoc, Grad) | 251d? | 2012-01-02 | 2012-12-28 |  | 689d |  | start no earlier than 2012-01-02 |  |  |  |  |  |
| 428 | 1.3.3.2.6 | **Cables** | 127d? | 2013-04-01 | 2013-09-27 |  | 501d |  |  |  |  |  |  | ܁. |
| 429 | 1.3.3.2.6.1 | Signal cables inside field cage | 6.35mo | 2013-04-01 | 2013-09-27 | 401 | 501d |  |  |  |  |  |  | ܁. |
| 430 | 1.3.3.2.6.2 | Signal cables outside field cage | 6.35mo | 2013-04-01 | 2013-09-27 | 402 | 501d |  |  |  |  |  |  | ܁. |
| 431 | 1.3.3.2.6.3 | Bias voltage cables outside field cage | 6.35mo | 2013-04-01 | 2013-09-27 | 403 | 501d |  |  |  |  |  |  | ܁. |
| 432 | 1.3.3.2.6.4 | Cable installation (STAR Ops) | 127d? | 2013-04-01 | 2013-09-27 |  | 501d |  | finish no earlier than 2013-09-27 |  |  |  |  |  |
| 433 | 1.3.3.2.7 | Transition boxes testing (Ben 20%, Dale 100%) | 3.15mo | 2012-07-02 | 2012-09-28 | 404FS+7d | 750d |  |  | MIT Elec Eng Project [10%]; MIT Tech Proj [10%] | 100.8h | 8,568.5 |  | ܁. |
| 434 | 1.3.3.2.8 | **Readout system** | 127d | 2013-04-01 | 2013-09-27 |  | 501d |  |  |  | 1016h | 111,851.44 |  | ܁. |
| 435 | 1.3.3.2.8.1 | Crates | 6.35mo | 2013-04-01 | 2013-09-27 | 406 | 501d | 0d |  |  |  |  |  | ܁. |
| 436 | 1.3.3.2.8.2 | Data transmitters | 6.35mo | 2013-04-01 | 2013-09-27 | 407 | 501d |  |  |  |  |  |  | ܁. |
| 437 | 1.3.3.2.8.3 | APV Readout Modules | 6.35mo | 2013-04-01 | 2013-09-27 | 408 | 501d |  |  |  |  |  |  | ܁. |
| 438 | 1.3.3.2.8.4 | APV Readout Controllers | 6.35mo | 2013-04-01 | 2013-09-27 | 409 | 501d |  |  |  |  |  |  | ܁. |
| 439 | 1.3.3.2.8.5 | LV supplies | 6.35mo | 2013-04-01 | 2013-09-27 |  | 501d |  | finish no earlier than 2013-09-27 |  |  |  |  | ܁. |
| 440 | 1.3.3.2.8.6 | Bias voltage supplies | 6.35mo | 2013-04-01 | 2013-09-27 | 410 | 501d |  |  |  |  |  |  | ܁. |
| 441 | 1.3.3.2.8.7 | Labor (Ben 50%, Gerard 50%) | 25.4w | 2013-04-01 | 2013-09-27 | 435SS | 501d |  |  | MIT Elec Eng Project [50%]; IUCF Elec Eng Project [50%] | 1016h | 111,851.44 |  | ܁. |

Notes:
- 411: Text14: The Data AQcuisation system consists of the fibers carying the processed data from the readout system, the data receivers and the computers which house the receivers and build the events.
- 415: Text14: The Slow Controls controls every aspect of the readout system and the environmental control of the detector system. It makes sure that the operational parameters are within bounds and takes appropiate action when this is not the case.
- 418: Text14: Assembling and testing of prototype detector modules. If the yield is high enough these modules will be used to assemble a full stave.
- 422: Text14: Sample testing of silicon sensors. Selecting readout chips. Mechanical testing of ladders. Electrical testing of hybrids.
- 423: Sensors already tested by Hamamatsu. / Test 1 sensor per batch. / At 24 sensors per batch, we need to test about 10 sensors. / Should not take more than 10 days.

| ID | WBS | Task | Duration | Start | Finish | Predecessors | Total slack | Free slack | Resources | Work | Cost | Participating Institutions | Text3 | Text4 | Text6 | Text7 | Text8 | Text9 | Text10 | Text11 |
| --- | --- | --- | --- | --- | --- | --- | --- | --- | --- | --- | --- | --- | --- | --- | --- | --- | --- | --- | --- | --- |
| 442 | 1.3.3.2.9 | **DAQ** | 127d | 2013-04-01 | 2013-09-27 |  | 501d |  |  |  |  | ܁. |  |  |  |  |  |  |  |  |
| 443 | 1.3.3.2.9.1 | Fibers | 6.35mo | 2013-04-01 | 2013-09-27 | 412 | 501d |  |  |  |  | ܁. |  |  |  |  |  |  |  |  |
| 444 | 1.3.3.2.9.2 | Data receivers | 6.35mo | 2013-04-01 | 2013-09-27 | 413 | 501d |  |  |  |  | ܁. |  |  |  |  |  |  |  |  |
| 445 | 1.3.3.2.9.3 | Computers | 6.35mo | 2013-04-01 | 2013-09-27 | 414 | 501d |  |  |  |  | ܁. |  |  |  |  |  |  |  |  |
| 446 | 1.3.3.3 | **Assemble modules** | 131d? | 2012-10-01 | 2013-04-11 | 423SS, 426SS | 486d | 40d |  | 2096h | 201,394.16 | ܁. | Assembly problems | none | increase in labor cost, $20k/month | cost/schedule | moderate | low | low | Establish conservative assembly pipeline |
| 447 | 1.3.3.3.1 | Mount readout chips | 98d | 2012-10-01 | 2013-02-22 | 426FS-61d | 486d | 0d |  |  |  | ܁. |  |  |  |  |  |  |  |  |
| 448 | 1.3.3.3.2 | Wire bonding chips | 99d | 2012-10-15 | 2013-03-12 | 447SS+2w | 486d | 0d |  |  |  | ܁. |  |  |  |  |  |  |  |  |
| 449 | 1.3.3.3.3 | Mount sensors | 97d | 2012-10-29 | 2013-03-22 | 423SS+6mo, 448SS+2w | 486d | 0d |  |  |  | ܁. |  |  |  |  |  |  |  |  |
| 450 | 1.3.3.3.4 | Wire bonding sensors | 98d | 2012-11-12 | 2013-04-08 | 449SS+2w | 486d | 0d |  |  |  | ܁. |  |  |  |  |  |  |  |  |
| 451 | 1.3.3.3.5 | Labor wire bonding (Bates tech, 100%) | 6.55mo? | 2012-10-01 | 2013-04-11 | 447SS, 450FF | 619d | 0d | MIT Tech Proj II | 1048h | 107,640.08 | ܁. |  |  |  |  |  |  |  |  |
| 452 | 1.3.3.3.6 | Labor assembly (Dale, 100%) | 131d? | 2012-10-01 | 2013-04-11 | 451SS | 619d |  | MIT Tech Proj | 1048h | 93,754.08 |  |  |  |  |  |  |  |  |  |
| 453 | 1.3.3.4 | **Assemble staves** | 109d | 2012-11-28 | 2013-05-07 | 446SS | 486d | 40d |  |  |  | ܁. | Assembly problems | none | increase in labor cost, $20k/month | cost/schedule | moderate | low | low | Establish conservative assembly pipeline |
| 454 | 1.3.3.4.1 | Mount modules (most likely not necessary) | 17.4w | 2012-11-28 | 2013-04-05 | 425SS+2mo, 450SS+2w | 486d | 0d |  |  |  | ܁. |  |  |  |  |  |  |  |  |
| 455 | 1.3.3.4.2 | Test staves (Gerrit,Grad) | 19.8w | 2012-12-12 | 2013-05-07 | 454SS+2w | 601d | 0d |  |  |  | ܁. |  |  |  |  |  |  |  |  |
| 456 | 1.3.3.4.3 | Survey staves (Gerrit,Grad) | 17.2w | 2012-12-28 | 2013-05-02 | 455SS+2w | 604d |  |  |  |  | ܁. |  |  |  |  |  |  |  |  |
| 457 | 1.3.3.5 | **Layer Integration** | 134d? | 2013-01-30 | 2013-08-08 | 453SS | 486d | 0d |  | 296h | 26,648.88 | ܁. | Integration problems | none | none | schedule | moderate | low | low | delay installation |
| 458 | 1.3.3.5.1 | Assemble layer (Gerrit,Grad, Jim/Jason 20%) | 4mo | 2013-01-30 | 2013-05-22 | 454SS+2mo | 486d | 0d | MIT Mech Eng Project [20%] | 128h | 11,523.84 | ܁. |  |  |  |  |  |  |  |  |
| 459 | 1.3.3.5.2 | Testing layer (Gerrit,Grad) | 4mo | 2013-02-06 | 2013-05-30 | 458SS+1w | 486d | 0d |  |  |  | ܁. |  |  |  |  |  |  |  |  |
| 460 | 1.3.3.5.3 | Survey layer (Gerrit, Surveyors) | 2mo | 2013-04-04 | 2013-05-30 | 459SS+2mo | 535d |  |  |  |  | ܁. |  |  |  |  |  |  |  |  |
| 461 | 1.3.3.5.4 | Insertion into HFT (Gerrit, Jim/Jason 100%) | 1.05mo? | 2013-05-31 | 2013-06-28 | 459 | 486d | 0d | MIT Mech Eng Project | 168h | 15,125.04 | ܁. |  |  |  |  |  |  |  |  |
| 462 | 1.3.3.5.5 | Testing on HFT (Gerrit, Grad) | 2.2mo? | 2013-06-07 | 2013-08-08 | 461SS+1w | 486d | 0d |  |  |  | ܁. |  |  |  |  |  |  |  |  |
| 463 | 1.3.3.5.6 | Survey in HFT (Gerrit, Surveyors) | 1mo | 2013-07-08 | 2013-08-02 | 462SS+1mo | 490d |  |  |  |  | ܁. |  |  |  |  |  |  |  |  |
| 464 | 1.3.3.6 | **Installation in STAR** | 50d? | 2013-08-09 | 2013-10-18 | 457 | 486d |  |  |  |  | ܁. |  |  |  |  |  |  |  |  |
| 465 | 1.3.3.6.1 | Insertion (STAR Ops) | 1.1mo? | 2013-08-09 | 2013-09-10 | 462 | 486d | 0d |  |  |  | ܁. |  |  |  |  |  |  |  |  |
| 466 | 1.3.3.6.2 | Testing (Gerrit, Grad) | 2mo | 2013-08-23 | 2013-10-18 | 465SS+2w | 486d |  |  |  |  | ܁. |  |  |  |  |  |  |  |  |

Notes:
- 446: Text14: Mount readout chips on hybrids and certify operation. Mount sensors on hybrid and certify operation. Maintain quality control. Pipelined production.
- 447: 2 modules per day
- 449: 2 modules per day
- 453: Text14: Mount certified modules on staves and test for properly functioning of staves. Survey accepted staves. Rework if necessary and if schedule permits.
- 454: first 10 ladders will take 2 weeks per ladder / then geared up, rest takes 1 week per ladder
- 455: first 10 ladders will take 2 weeks per ladder / then geared up, rest takes 1 week per ladder
- 457: Text14: Integrate 24 certified staves into a layer at 14 cm radius on the Middle Support Cylinder. Test layer and survey when fully operational. Insert MSC into HFT system and test. Survey in HFT system when fully operational.
- 464: Text14: After the HFT is installed in the inner filed cage in STAR, the IST needs to be tested again for proper functioning.

| ID | WBS | Task | Type | Duration | Start | Finish | Predecessors | Total slack | Free slack | Constraint | Resources | Work | Cost | Text3 | Text4 | Text6 | Text7 | Text8 | Text9 | Text10 | Text11 | Participating Institutions |
| --- | --- | --- | --- | --- | --- | --- | --- | --- | --- | --- | --- | --- | --- | --- | --- | --- | --- | --- | --- | --- | --- | --- |
| 467 | 1.3.3.7 | **Cooling system** |  | 30d? | 2013-08-16 | 2013-09-27 |  | 501d |  |  |  | 216h | 19,446.48 | Assembly problems | none | parts and labor | cost/schedule | low | low | low | assemble early | ܁. |
| 468 | 1.3.3.7.1 | Cooling system Assembly |  | 1mo | 2013-08-16 | 2013-09-13 | 465SS+1w | 506d | 0d |  |  |  |  |  |  |  |  |  |  |  |  | ܁. |
| 469 | 1.3.3.7.2 | Cooling system Testing |  | 1mo | 2013-08-23 | 2013-09-20 | 468SS+1w | 506d |  |  |  |  |  |  |  |  |  |  |  |  |  | ܁. |
| 470 | 1.3.3.7.3 | Labor (Jim/Jason, 100%, Star Ops) |  | 27d? | 2013-08-21 | 2013-09-27 |  | 501d |  | start no earlier than 2013-08-21 | MIT Mech Eng Project | 216h | 19,446.48 |  |  |  |  |  |  |  |  |  |
| 471 | 1.3.3.8 | **Labor** |  | 267d? | 2012-10-01 | 2013-10-23 |  | 483d |  |  |  | 2539.2h | 224,338.75 |  |  |  |  |  |  |  |  | ܁. |
| 472 | 1.3.3.8.1 | Electrical assistance (Ben 40%) |  | 52.2w? | 2012-10-01 | 2013-10-15 |  | 489d |  | start no earlier than 2012-10-01 | MIT Elec Eng Project [40%] | 835.2h | 71,543.23 |  |  |  |  |  |  |  |  | ܁. |
| 473 | 1.3.3.8.2 | Mechanical assistance (Jim/Jason 30%) |  | 13mo | 2012-10-02 | 2013-10-15 |  | 489d |  | finish no earlier than 2013-10-15 | MIT Mech Eng Project [30%] | 624h | 56,178.72 |  |  |  |  |  |  |  |  | ܁. |
| 474 | 1.3.3.8.3 | Technical assistance installation (Dale 100%) |  | 135d? | 2013-04-15 | 2013-10-23 |  | 483d |  | start no earlier than 2013-04-15 | MIT Tech Proj | 1080h | 96,616.8 |  |  |  |  |  |  |  |  |  |
| 475 | 1.3.4 | **Management** |  | 806d? | 2010-08-31 | 2013-11-07 |  | 31d |  |  |  | 6264h | 105,403.85 |  |  |  |  |  |  |  |  | ܁. |
| 476 | 1.3.4.1 | Draft and Submit SOW for Post CD 1 Efforts |  | 44d | 2010-08-31 | 2010-10-29 | 17 | 31d | 0d |  |  |  |  |  |  |  |  |  |  |  |  |  |
| 477 | 1.3.4.2 | Bookkeeping |  | 39.15mo? | 2010-10-01 | 2013-11-07 |  | 472d |  | start no earlier than 2010-10-01 | MIT Book Keeper | 6264h | 105,403.85 |  |  |  |  |  |  |  |  | ܁. |
| 478 | 1.3.4.3 | **Level 1** |  | 694d? | 2011-01-03 | 2013-10-01 |  | 499d |  |  |  |  |  |  |  |  |  |  |  |  |  | ܁. |
| 479 | 1.3.4.3.1 | Sensor, module and ladder design finished | milestone | 0.05mo? | 2011-01-03 | 2011-01-03 |  | 1192d |  | start no earlier than 2011-01-03 |  |  |  |  |  |  |  |  |  |  |  | ܁. |
| 480 | 1.3.4.3.2 | Prototype ladder tested | milestone | 0.05mo? | 2011-10-03 | 2011-10-03 |  | 1002d |  | start no earlier than 2011-10-03 |  |  |  |  |  |  |  |  |  |  |  | ܁. |
| 481 | 1.3.4.3.3 | First batch of flex hybrids produced | milestone | 0.05mo? | 2012-04-02 | 2012-04-02 |  | 876d |  | start no earlier than 2012-04-02 |  |  |  |  |  |  |  |  |  |  |  | ܁. |
| 482 | 1.3.4.3.4 | First ladder produced | milestone | 0.05mo? | 2012-11-30 | 2012-11-30 |  | 707d |  | start no earlier than 2012-11-30 |  |  |  |  |  |  |  |  |  |  |  | ܁. |
| 483 | 1.3.4.3.5 | Staves finalized | milestone | 0.05mo? | 2013-04-01 | 2013-04-01 |  | 627d |  | start no earlier than 2013-04-01 |  |  |  |  |  |  |  |  |  |  |  | ܁. |
| 484 | 1.3.4.3.6 | Integrated in HFT | milestone | 0.05mo? | 2013-10-01 | 2013-10-01 |  | 499d |  | start no earlier than 2013-10-01 |  |  |  |  |  |  |  |  |  |  |  | ܁. |
| 485 | 1.3.4.4 | **Level 2** |  | 508d? | 2011-05-31 | 2013-06-04 |  | 582d |  |  |  |  |  |  |  |  |  |  |  |  |  | ܁. |
| 486 | 1.3.4.4.1 | Prototype sensors produced | milestone | 0.05mo? | 2011-05-31 | 2011-05-31 |  | 1089d |  | start no earlier than 2011-05-31 |  |  |  |  |  |  |  |  |  |  |  | ܁. |
| 487 | 1.3.4.4.2 | Prototype ladder assembled | milestone | 0.05mo? | 2011-06-15 | 2011-06-15 |  | 1078d |  | start no earlier than 2011-06-15 |  |  |  |  |  |  |  |  |  |  |  | ܁. |
| 488 | 1.3.4.4.3 | First batch of silicon sensors produced | milestone | 0.05mo? | 2012-04-02 | 2012-04-02 |  | 876d |  | start no earlier than 2012-04-02 |  |  |  |  |  |  |  |  |  |  |  | ܁. |
| 489 | 1.3.4.4.4 | Start of cooling system production | milestone | 0.05mo? | 2012-04-06 | 2012-04-06 |  | 872d |  | start no earlier than 2012-04-06 |  |  |  |  |  |  |  |  |  |  |  | ܁. |
| 490 | 1.3.4.4.5 | Start of wire bonding | milestone | 0.05mo? | 2012-10-15 | 2012-10-15 |  | 739d |  | start no earlier than 2012-10-15 |  |  |  |  |  |  |  |  |  |  |  | ܁. |
| 491 | 1.3.4.4.6 | Start of layer integration | milestone | 0.05mo? | 2013-02-04 | 2013-02-04 |  | 666d |  | start no earlier than 2013-02-04 |  |  |  |  |  |  |  |  |  |  |  | ܁. |
| 492 | 1.3.4.4.7 | Half of staves surveyed | milestone | 0.05mo? | 2013-03-29 | 2013-03-29 |  | 628d |  | start no earlier than 2013-03-29 |  |  |  |  |  |  |  |  |  |  |  | ܁. |
| 493 | 1.3.4.4.8 | Layer survey finished | milestone | 1d? | 2013-06-04 | 2013-06-04 |  | 582d |  | start no earlier than 2013-06-04 |  |  |  |  |  |  |  |  |  |  |  | ܁. |

Notes:
- 467: Text14: Cooling system needs to be installed in STAR and tested. After the HFT is installed this cooling system needs to be connected to the IST. Most likely a temporary cooling system will be used for testing before installation.
- 471: Text14: All project funded labor needed for the assembly, testing and installation.

| ID | WBS | Task | Type | Duration | Start | Finish | Predecessors | Complete | Remaining | Total slack | Free slack | Constraint | Resources | Work | Actual work | Cost | Baseline cost | Actual cost | Participating Institutions |
| --- | --- | --- | --- | --- | --- | --- | --- | --- | --- | --- | --- | --- | --- | --- | --- | --- | --- | --- | --- |
| 494 | 1.4 | **SSD** |  | 781d? | 2009-10-01 A | 2012-10-19 |  | 2% | 766.79d? | 735d |  |  |  | 2816.6h | 239.2h | 651,470.04 |  | 261.85 |  |
| 495 | 1.4.1 | **Mechanics** |  | 263d? | 2009-10-01 | 2010-10-04 |  |  |  | 1253d |  |  |  |  |  |  | 999,999,999,999.99 |  | ܁- |
| 496 | 1.4.1.1 | Mechanical envelope for PCB for Ladder Board Interface Cable |  | 5d | 2010-08-31 | 2010-09-06 | 17 |  |  | 1038d | 0d |  |  |  |  |  | 999,999,999,999.99 |  |  |
| 497 | 1.4.1.2 | Design brackets that bond to the ESC/WSC |  | 5d | 2010-08-31 | 2010-09-06 | 17 |  |  | 1253d | 0d |  |  |  |  |  | 999,999,999,999.99 |  | ܁- |
| 498 | 1.4.1.3 | Design brackets that bond to the SSD |  | 5d | 2010-09-07 | 2010-09-13 | 497 |  |  | 1253d | 0d |  |  |  |  |  | 999,999,999,999.99 |  | ܁- |
| 499 | 1.4.1.4 | Design Assembly Fixtures for alignment |  | 5d | 2010-09-14 | 2010-09-20 | 498 |  |  | 1253d | 0d |  |  |  |  |  | 999,999,999,999.99 |  | ܁- |
| 500 | 1.4.1.5 | Design Assembly fixtures for mounting to the ESC/WSC |  | 5d | 2010-09-21 | 2010-09-27 | 499 |  |  | 1253d | 0d |  |  |  |  |  | 999,999,999,999.99 |  | ܁- |
| 501 | 1.4.1.6 | Design Cable routing to patch panels |  | 5d | 2010-09-28 | 2010-10-04 | 500 |  |  | 1253d |  |  |  |  |  |  | 999,999,999,999.99 |  | ܁- |
| 502 | 1.4.1.7 | Design Patch Panels on ESC/WSC |  | 1d? | 2009-10-01 | 2009-10-01 |  |  |  | 1515d |  |  |  |  |  |  |  |  | ܁- |
| 503 | 1.4.1.8 | Cost and Schedule Estimate |  | 5d | 2009-10-01 | 2009-10-07 |  |  |  | 1481d | 0d |  |  |  |  |  | 999,999,999,999.99 |  | ܁- |
| 504 | 1.4.1.9 | Design Review |  | 14d | 2009-10-08 | 2009-10-27 | 503 |  |  | 1481d | 0d |  |  |  |  |  | 999,999,999,999.99 |  | ܁- |
| 505 | 1.4.1.10 | Mechanical Design Complete | milestone | 0d | 2009-10-27 | 2009-10-27 | 504 |  |  | 1481d | 0d |  |  |  |  |  | 999,999,999,999.99 |  | ܁- |
| 506 | 1.4.1.11 | Machine fixtures |  | 10d | 2009-10-28 | 2009-11-10 | 505 |  |  | 1485d | 0d |  |  |  |  |  | 999,999,999,999.99 |  | ܁- |
| 507 | 1.4.1.12 | Assemble fixtures |  | 2d | 2009-11-11 | 2009-11-12 | 506 |  |  | 1485d |  |  |  |  |  |  | 999,999,999,999.99 |  | ܁- |
| 508 | 1.4.1.13 | Machine brackets |  | 14d | 2009-10-28 | 2009-11-16 | 505 |  |  | 1481d | 0d |  |  |  |  |  | 999,999,999,999.99 |  | ܁- |
| 509 | 1.4.1.14 | Bond Brackets to ESC/WSC |  | 2d | 2009-11-17 | 2009-11-18 | 508 |  |  | 1481d | 0d |  |  |  |  |  | 999,999,999,999.99 |  | ܁- |
| 510 | 1.4.1.15 | Mechanics Completed | milestone | 0d | 2009-11-18 | 2009-11-18 | 509 |  |  | 1481d |  |  |  |  |  |  | -999,999,999,999.99 |  | ܁- |
| 511 | 1.4.2 | **Electronics** |  | 531d | 2010-08-31 A | 2012-10-03 |  | 4% | 511.88d | 747d |  |  |  | 2409.6h | 239.2h | 470,315.17 | -999,999,999,999.99 | 261.85 |  |
| 512 | 1.4.2.1 | **Ladder Board** |  | 459d | 2010-08-31 A | 2012-06-21 |  | 11% | 409.69d | 819d |  |  |  | 693.6h | 237.6h | 139,564.61 |  |  |  |
| 513 | 1.4.2.1.1 | **Design and Prototype** |  | 201d | 2010-08-31 A | 2011-06-16 |  | 24% | 153.28d | 847d |  |  |  | 360h | 237.6h |  | -999,999,999,999.99 |  | ܁4 |
| 514 | 1.4.2.1.1.1 | Ladder Board Design Completed | milestone | 0d | 2010-09-30 A | 2010-09-30 A |  | 100% |  |  |  | start no earlier than 2010-09-30 |  |  |  |  |  |  | ܁4 |
| 515 | 1.4.2.1.1.2 | Define Ladder Board Parts |  | 30d | 2010-08-31 A | 2010-10-11 A | 17 | 100% |  |  |  |  |  |  |  |  |  |  | ܁4 |
| 516 | 1.4.2.1.1.3 | Order and Receive Ladder Board Parts |  | 45d | 2010-09-01 A | 2010-11-02 | 515 | 99% | 0.45d | 868d | 21d |  |  | 240h | 237.6h |  |  |  | ܁* |
| 517 | 1.4.2.1.1.4 | Order and Receive Ladder Board PCB |  | 45d | 2010-09-30 | 2010-12-03 | 514 |  |  | 847d | 0d |  |  |  |  |  | 999,999,999,999.99 |  | ܁* |
| 518 | 1.4.2.1.1.5 | Assemble Ladder Prototype |  | 30d | 2010-12-06 | 2011-01-19 | 517, 516 |  |  | 847d | 0d |  | BNL Elec. Tech (Contributed) [50%] | 120h |  |  | -999,999,999,999.99 |  | ܁* |
| 519 | 1.4.2.1.1.6 | Design and Build Debug Board |  | 60d | 2010-09-30 | 2010-12-27 | 514 |  |  | 862d | 15d |  |  |  |  |  |  |  | ܁4 |
| 520 | 1.4.2.1.1.7 | Test Ladder Board Prototype |  | 90d | 2011-01-20 | 2011-05-26 | 518, 519 |  |  | 847d | 0d |  |  |  |  |  |  |  | ܁4 |
| 521 | 1.4.2.1.1.8 | Define Ladder Board Changes |  | 7d | 2011-05-27 | 2011-06-07 | 520 |  |  | 847d | 0d |  |  |  |  |  |  |  | ܁4 |
| 522 | 1.4.2.1.1.9 | Full Cost Estimate for Production |  | 7d | 2011-06-08 | 2011-06-16 | 520, 521 |  |  | 847d | 0d |  |  |  |  |  |  |  | ܁* |
| 523 | 1.4.2.1.1.10 | Ladder Board Prototype Finished | milestone | 0d | 2011-06-16 | 2011-06-16 | 522, 624 |  |  | 847d | 0d |  |  |  |  |  |  |  | ܁* |

Notes:
- 509: Need to make sure that OSC if finished
- 516: How to do Redirect?
- 517: Should this be on R & D funds?
- 518: Christophe, Few days to assemble FPGA at sub-contractor, 1 week per PCB to assemble all other components at BNL. I include some shipping time.
- 520: Should this be on BNL physics travel budget?

| ID | WBS | Task | Type | Duration | Start | Finish | Predecessors | Complete | Remaining | Total slack | Free slack | Resources | Work | Actual work | Cost | Baseline cost | Actual cost | Participating Institutions |
| --- | --- | --- | --- | --- | --- | --- | --- | --- | --- | --- | --- | --- | --- | --- | --- | --- | --- | --- |
| 524 | 1.4.2.1.2 | **Preproduction** |  | 265d | 2011-06-07 | 2012-06-21 | 521 |  |  | 819d |  |  | 141.6h |  | 13,919.3 |  |  |  |
| 525 | 1.4.2.1.2.1 | Design Review |  | 14d | 2011-11-11 | 2011-12-02 | 523, 553, 581, 600 |  |  | 819d | 0d |  |  |  |  |  |  | ܁* |
| 526 | 1.4.2.1.2.2 | Modify PCB Board |  | 21d | 2011-12-05 | 2012-01-02 | 523, 525 |  |  | 819d | 0d |  |  |  |  | 999,999,999,999.99 |  | ܁4 |
| 527 | 1.4.2.1.2.3 | Order and Receive Parts for ladder board |  | 45d | 2012-01-03 | 2012-03-07 | 526 |  |  | 894d |  | BNL Material [90%] |  |  | 900 | 999,999,999,999.99 |  | ܁* |
| 528 | 1.4.2.1.2.4 | Order and Receive PCB |  | 45d | 2012-01-03 | 2012-03-07 | 526 |  |  | 819d | 0d | BNL Material [275%] |  |  | 2,750 |  |  | ܁* |
| 529 | 1.4.2.1.2.5 | Assemble ladder board |  | 15d | 2012-03-08 | 2012-03-28 | 528 |  |  | 819d | 0d | BNL Elec. Tech (Contributed) [33%] | 39.6h |  |  |  |  | ܁* |
| 530 | 1.4.2.1.2.6 | Test ladder board |  | 60d | 2012-03-29 | 2012-06-21 | 529 |  |  | 819d |  | BNL Elec. Tech (Redirect) [21.2%] | 102h |  | 10,269.3 |  |  | ܁4 |
| 531 | 1.4.2.1.2.7 | Ladder Board Preproduction Complete | milestone | 0d | 2011-06-07 | 2011-06-07 |  |  |  | 871d | 35d |  |  |  |  | -999,999,999,999.99 |  |  |
| 532 | 1.4.2.1.3 | **Production** |  | 120d | 2011-07-28 | 2012-01-17 |  |  |  | 836d |  |  | 192h |  | 125,645.31 |  |  | ܁* |
| 533 | 1.4.2.1.3.1 | Ladder Board Production Design Review |  | 14d | 2011-07-28 | 2011-08-16 | 531, 553 |  |  | 836d | 0d |  |  |  |  |  |  | ܁* |
| 534 | 1.4.2.1.3.2 | Modify Ladder Board if Necessary |  | 14d | 2011-08-17 | 2011-09-06 | 533 |  |  | 836d | 0d |  |  |  |  | 999,999,999,999.99 |  | ܁4 |
| 535 | 1.4.2.1.3.3 | Order and Receive Parts for Remaing Boards |  | 60d | 2011-09-07 | 2011-12-01 | 534 |  |  | 961d |  | BNL Material [3750%] |  |  | 37,500 | -999,999,999,999.99 |  | ܁* |
| 536 | 1.4.2.1.3.4 | Order and Receive PCB |  | 45d | 2011-09-07 | 2011-11-08 | 534 |  |  | 836d | 0d | BNL Material [5766%] |  |  | 57,660 |  |  | ܁* |
| 537 | 1.4.2.1.3.5 | Assemble Ladder Boards |  | 21d | 2011-11-09 | 2011-12-09 | 536 |  |  | 836d | 0d | BNL Material [1700%] |  |  | 17,000 | -999,999,999,999.99 |  | ܁* |
| 538 | 1.4.2.1.3.6 | Test Boards |  | 10d | 2011-12-12 | 2011-12-23 | 537 |  |  | 836d | 0d | BNL Elec. Eng Sr. (Redirect) | 80h |  | 13,485.31 |  |  | ܁* |
| 539 | 1.4.2.1.3.7 | Assemble ladder boards on ladders |  | 2d | 2011-12-26 | 2011-12-27 | 538 |  |  | 836d | 0d |  |  |  |  |  |  | ܁4 |
| 540 | 1.4.2.1.3.8 | Test ladders on Bench |  | 14d | 2011-12-28 | 2012-01-17 | 539 |  |  | 836d | 0d | SUBATECH Engineer | 112h |  |  |  |  | ܁* |
| 541 | 1.4.2.1.3.9 | Ladder Board Production Complete | milestone | 0d | 2012-01-17 | 2012-01-17 | 540 |  |  | 836d | 0d |  |  |  |  | -999,999,999,999.99 |  | ܁* |
| 542 | 1.4.2.2 | **RDO Board** |  | 531d | 2010-08-31 A | 2012-10-03 |  |  | 530.77d | 747d |  |  | 1716h | 1.6h | 317,350.56 |  | 261.85 | ܁* |
| 543 | 1.4.2.2.1 | **Prototype** |  | 229d | 2010-08-31 A | 2011-07-27 |  |  | 228.79d | 1049d |  |  | 912h | 1.6h | 118,374.31 | -999,999,999,999.99 | 261.85 | ܁* |
| 544 | 1.4.2.2.1.1 | FPGA Design for VME |  | 30d | 2010-09-30 | 2010-11-10 | 514 |  |  | 751d | 0d |  |  |  |  |  |  | ܁4 |
| 545 | 1.4.2.2.1.2 | FPGA Design for Trigger/DAQ |  | 80d | 2010-11-11 | 2011-03-10 | 544 |  |  | 751d | 1d |  |  |  |  | 999,999,999,999.99 |  | ܁4 |
| 546 | 1.4.2.2.1.3 | Slave FPGA Design |  | 55d | 2010-08-31 | 2010-11-15 | 17 |  |  | 828d | 0d | BNL Scientist Sr. (Redirect) [1.8%] | 8h |  | 1,585.11 |  |  | ܁* |
| 547 | 1.4.2.2.1.4 | Order Altera Tool Support |  | 1d | 2010-12-02 | 2010-12-02 | 546FS+10d |  |  | 1212d |  | BNL Material [250%] |  |  | 2,500 |  |  | ܁* |
| 548 | 1.4.2.2.1.5 | Design RDO Board |  | 48d | 2011-01-03 A | 2011-03-11 |  | 1% | 47.69d | 735d | 0d | BNL Elec. Eng Sr. (Redirect); BNL Elec. Tech (Redirect) | 480h | 1.6h | 62,736.89 |  | 261.85 | ܁* |
| 549 | 1.4.2.2.1.6 | Order and Receive RDO Parts |  | 45d | 2011-03-14 | 2011-05-13 | 548 |  |  | 735d | 0d | BNL Elec. Tech (Redirect) [27.8%]; BNL Material | 100h |  | 10,774.7 |  |  | ܁* |
| 550 | 1.4.2.2.1.7 | Order and Receive RDO Board PCB |  | 30d | 2011-03-14 | 2011-04-22 | 544, 545, 546, 548 |  |  | 750d | 15d | BNL Material [150%] |  |  | 1,500 |  |  | ܁* |
| 551 | 1.4.2.2.1.8 | Assemble RDO Board Prototype |  | 21d | 2011-05-16 | 2011-06-14 | 549, 550 |  |  | 735d | 0d | BNL Elec. Tech (Contributed) [50%] | 84h |  |  |  |  | ܁* |
| 552 | 1.4.2.2.1.9 | Test RDO Board Prototype |  | 30d | 2011-06-15 | 2011-07-27 | 551 |  |  | 735d | 0d | BNL Elec. Eng Sr. (Redirect) | 240h |  | 39,277.61 |  |  | ܁* |
| 553 | 1.4.2.2.1.10 | RDO Prototype Complete | milestone | 0d | 2011-07-27 | 2011-07-27 | 552 |  |  | 735d | 0d |  |  |  |  | -999,999,999,999.99 |  | ܁* |

Notes:
- 529: should be labeled contributed
- 530: Added extra time in case need modifications to board.
- 536: Using quote for prototype ladder board
- 545: Christophe says this may be much longer.
- 548: Estimate of time to complete schematic and lay out board: 2 months (allowing for other commitments of STAR personnel)

| ID | WBS | Task | Type | Duration | Start | Finish | Predecessors | Total slack | Free slack | Resources | Work | Cost | Baseline cost | Participating Institutions |
| --- | --- | --- | --- | --- | --- | --- | --- | --- | --- | --- | --- | --- | --- | --- |
| 554 | 1.4.2.2.2 | **Preproduction** |  | 163d | 2011-07-28 | 2012-03-19 |  | 747d |  |  | 600h | 101,300.52 | -999,999,999,999.99 | ܁* |
| 555 | 1.4.2.2.2.1 | Preproduction Design Review |  | 14d | 2011-07-28 | 2011-08-16 | 553 | 747d | 0d |  |  |  | -999,999,999,999.99 | ܁* |
| 556 | 1.4.2.2.2.2 | Order Synopsys Tool Support |  | 1d | 2011-08-31 | 2011-08-31 | 555FS+10d | 983d | 0d | BNL Material [400%] |  | 4,000 | -0 | ܁* |
| 557 | 1.4.2.2.2.3 | Order Altera Tool Support |  | 1d | 2011-10-28 | 2011-10-28 | 556FS+40d | 983d |  | BNL Material [250%] |  | 2,500 | -0 | ܁* |
| 558 | 1.4.2.2.2.4 | Full Cost Estimate for Production |  | 3d | 2011-07-28 | 2011-08-01 | 552 | 758d | 11d |  |  |  |  | ܁* |
| 559 | 1.4.2.2.2.5 | Modify PCB Board |  | 14d | 2011-08-17 | 2011-09-06 | 555, 558 | 747d | 0d |  |  |  |  | ܁* |
| 560 | 1.4.2.2.2.6 | Order and Receive Parts |  | 60d | 2011-09-07 | 2011-12-01 | 559 | 747d | 0d | BNL Material |  | 1,000 | -999,999,999,999.99 | ܁* |
| 561 | 1.4.2.2.2.7 | Order and Receive PCB |  | 30d | 2011-09-07 | 2011-10-18 | 559 | 777d | 30d | BNL Material [200%] |  | 2,000 | -999,999,999,999.99 | ܁* |
| 562 | 1.4.2.2.2.8 | Assemble Boards |  | 15d | 2011-12-02 | 2011-12-22 | 560, 561 | 747d | 0d | BNL Elec. Tech (Redirect) | 120h | 12,081.53 |  | ܁* |
| 563 | 1.4.2.2.2.9 | Test Boards |  | 60d | 2011-12-23 | 2012-03-19 | 562 | 747d | 0d | BNL Material [1510%]; BNL Elec. Tech (Redirect); BNL Elec. Eng Sr. (Redirect) | 480h | 79,718.99 | -999,999,999,999.99 | ܁* |
| 564 | 1.4.2.2.2.10 | RDO Preproduction Complete | milestone | 0d | 2012-03-19 | 2012-03-19 | 563 | 747d | 0d |  |  |  | -999,999,999,999.99 | ܁* |
| 565 | 1.4.2.2.3 | **Production** |  | 139d | 2012-03-20 | 2012-10-03 |  | 747d |  |  | 204h | 97,675.72 | -999,999,999,999.99 | ܁* |
| 566 | 1.4.2.2.3.1 | Order Synopsys Tool Support |  | 1d | 2012-05-15 | 2012-05-15 | 564FS+40d | 824d | 0d | BNL Material [400%] |  | 4,000 |  | ܁* |
| 567 | 1.4.2.2.3.2 | Order Altera Tool Support |  | 1d | 2012-06-14 | 2012-06-14 | 566FS+20d | 824d |  | BNL Material [250%] |  | 2,500 |  | ܁* |
| 568 | 1.4.2.2.3.3 | RDO Production Design Review |  | 14d | 2012-03-20 | 2012-04-06 | 531, 564 | 747d | 0d |  |  |  | -999,999,999,999.99 | ܁* |
| 569 | 1.4.2.2.3.4 | Modify RDO Board Design (if necessary) |  | 14d | 2012-04-09 | 2012-04-26 | 568 | 747d | 0d |  |  |  | -999,999,999,999.99 | ܁* |
| 570 | 1.4.2.2.3.5 | Order and Receive Parts |  | 60d | 2012-04-27 | 2012-07-23 | 569 | 747d | 0d | BNL Material [4753%] |  | 47,530 | -999,999,999,999.99 | ܁* |
| 571 | 1.4.2.2.3.6 | Order and Receive PCB |  | 45d | 2012-04-27 | 2012-06-29 | 569 | 762d | 15d | BNL Material [490%] |  | 4,900 | -999,999,999,999.99 | ܁* |
| 572 | 1.4.2.2.3.7 | Assemble Boards |  | 21d | 2012-07-24 | 2012-08-21 | 570, 571 | 747d | 0d | BNL Material [1000%]; BNL Elec. Tech (Redirect) [50%] | 84h | 18,457.07 | -999,999,999,999.99 | ܁* |
| 573 | 1.4.2.2.3.8 | Test Boards |  | 30d | 2012-08-22 | 2012-10-03 | 572 | 747d | 0d | BNL Elec. Eng Sr. (Redirect) [50%] | 120h | 20,288.65 | -999,999,999,999.99 | ܁* |
| 574 | 1.4.2.2.3.9 | RDO Production Complete | milestone | 0d | 2012-10-03 | 2012-10-03 | 573 | 747d | 0d |  |  |  | 999,999,999,999.99 | ܁* |
| 575 | 1.4.2.3 | **DAQ** |  | 345d | 2010-08-31 | 2012-01-10 |  | 899d |  |  |  | 13,400 |  | ܁* |
| 576 | 1.4.2.3.1 | **Prototype DAQ** |  | 150d | 2010-08-31 | 2011-04-05 |  | 899d |  |  |  | 2,900 | 999,999,999,999.99 | ܁* |
| 577 | 1.4.2.3.1.1 | Obtain DAQ Computer for testing |  | 30d | 2010-08-31 | 2010-10-11 | 17 | 993d | 60d | BNL Material [290%] |  | 2,900 |  | ܁* |
| 578 | 1.4.2.3.1.2 | Obtain DRORC Card |  | 1d | 2010-08-31 | 2010-08-31 | 17 | 1022d | 89d |  |  |  |  | ܁* |
| 579 | 1.4.2.3.1.3 | Order and receive a TCD |  | 90d | 2010-08-31 | 2011-01-07 | 17 | 899d | 0d |  |  |  |  | ܁* |
| 580 | 1.4.2.3.1.4 | Develop prototype test software |  | 60d | 2011-01-10 | 2011-04-05 | 577, 578, 579 | 933d | 0d |  |  |  |  | ܁* |
| 581 | 1.4.2.3.1.5 | Prototype DAQ Software Complete | milestone | 0d | 2011-04-05 | 2011-04-05 | 580 | 933d | 0d |  |  |  | 999,999,999,999.99 | ܁* |

Notes:
- 561: Add 15 days for BNL purchasing
- 563: There is some contingency in this schedule in case there is a problem with the board.
- 571: Add 15 days for BNL purchasing
- 577: From Tonko. Need to change to BNL Material

| ID | WBS | Task | Type | Duration | Start | Finish | Predecessors | Total slack | Free slack | Resources | Cost | Baseline cost | Participating Institutions |
| --- | --- | --- | --- | --- | --- | --- | --- | --- | --- | --- | --- | --- | --- |
| 582 | 1.4.2.3.2 | **Production DAQ** |  | 195d | 2011-04-06 | 2012-01-10 |  | 933d |  |  | 10,500 |  | ܁* |
| 583 | 1.4.2.3.2.1 | Design Review |  | 14d | 2011-04-06 | 2011-04-25 | 581 | 933d | 0d |  |  |  | ܁* |
| 584 | 1.4.2.3.2.2 | Obtain Second DAQ Computer |  | 30d | 2011-04-26 | 2011-06-07 | 583 | 1053d | 120d | BNL Material [290%] | 2,900 | -999,999,999,999.99 | ܁* |
| 585 | 1.4.2.3.2.3 | Order 1 more DRORC plus 1 spare |  | 90d | 2011-04-26 | 2011-08-31 | 583 | 933d | 0d | BNL Material [340%] | 3,400 | 999,999,999,999.99 | ܁* |
| 586 | 1.4.2.3.2.4 | Order 6 SIU |  | 90d | 2011-04-26 | 2011-08-31 | 583 | 933d | 0d | BNL Material [420%] | 4,200 |  | ܁* |
| 587 | 1.4.2.3.2.5 | Develop Final testing software |  | 60d | 2011-09-01 | 2011-11-28 | 581, 585, 586 | 933d | 0d |  |  |  | ܁* |
| 588 | 1.4.2.3.2.6 | Develop DAQ Software |  | 30d | 2011-04-06 | 2011-05-17 | 581 | 1067d | 134d |  |  | 999,999,999,999.99 | ܁* |
| 589 | 1.4.2.3.2.7 | Test Ladders on Bench |  | 30d | 2011-11-29 | 2012-01-09 | 584, 587, 588 | 933d | 0d |  |  | 999,999,999,999.99 | ܁* |
| 590 | 1.4.2.3.2.8 | Assemble DAQ Computer in DAQ Room |  | 1d | 2012-01-10 | 2012-01-10 | 585, 589 | 933d | 0d |  |  | 999,999,999,999.99 | ܁* |
| 591 | 1.4.2.3.2.9 | DAQ Complete | milestone | 0d | 2012-01-10 | 2012-01-10 | 590 | 933d | 186d |  |  |  | ܁* |
| 592 | 1.4.2.4 | **Integrated Test System** |  | 214d | 2011-01-10 | 2011-11-10 |  | 819d |  |  |  |  |  |
| 593 | 1.4.2.4.1 | Assemble Trigger System(s) |  | 15d | 2011-01-10 | 2011-01-31 | 579 | 899d | 0d |  |  |  | ܁* |
| 594 | 1.4.2.4.2 | Obtain Power Supply, VME Crate, Computer |  | 15d | 2011-02-01 | 2011-02-21 | 593 | 899d | 0d |  |  |  | ܁* |
| 595 | 1.4.2.4.3 | Obtain Ladder Board and RDO Board |  | 1d | 2011-07-28 | 2011-07-28 | 523, 553 | 819d | 0d |  |  | 999,999,999,999.99 | ܁* |
| 596 | 1.4.2.4.4 | Define first generation test software |  | 30d | 2011-02-22 | 2011-04-05 | 594 | 899d | 80d |  |  |  | ܁* |
| 597 | 1.4.2.4.5 | Provide first generation Slow Control Software |  | 30d | 2011-07-29 | 2011-09-09 | 595, 596 | 819d | 0d |  |  |  | ܁* |
| 598 | 1.4.2.4.6 | Test system up to and not including DAQ |  | 30d | 2011-09-12 | 2011-10-21 | 593, 594, 595, 597 | 819d | 0d |  |  |  | ܁* |
| 599 | 1.4.2.4.7 | Test including DAQ |  | 14d | 2011-10-24 | 2011-11-10 | 598 | 819d | 0d |  |  |  | ܁* |
| 600 | 1.4.2.4.8 | Testing Complete | milestone | 0d | 2011-11-10 | 2011-11-10 | 599 | 819d | 0d |  |  | -999,999,999,999.99 | ܁* |
| 601 | 1.4.2.5 | Electronics Complete | milestone | 0d | 2012-10-03 | 2012-10-03 | 541, 574, 591 | 747d |  |  |  |  |  |
| 602 | 1.4.3 | **Assembly** |  | 442d | 2010-08-31 | 2012-05-29 |  | 836d |  |  | 10,183.38 |  |  |
| 603 | 1.4.3.1 | **Alignment** |  | 394d | 2010-08-31 | 2012-03-21 |  | 836d |  |  | 2,373.69 |  |  |
| 604 | 1.4.3.1.1 | Define Method |  | 15d | 2010-08-31 | 2010-09-20 | 17 | 1170d | 334d |  |  |  | ܁- |
| 605 | 1.4.3.1.2 | Ship to LBNL |  | 15d | 2012-01-18 | 2012-02-07 | 541, 604 | 836d | 0d | LBL_Material [200%] | 2,373.69 |  | ܁- |
| 606 | 1.4.3.1.1 | Alignment (Temporary Placeholder) |  | 30d | 2012-02-08 | 2012-03-21 | 605 | 836d | 0d |  |  |  |  |
| 607 | 1.4.3.1.3 | Alignment Complete | milestone | 0d | 2012-03-21 | 2012-03-21 | 606 | 836d | 0d |  |  |  | ܁- |

Notes:
- 584: Tonko's estimate - Change to BNL Material
- 597: I estimate 6-8 months. The platform (VxWorks or ???) has to be defined, the basic functionality and interface has to be working and some specific "buttons" have to be implemented, whether command line or GUI, doesn't matter. But this will not happen in a week or two
- 607: Need to add alignment work from other part of WBS section

| ID | WBS | Task | Type | Duration | Start | Finish | Predecessors | Total slack | Free slack | Constraint | Resources | Work | Cost | Baseline cost | Participating Institutions |
| --- | --- | --- | --- | --- | --- | --- | --- | --- | --- | --- | --- | --- | --- | --- | --- |
| 608 | 1.4.3.2 | **OSC Assembly** |  | 78d | 2012-02-08 | 2012-05-29 |  | 836d | 0d |  |  |  | 7,809.69 |  |  |
| 609 | 1.4.3.2.1 | Ship to Assembly Hall |  | 15d | 2012-03-22 | 2012-04-11 | 607 | 836d | 0d |  | LBL_Material [200%] |  | 2,373.69 |  | ܁- |
| 610 | 1.4.3.2.2 | Install Ladders on ESC/WSC |  | 1d | 2012-04-12 | 2012-04-12 | 609 | 836d | 0d |  |  |  |  |  | ܁* |
| 611 | 1.4.3.2.3 | Installation of ESC and WSC patch panels complete | milestone | 0d | 2012-02-08 | 2012-02-08 |  | 882d | 16d | start no earlier than 2012-02-08 |  |  |  |  | ܁* |
| 612 | 1.4.3.2.4 | Attach Cables on Ladders and Patch Panel |  | 1d | 2012-04-13 | 2012-04-13 | 610, 611 | 836d | 0d |  |  |  |  |  | ܁* |
| 613 | 1.4.3.2.5 | Temporary Cooling? |  | 1d | 2012-04-16 | 2012-04-16 | 612 | 836d | 0d |  |  |  |  |  | ܁* |
| 614 | 1.4.3.2.6 | Test System |  | 30d | 2012-04-17 | 2012-05-29 | 612, 613 | 836d | 0d |  | BNL Travel [360%] |  | 5,436 |  | ܁* |
| 615 | 1.4.3.2.7 | Assembly on ESC/WSC Complete | milestone | 0d | 2012-05-29 | 2012-05-29 | 614 | 836d |  |  |  |  |  |  | ܁* |
| 616 | 1.4.3.3 | Ready to Install in STAR | milestone | 0d | 2012-05-29 | 2012-05-29 | 608 | 836d |  |  |  |  |  |  |  |
| 617 | 1.4.4 | **Infrastructure** |  | 543d | 2010-08-31 | 2012-10-19 |  | 735d |  |  |  | 407h | 170,971.49 |  |  |
| 618 | 1.4.4.1 | **Cables** |  | 395d | 2010-09-07 | 2012-03-29 |  | 878d | 143d |  |  | 395h | 52,684.96 |  | ܁- |
| 619 | 1.4.4.1.1 | **Power Cables - Ladder Board to ESC/WSC Patch Panel** |  | 394d | 2010-09-07 | 2012-03-28 |  | 879d |  |  |  | 154h | 28,687.98 | 999,999,999,999.99 |  |
| 620 | 1.4.4.1.1.1 | Design PCB for Ladder Board Interface Cable |  | 2d | 2010-09-07 | 2010-09-08 | 496 | 1038d | 0d |  | LBL_Electrical Designer | 16h | 1,644 | -999,999,999,999.99 | ܁- |
| 621 | 1.4.4.1.1.2 | Order and Receive PCB |  | 3w | 2010-09-09 | 2010-09-29 | 620 | 1254.8d | 0d |  |  |  |  | -999,999,999,999.99 | ܁- |
| 622 | 1.4.4.1.1.3 | Fabricate PCB Test Interface Cable |  | 1.2d | 2010-09-30 | 2010-10-01 | 621 | 1254.8d |  |  | LBL_Mech Eng Sr.; MIT Mech Eng Project; LBL_Mech Tech 4 | 24h | 2,422.28 | 999,999,999,999.99 | ܁- |
| 623 | 1.4.4.1.1.4 | Program Tester |  | 2d | 2010-09-09 | 2010-09-10 | 620 | 1038d | 0d |  | LBL_Mech Eng Sr. | 16h | 2,251.84 | 999,999,999,999.99 | ܁- |
| 624 | 1.4.4.1.1.5 | Build Tester |  | 1d | 2010-09-13 | 2010-09-13 | 623 | 1038d | 0d |  | LBL_Elec Tech | 8h | 661.44 |  | ܁- |
| 625 | 1.4.4.1.1.6 | Test Assembly |  | 14d | 2010-09-14 | 2010-10-01 | 624 | 1159d | 280d |  |  |  |  |  | ܁- |
| 626 | 1.4.4.1.1.7 | Design Review |  | 14d | 2011-11-11 | 2011-12-02 | 523, 553, 581, 600, 625 | 879d | 0d |  |  |  |  |  | ܁- |
| 627 | 1.4.4.1.1.8 | Modify PCB Board (if necessary) |  | 5d | 2011-12-05 | 2011-12-09 | 626 | 879d | 0d |  | LBL_Elec Eng Sr [20%] | 8h | 1,125.49 |  | ܁- |
| 628 | 1.4.4.1.1.9 | Order and Receive PCB Board |  | 30d | 2011-12-12 | 2012-01-23 | 627 | 879d | 0d |  | LBL_Material [70%] |  | 830.79 |  | ܁- |
| 629 | 1.4.4.1.1.10 | Design and Select Cable |  | 1d | 2012-01-24 | 2012-01-24 | 628 | 879d | 0d |  | LBL_Elec Eng Sr [25%] | 2h | 281.37 |  | ܁- |
| 630 | 1.4.4.1.1.11 | Order and Receive Cable |  | 30d | 2012-01-25 | 2012-03-07 | 629 | 879d | 0d |  | LBL_Material [751%] |  | 8,913.21 |  | ܁- |
| 631 | 1.4.4.1.1.12 | Build Cable Assembly |  | 10d | 2012-03-08 | 2012-03-28 | 630 | 879d | 0d |  | LBL_Mech Tech 4; LBL_Material [163%] | 80h | 10,557.55 |  | ܁- |
| 632 | 1.4.4.1.1.13 | ESC/WSC Cables Ready to be Installed | milestone | 0d | 2012-03-28 | 2012-03-28 | 631 | 879d |  |  |  |  |  |  | ܁- |

Notes:
- 611: The installation needs to be in the integration section. The date is arbritrary.
- 614: 3 people sharing BNL apartment 1 month
- 631: Cable assembly 50 each / ~~~~~~ - 2 hours each per cable with color code cable or 80 hours for Technician. / ~~~~~~ - 2.5 hours each per cable without color code cable or 100 hours for Technician.

| ID | WBS | Task | Type | Duration | Start | Finish | Predecessors | Total slack | Free slack | Constraint | Resources | Work | Cost | Baseline cost | Participating Institutions |
| --- | --- | --- | --- | --- | --- | --- | --- | --- | --- | --- | --- | --- | --- | --- | --- |
| 633 | 1.4.4.1.2 | **Fiber Cables - Ladder Board to ESC/WSC Patch Panel** |  | 52d | 2012-01-17 | 2012-03-29 |  | 878d |  |  |  |  | 1,186.85 |  |  |
| 634 | 1.4.4.1.2.1 | Design |  | 7d | 2012-01-17 | 2012-01-25 |  | 878d | 0d | start no earlier than 2012-01-17 |  |  |  |  | ܁* |
| 635 | 1.4.4.1.2.2 | Order and Receive Fiber |  | 45d | 2012-01-26 | 2012-03-29 | 634 | 878d | 0d |  | LBL_Material |  | 1,186.85 |  | ܁* |
| 636 | 1.4.4.1.2.3 | Ladder Board Fibers Ready to be Installed | milestone | 0d | 2012-03-29 | 2012-03-29 | 635 | 878d |  |  |  |  |  |  | ܁* |
| 637 | 1.4.4.1.3 | **Power and Fibers - ESC/WSC Patch Panel to Rack Patch Panel** |  | 60d | 2011-06-17 | 2011-09-12 |  | 1017d |  |  |  | 208h | 20,403.13 | 999,999,999,999.99 | ܁* |
| 638 | 1.4.4.1.3.1 | Specify Fiber Cable |  | 5d | 2011-06-17 | 2011-06-23 | 523 | 1017d | 0d |  | BNL Elec. Eng Sr. (Redirect) [10%] | 4h | 654.63 |  | ܁* |
| 639 | 1.4.4.1.3.2 | Design Power Cable |  | 5d | 2011-06-17 | 2011-06-23 | 523 | 1017d | 0d |  | BNL Elec. Eng Sr. (Redirect) [20%] | 8h | 1,309.25 | 999,999,999,999.99 | ܁* |
| 640 | 1.4.4.1.3.3 | Order and Receive Fiber Cable |  | 30d | 2011-06-24 | 2011-08-05 | 638 | 1042d |  |  | BNL Material [101%] |  | 1,010 | 999,999,999,999.99 | ܁* |
| 641 | 1.4.4.1.3.4 | Order and Receive Power Cable |  | 30d | 2011-06-24 | 2011-08-05 | 639 | 1022d | 0d |  | BNL Material [1158%] |  | 11,580 |  | ܁* |
| 642 | 1.4.4.1.3.5 | Attach Ends to Power Cable |  | 20d | 2011-08-08 | 2011-09-02 | 641 | 1022d |  |  | BNL Elec. Tech (Contributed) [55%] | 88h |  |  | ܁* |
| 643 | 1.4.4.1.3.6 | Design "Power Patch Panel" |  | 5d | 2011-06-24 | 2011-06-30 | 639 | 1017d | 0d |  | BNL Elec. Eng Sr. (Redirect) [20%] | 8h | 1,309.25 |  | ܁* |
| 644 | 1.4.4.1.3.7 | Design "Fiber Patch Panel" |  | 5d | 2011-06-24 | 2011-06-30 | 638 | 1017d | 0d |  | BNL Elec. Tech (Contributed) [10%] | 4h |  |  | ܁* |
| 645 | 1.4.4.1.3.8 | Order parts for Power and Fiber Rack Patch Panels |  | 30d | 2011-07-01 | 2011-08-12 | 643, 644 | 1017d | 0d |  | BNL Elec. Tech (Contributed) [3.3%] | 8h |  |  | ܁* |
| 646 | 1.4.4.1.3.9 | Build "Rack Power Patch Panel" |  | 20d | 2011-08-15 | 2011-09-12 | 645 | 1017d | 0d |  | BNL Material [354%]; BNL Elec. Tech (Contributed) [50%] | 80h | 3,540 |  | ܁* |
| 647 | 1.4.4.1.3.10 | Build "Rack Fiber Patch Panel" |  | 5d | 2011-08-15 | 2011-08-19 | 645 | 1032d | 15d |  | BNL Material; BNL Elec. Tech (Contributed) [20%] | 8h | 1,000 |  | ܁* |
| 648 | 1.4.4.1.3.11 | Patch Panel to Rack Cables Complete | milestone | 0d | 2011-09-12 | 2011-09-12 | 646, 647 | 1017d |  |  |  |  |  | -999,999,999,999.99 | ܁* |
| 649 | 1.4.4.1.4 | **Optical Fibers from Rack Patch Panel to VME to DAQ** |  | 45d | 2011-06-17 | 2011-08-19 |  | 1032d |  |  |  | 33h | 2,407 | -999,999,999,999.99 | ܁* |
| 650 | 1.4.4.1.4.1 | Specify Fiber Cables |  | 5d | 2011-06-17 | 2011-06-23 | 523 | 1032d | 0d |  | BNL Elec. Eng Sr. (Redirect) [20%] | 8h | 1,309.25 |  | ܁* |
| 651 | 1.4.4.1.4.2 | Design "To DAQ Patch Panel" |  | 10d | 2011-06-24 | 2011-07-08 | 650 | 1032d | 0d |  | BNL Elec. Tech (Contributed) [30%] | 24h |  | -999,999,999,999.99 | ܁* |
| 652 | 1.4.4.1.4.3 | Order and Receive "DAQ Patch Panel" supplies |  | 30d | 2011-07-11 | 2011-08-19 | 651 | 1032d | 0d |  | BNL Material [50%] |  | 500 |  | ܁* |
| 653 | 1.4.4.1.4.4 | Order and Receive Jumper Fiber Cables |  | 30d | 2011-07-11 | 2011-08-19 | 651 | 1032d | 0d |  | BNL Elec. Tech (Redirect) [0.4%]; BNL Material [50%] | 1h | 597.75 | -999,999,999,999.99 | ܁* |
| 654 | 1.4.4.1.4.5 | Fiber Ready to be installed from Rack to DAQ | milestone | 0d | 2011-08-19 | 2011-08-19 | 653, 652 | 1032d |  |  |  |  |  | -999,999,999,999.99 | ܁* |
| 655 | 1.4.4.2 | **Power Supply** |  | 310d | 2011-01-21 | 2012-04-10 |  | 870d | 135d |  |  | 4h | 110,866.53 |  | ܁- |
| 656 | 1.4.4.2.1 | Define Parameters |  | 15d | 2011-06-17 | 2011-07-08 | 523 | 1062d |  |  |  |  |  |  | ܁- |
| 657 | 1.4.4.2.2 | Get Bids |  | 30d | 2011-01-21 | 2011-03-04 |  | 871d | 0d | start no earlier than 2011-01-21 |  |  |  |  | ܁- |
| 658 | 1.4.4.2.3 | Select Vendor |  | 60d | 2011-03-07 | 2011-05-27 | 657 | 871d | 0d |  |  |  |  |  | ܁- |
| 659 | 1.4.4.2.4 | Order and Receive Components for Testing including Patch Cable |  | 70d | 2011-05-31 | 2011-09-07 | 658 | 871d | 0d |  | LBL_Material [1843%] |  | 21,444.67 | -999,999,999,999.99 | ܁- |
| 660 | 1.4.4.2.5 | Test System |  | 60d | 2011-09-08 | 2011-12-02 | 659 | 871d | 0d |  |  |  |  |  | ܁- |
| 661 | 1.4.4.2.6 | Design Rack Power Patch Cables |  | 5d | 2011-12-05 | 2011-12-09 | 660 | 871d | 0d |  | LBL_Elec Eng Sr [10%] | 4h | 562.74 | -999,999,999,999.99 | ܁- |
| 662 | 1.4.4.2.7 | Design Review |  | 14d | 2011-12-12 | 2011-12-29 | 661 | 871d | 0d |  |  |  |  |  | ܁- |
| 663 | 1.4.4.2.8 | Order/Receive Power Cables from Patch Panel to Power Supply |  | 70d | 2011-12-30 | 2012-04-09 | 662 | 871d | 1d |  | LBL_Material [358%] |  | 4,248.91 | -999,999,999,999.99 | ܁- |
| 664 | 1.4.4.2.9 | Order Balance of HV Components |  | 70d | 2012-01-02 | 2012-04-10 | 662 | 870d | 0d | start no earlier than 2012-01-02 | LBL_Material [7129%] |  | 84,610.21 | -999,999,999,999.99 | ܁- |
| 665 | 1.4.4.2.10 | Power Supply Order Complete | milestone | 0d | 2012-04-10 | 2012-04-10 | 664, 663 | 870d |  |  |  |  |  | -999,999,999,999.99 | ܁- |

Notes:
- 659: Vendor Quote / Time quote is 10 to 12 weeks. Add 10 days for purchasing.
- 664: Vendor Quote / Time quote is 10 to 12 weeks. Add 10 days for purchasing. / Add 1k for patch cables so that can use supply.

| ID | WBS | Task | Type | Duration | Start | Finish | Predecessors | Total slack | Free slack | Constraint | Resources | Work | Cost | Baseline cost | Participating Institutions |
| --- | --- | --- | --- | --- | --- | --- | --- | --- | --- | --- | --- | --- | --- | --- | --- |
| 666 | 1.4.4.3 | **Cooling** |  | 515d | 2010-08-31 | 2012-09-11 |  | 763d | 0d |  |  | 8h | 5,420 |  | ܁- |
| 667 | 1.4.4.3.1 | Design prototype cooling |  | 120d | 2010-08-31 | 2011-02-21 | 17 | 763d | 0d |  |  |  |  |  | ܁- |
| 668 | 1.4.4.3.2 | Order, Receive, and Install Prototype Vacuum Source |  | 120d | 2011-02-22 | 2011-08-11 | 667 | 763d | 0d |  | BNL Material [392%] |  | 3,920 |  | ܁- |
| 669 | 1.4.4.3.3 | Build prototype cooling |  | 30d | 2011-08-12 | 2011-09-23 | 668 | 763d | 0d |  |  |  |  |  | ܁* |
| 670 | 1.4.4.3.4 | Design mock Ladder |  | 7d | 2011-09-26 | 2011-10-04 | 669 | 763d | 0d |  |  |  |  |  | ܁- |
| 671 | 1.4.4.3.5 | Build mock ladder |  | 30d | 2011-10-05 | 2011-11-15 | 670 | 763d | 0d |  |  |  |  |  | ܁* |
| 672 | 1.4.4.3.6 | Assemble mock ladder and prototype cooling |  | 15d | 2011-11-16 | 2011-12-08 | 671 | 763d | 0d |  |  |  |  |  | ܁* |
| 673 | 1.4.4.3.7 | Test Prototype |  | 30d | 2011-12-09 | 2012-01-20 | 672 | 763d | 0d |  |  |  |  |  | ܁- |
| 674 | 1.4.4.3.8 | Cost Estimate |  | 14d | 2011-12-09 | 2011-12-28 | 673SS | 763d | 0d |  |  | 8h |  |  | ܁- |
| 675 | 1.4.4.3.9 | Design Review |  | 15d | 2011-12-29 | 2012-01-19 | 674 | 763d | 0d |  |  |  |  | -81.93 | ܁- |
| 676 | 1.4.4.3.10 | Order Parts, Build and Install System |  | 150d | 2012-01-20 | 2012-08-21 | 675 | 763d | 0d |  | BNL Material [150%] |  | 1,500 |  | ܁* |
| 677 | 1.4.4.3.11 | Test System |  | 14d | 2012-08-22 | 2012-09-11 | 676 | 763d | 0d |  |  |  |  |  | ܁- |
| 678 | 1.4.4.3.12 | Cooling System Complete | milestone | 0d | 2012-09-11 | 2012-09-11 | 677 | 763d |  |  |  |  |  |  | ܁- |
| 679 | 1.4.4.4 | **Slow Controls** |  | 438d | 2011-02-01 | 2012-10-19 |  | 735d | 0d |  |  |  | 2,000 | -999,999,999,999.99 |  |
| 680 | 1.4.4.4.1 | Define Parameters |  | 15d | 2011-02-01 | 2011-02-21 |  | 1158d |  | start no earlier than 2011-02-01 |  |  |  |  |  |
| 681 | 1.4.4.4.2 | **Assemble test System** |  | 195d | 2011-03-01 | 2011-12-05 |  | 735d |  |  |  |  | 2,000 |  |  |
| 682 | 1.4.4.4.2.1 | Define Test System |  | 30d | 2011-03-01 | 2011-04-11 |  | 766d | 0d | start no earlier than 2011-03-01 |  |  |  |  |  |
| 683 | 1.4.4.4.2.2 | Order VME Controller or PC |  | 45d | 2011-04-12 | 2011-06-14 | 682 | 766d | 31d |  | BNL Material [200%] |  | 2,000 | -999,999,999,999.99 |  |
| 684 | 1.4.4.4.2.3 | Obtain Two RDO Cards |  | 1d | 2011-07-28 | 2011-07-28 | 553 | 735d | 0d |  |  |  |  |  |  |
| 685 | 1.4.4.4.2.4 | Slow Control Hardware Assembled | milestone | 0d | 2011-07-28 | 2011-07-28 | 683, 684 | 735d | 0d |  |  |  |  |  |  |
| 686 | 1.4.4.4.2.5 | Program RDO Card to act like Ladder Board |  | 14d | 2011-07-29 | 2011-08-17 | 685 | 735d | 0d |  |  |  |  |  |  |
| 687 | 1.4.4.4.2.6 | Ladder Board Software |  | 30d | 2011-08-18 | 2011-09-29 | 682, 686 | 735d | 0d |  |  |  |  |  |  |
| 688 | 1.4.4.4.2.7 | RDO Board Software |  | 30d | 2011-08-18 | 2011-09-29 | 682, 686 | 735d | 0d |  |  |  |  |  |  |
| 689 | 1.4.4.4.2.8 | Power Software |  | 25d | 2011-07-29 | 2011-09-01 | 682, 685 | 754d | 19d |  |  |  |  |  |  |
| 690 | 1.4.4.4.2.9 | Test and Implement System |  | 45d | 2011-09-30 | 2011-12-05 | 687, 688, 689 | 735d | 0d |  |  |  |  |  |  |
| 691 | 1.4.4.4.2.10 | Slow Control Test System Complete | milestone | 0d | 2011-12-05 | 2011-12-05 | 690 | 735d | 0d |  |  |  |  |  |  |

Notes:
- 676: Should Revisit this

| ID | WBS | Task | Type | Duration | Start | Finish | Predecessors | Total slack | Free slack | Constraint | Resources | Work | Cost | Baseline cost |
| --- | --- | --- | --- | --- | --- | --- | --- | --- | --- | --- | --- | --- | --- | --- |
| 692 | 1.4.4.4.3 | **Assemble Final System** |  | 224d | 2011-12-06 | 2012-10-19 |  | 735d |  |  |  |  |  |  |
| 693 | 1.4.4.4.3.1 | Define Final System |  | 14d | 2011-12-06 | 2011-12-23 | 691 | 735d | 0d |  |  |  |  | -999,999,999,999.99 |
| 694 | 1.4.4.4.3.2 | Incorporate Ladder Board Controls and Configuration |  | 30d | 2011-12-26 | 2012-02-06 | 693 | 735d | 0d |  |  |  |  | -999,999,999,999.99 |
| 695 | 1.4.4.4.3.3 | Incorporate RDO Board Controls and Configuration |  | 15d | 2011-12-26 | 2012-01-13 | 693 | 750d | 15d |  |  |  |  |  |
| 696 | 1.4.4.4.3.4 | Incorporate DAQ Controls and Configuration |  | 15d | 2011-12-26 | 2012-01-13 | 693 | 750d | 15d |  |  |  |  | -999,999,999,999.99 |
| 697 | 1.4.4.4.3.5 | Incorporate Power Controls and Configuration |  | 15d | 2011-12-26 | 2012-01-13 | 693 | 750d | 15d |  |  |  |  |  |
| 698 | 1.4.4.4.3.6 | Slow Controls Reading for Testing | milestone | 0d | 2012-02-06 | 2012-02-06 | 695, 696, 697, 694 | 735d | 0d |  |  |  |  |  |
| 699 | 1.4.4.4.3.7 | Test and Implement Full Slow Control System on Bench |  | 150d | 2012-02-07 | 2012-09-07 | 698 | 735d | 0d |  |  |  |  |  |
| 700 | 1.4.4.4.3.8 | Slow Controls Complete |  | 30d | 2012-09-10 | 2012-10-19 | 696, 699 | 735d |  |  |  |  |  |  |
| 701 | 1.4.4.5 | Infrastructure Complete | milestone | 0d | 2012-10-19 | 2012-10-19 | 618, 655, 666, 679 | 735d |  |  |  |  |  |  |
| 702 | 1.4.4.6 | SSD Sub-System Complete | milestone | 0d | 2012-09-11 | 2012-09-11 | 666 | 763d |  |  |  |  |  | -999,999,999,999.99 |
| 703 | 1.5 | **Integration and Global Supports** |  | 1172d? | 2009-10-01 | 2014-05-16 |  | 344d |  |  |  | 12087.2h | 1,688,355.92 |  |
| 704 | 1.5.1 | **Mechanics** |  | 675d? | 2009-10-01 | 2012-05-21 |  | 841d |  |  |  | 5583.68h | 739,982.25 |  |
| 705 | 1.5.1.1 | **Inner Detector Support (IDS)** |  | 554d? | 2009-10-01 | 2011-11-30 |  | 962d |  |  |  | 2129.68h | 360,159.9 |  |
| 706 | 1.5.1.1.1 | West Support Cylinder Interface | milestone | 0d | 2011-02-22 | 2011-02-22 |  | 1003d | 0d | start no earlier than 2011-02-22 |  |  |  |  |
| 707 | 1.5.1.1.2 | Outer Support Cylinder Shipped | milestone | 0d? | 2011-04-22 | 2011-04-22 | 784 | 1115d |  |  |  |  |  |  |
| 708 | 1.5.1.1.3 | East Support Cylinder Shipped | milestone | 0d | 2011-06-24 | 2011-06-24 | 745SS | 1072d |  |  |  |  |  |  |
| 709 | 1.5.1.1.4 | Inner Detector Support Assembled with SSD/IST/FGT | milestone | 0d | 2011-08-12 | 2011-08-12 | 937 | 1037d |  |  |  |  |  |  |
| 710 | 1.5.1.1.5 | **East Support Cylinder (ESC)** |  | 166d | 2010-11-02 | 2011-06-30 |  | 1051d |  |  |  | 836h | 173,832.72 |  |
| 711 | 1.5.1.1.5.1 | **Composite Material Batches** |  | 5d | 2010-11-02 | 2010-11-08 |  | 1051d |  |  |  | 80h | 90,985.59 |  |
| 712 | 1.5.1.1.5.1.1 | CN60 Batch (ESC,OSC,MSC PT and MSC) |  | 5d | 2010-11-02 | 2010-11-08 |  | 1051d | 44d | start no earlier than 2010-11-02 | LBL_Material [3300%]; LBL_Mech Tech 4 | 40h | 42,583.86 |  |
| 713 | 1.5.1.1.5.1.2 | YSH80 Batch (ESC, OSC, MSC PT and MSC) |  | 5d | 2010-11-02 | 2010-11-08 |  | 1061d | 58d | start no earlier than 2010-11-02 | LBL_Material [3800%]; LBL_Mech Tech 4 | 40h | 48,401.73 |  |
| 714 | 1.5.1.1.5.2 | **Shell Laminate** |  | 7d | 2011-04-04 | 2011-04-12 |  | 1003d |  |  |  | 224h | 21,692.36 |  |
| 715 | 1.5.1.1.5.2.1 | Ply Trim and Kit |  | 2d | 2011-04-04 | 2011-04-05 | 713FS+8w, 706, 780 | 1003d | 0d | start no earlier than 2011-02-14 | LBL_Mech Tech 4 [150%] | 24h | 2,511.55 |  |
| 716 | 1.5.1.1.5.2.2 | Shell Lamination |  | 5d | 2011-04-06 | 2011-04-12 | 715 | 1003d | 0d |  | LBL_Material [80%]; LBL_Mech Tech 4 [300%]; LBL_Mech Tech 3 [200%] | 200h | 19,180.81 |  |

| ID | WBS | Task | Duration | Start | Finish | Predecessors | Total slack | Free slack | Constraint | Resources | Work | Cost |
| --- | --- | --- | --- | --- | --- | --- | --- | --- | --- | --- | --- | --- |
| 717 | 1.5.1.1.5.3 | **Flange Laminates** | 11d | 2011-04-13 | 2011-04-27 |  | 1003d |  |  |  | 44h | 5,088.42 |
| 718 | 1.5.1.1.5.3.1 | Ply Trim and Kit | 8h | 2011-04-13 | 2011-04-13 | 712FS+8w, 716 | 1003d | 0d |  | LBL_Mech Tech 4 | 8h | 837.18 |
| 719 | 1.5.1.1.5.3.2 | Flange | 5d | 2011-04-14 | 2011-04-20 | 718 | 1003d | 0d |  | LBL_Material [20%]; LBL_Mech Tech 4 [40%] | 16h | 1,907.08 |
| 720 | 1.5.1.1.5.3.3 | Flange Base | 5d | 2011-04-21 | 2011-04-27 | 719 | 1003d | 0d |  | LBL_Material [21%]; LBL_Machinist Jr. [10%]; LBL_Mech Tech 4 [40%] | 20h | 2,344.15 |
| 721 | 1.5.1.1.5.4 | **Conical Transition Plate Laminates** | 16d | 2011-04-28 | 2011-05-19 |  | 1003d |  |  |  | 72h | 8,048.67 |
| 722 | 1.5.1.1.5.4.1 | Ply Trim and Kit | 16h | 2011-04-28 | 2011-04-29 | 720 | 1003d | 0d |  | LBL_Mech Tech 4 | 16h | 1,674.37 |
| 723 | 1.5.1.1.5.4.2 | Cone Laminate | 5d | 2011-05-02 | 2011-05-06 | 722 | 1003d | 0d |  | LBL_Material [11%]; LBL_Mech Tech 4 [60%] | 24h | 2,639.55 |
| 724 | 1.5.1.1.5.4.3 | Large Flange Base | 5d | 2011-05-09 | 2011-05-13 | 723 | 1003d | 0d |  | LBL_Material [21%]; LBL_Machinist Jr. [10%]; LBL_Mech Tech 4 [40%] | 20h | 2,344.15 |
| 725 | 1.5.1.1.5.4.4 | Small Flange Base | 4d | 2011-05-16 | 2011-05-19 | 724 | 1003d | 0d |  | LBL_Material [11%]; LBL_Machinist Jr. [12.5%]; LBL_Mech Tech 4 | 12h | 1,390.61 |
| 726 | 1.5.1.1.5.5 | **Interface Parts** | 15d | 2011-02-22 | 2011-03-15 |  | 1143d |  |  |  | 56h | 7,875.93 |
| 727 | 1.5.1.1.5.5.1 | Termination Flange | 2w | 2011-02-22 | 2011-03-08 | 706 | 1143d | 0d | start no earlier than 2011-01-04 | LBL_Material [160%]; LBL_Machinist Jr. [50%] | 40h | 6,116.03 |
| 728 | 1.5.1.1.5.5.2 | Threaded Inserts | 5d | 2011-03-09 | 2011-03-15 | 727 | 1143d |  |  | LBL_Material [5%]; LBL_Machinist Jr. [40%] | 16h | 1,759.9 |
| 729 | 1.5.1.1.5.6 | **Assembly Tool Modification (from WSC)** | 15d | 2011-04-13 | 2011-05-03 |  | 1024d |  |  |  | 120h | 12,684.66 |
| 730 | 1.5.1.1.5.6.1 | Clocking Plates Modification | 10d | 2011-04-13 | 2011-04-26 | 706, 716 | 1024d | 0d |  | LBL_Machinist Jr. [50%]; LBL_Mech Tech 4 [10%] | 48h | 5,091.5 |
| 731 | 1.5.1.1.5.6.2 | Cone Plate Modification | 6d | 2011-04-13 | 2011-04-20 | 730SS | 1028d | 4d |  | LBL_Machinist Jr. [66.7%]; LBL_Mech Tech 4 [16.7%] | 40h | 4,240.63 |
| 732 | 1.5.1.1.5.6.3 | Tool Assembly/Survey | 5d | 2011-04-27 | 2011-05-03 | 730, 731 | 1024d | 21d |  | LBL_Mech Tech 4 [60%]; LBL_CMM | 32h | 3,352.53 |
| 733 | 1.5.1.1.5.7 | **ESC Assembly** | 30d | 2011-04-28 | 2011-06-09 |  | 1019d | 0d |  |  | 208h | 21,774.36 |
| 734 | 1.5.1.1.5.7.1 | Cone Bonded Assembly | 4d | 2011-05-09 | 2011-05-12 | 723 | 1012d | 0d |  | LBL_Mech Tech 4 [75%] | 24h | 2,511.55 |
| 735 | 1.5.1.1.5.7.2 | Termination Flange Assembly | 4d | 2011-05-20 | 2011-05-25 | 724, 725 | 1003d | 0d |  | LBL_Mech Tech 4 [75%] | 24h | 2,511.55 |
| 736 | 1.5.1.1.5.7.3 | Flange Bonded Assembly | 4d | 2011-04-28 | 2011-05-03 | 720 | 1019d | 0d |  | LBL_Mech Tech 4 [75%] | 24h | 2,511.55 |
| 737 | 1.5.1.1.5.7.4 | ESC Assembly and Survey | 6d | 2011-05-26 | 2011-06-03 | 734, 735, 736 | 1071d |  |  | LBL_Mech Tech 4 [50%]; LBL_CMM | 32h | 3,352.53 |
| 738 | 1.5.1.1.5.7.5 | Cone Bonded Assembly | 5d | 2011-05-13 | 2011-05-19 | 734 | 1012d | 9d |  | LBL_Mech Tech 4 [60%] | 24h | 2,511.55 |
| 739 | 1.5.1.1.5.7.6 | Termination Flange Assembly | 5d | 2011-05-26 | 2011-06-02 | 735 | 1003d | 0d |  | LBL_Mech Tech 4 [60%] | 24h | 2,511.55 |
| 740 | 1.5.1.1.5.7.7 | Flange Bonded Assembly | 5d | 2011-05-04 | 2011-05-10 | 736 | 1019d | 16d |  | LBL_Mech Tech 4 [60%] | 24h | 2,511.55 |
| 741 | 1.5.1.1.5.7.8 | ESC Assembly and Survey | 5d | 2011-06-03 | 2011-06-09 | 738, 739, 740, 732 | 1003d | 0d |  | LBL_Mech Tech 4 [60%]; LBL_CMM | 32h | 3,352.53 |

| ID | WBS | Task | Duration | Start | Finish | Predecessors | Total slack | Free slack | Constraint | Resources | Work | Cost |
| --- | --- | --- | --- | --- | --- | --- | --- | --- | --- | --- | --- | --- |
| 742 | 1.5.1.1.5.8 | **Shipping (ESC 2011)** | 15d | 2011-06-10 | 2011-06-30 | 733 | 1067d |  |  |  | 32h | 5,682.72 |
| 743 | 1.5.1.1.5.8.1 | Box Fab -- Carpenters not MT but cost scaled | 5d | 2011-06-10 | 2011-06-16 |  | 1067d | 0d |  | LBL_Mech Tech 4 [30%]; LBL_Material [50%]; LBL_Machinist Jr. | 16h | 2,262.99 |
| 744 | 1.5.1.1.5.8.2 | Packing | 5d | 2011-06-17 | 2011-06-23 | 743 | 1067d | 0d |  | LBL_Mech Tech 4 [40%] | 16h | 1,674.37 |
| 745 | 1.5.1.1.5.8.3 | Shipping Cost | 5d | 2011-06-24 | 2011-06-30 | 744 | 1067d | 0d |  | LBL_Material [150%] |  | 1,745.36 |
| 746 | 1.5.1.1.6 | **Outer Support Cylinder (OSC)** | 272d | 2010-11-01 | 2011-11-30 |  | 962d |  |  |  | 1293.68h | 186,327.18 |
| 747 | 1.5.1.1.6.1 | **Tooling OSC Prototype (MSC PIT Tool Development)** | 77d | 2010-11-01 | 2011-02-22 |  | 1007d |  |  |  | 272h | 59,950.65 |
| 748 | 1.5.1.1.6.1.1 | **Shell Production Tool (Same as MSC PIT)** | 50d | 2010-11-01 | 2011-01-13 |  | 1007d |  |  |  | 40h | 32,471.38 |
| 749 | 1.5.1.1.6.1.1.1 | Tool Fabrication | 5d | 2010-11-01 | 2010-11-05 |  | 1007d | 0d | start no earlier than 2010-11-01 | LBL_Mech Tech 4 [40%]; LBL_Material [2500%] | 16h | 30,763.72 |
| 750 | 1.5.1.1.6.1.1.2 | Tool Preparation | 5d | 2011-01-07 | 2011-01-13 | 749FS+8w | 1007d | 0d |  | LBL_Mech Tech 3 [60%] | 24h | 1,707.66 |
| 751 | 1.5.1.1.6.1.2 | **Flange Tooling** | 15d | 2011-02-02 | 2011-02-22 |  | 1007d |  |  |  | 96h | 12,189.4 |
| 752 | 1.5.1.1.6.1.2.1 | Lamination Tool | 2w | 2011-02-02 | 2011-02-15 | 762FS+5d | 1007d | 0d | start no earlier than 2010-11-01 | LBL_Material [50%]; LBL_Machinist Sr. [30%]; LBL_Mech Tech 4 | 32h | 4,273.64 |
| 753 | 1.5.1.1.6.1.2.2 | Bond Tool | 1w | 2011-02-16 | 2011-02-22 | 752 | 1157d |  |  | LBL_Material [50%]; LBL_Machinist Jr. [40%]; LBL_Mech Tech 4 [40%] | 32h | 3,957.88 |
| 754 | 1.5.1.1.6.1.2.3 | Trim Tool | 1w | 2011-02-16 | 2011-02-22 | 752 | 1157d |  |  | LBL_Material [50%]; LBL_Machinist Jr. [40%]; LBL_Mech Tech 4 [40%] | 32h | 3,957.88 |
| 755 | 1.5.1.1.6.1.3 | **Assembly Tool (not shared with MSC)** | 20d | 2010-12-01 | 2010-12-29 |  | 1189d |  |  |  | 136h | 15,289.88 |
| 756 | 1.5.1.1.6.1.3.1 | Clocking Plates Modification | 10d | 2010-12-01 | 2010-12-14 |  | 1189d | 0d | start no earlier than 2010-12-01 | LBL_Machinist Jr.; LBL_Mech Tech 4 [20%] | 48h | 5,077.82 |
| 757 | 1.5.1.1.6.1.3.2 | Space Bars | 10d | 2010-12-01 | 2010-12-14 | 756SS | 1189d | 0d |  | LBL_Material [80%]; LBL_Machinist Jr. [50%] | 40h | 5,185.17 |
| 758 | 1.5.1.1.6.1.3.3 | Tool Assembly/Survey | 10d | 2010-12-15 | 2010-12-29 | 756, 757 | 1189d | 54d |  | LBL_Mech Tech 4 [50%]; LBL_CMM [10%] | 48h | 5,026.89 |
| 759 | 1.5.1.1.6.2 | **OSC Assembly 2011** | 69d | 2011-01-14 | 2011-04-22 |  | 1007d |  |  |  | 634.08h | 75,266.86 |
| 760 | 1.5.1.1.6.2.1 | **Shell Laminate Prototype** | 7d | 2011-01-14 | 2011-01-25 |  | 1007d |  |  |  | 168h | 18,744.44 |
| 761 | 1.5.1.1.6.2.1.1 | Ply Trim and Kit | 2d | 2011-01-14 | 2011-01-18 | 750, 712 | 1007d | 0d |  | LBL_Mech Tech 4 [150%] | 24h | 2,511.55 |
| 762 | 1.5.1.1.6.2.1.2 | Shell Lamination | 5d | 2011-01-19 | 2011-01-25 | 761 | 1007d | 0d |  | LBL_Material; LBL_Mech Tech 4 [360%] | 144h | 16,232.89 |
| 763 | 1.5.1.1.6.2.2 | **Shell Laminate 2011 (Initial Install)** | 13.82d | 2011-01-26 | 2011-02-14 |  | 1163.18d |  |  |  | 144h | 16,739.51 |
| 764 | 1.5.1.1.6.2.2.1 | Ply Trim and Kit | 1d | 2011-01-26 | 2011-01-26 | 762 | 1163.18d | 0d |  | LBL_Mech Tech 4 [200%]; LBL_Mech Eng Sr. | 24h | 2,834.07 |
| 765 | 1.5.1.1.6.2.2.2 | Shell Lamination | 5d | 2011-01-27 | 2011-02-14 | 764 | 1163.18d |  |  | LBL_Material [231%]; LBL_Mech Tech 4 [200%]; LBL_Mech Tech 3 | 120h | 13,905.44 |

| ID | WBS | Task | Duration | Start | Finish | Predecessors | Total slack | Free slack | Constraint | Resources | Work | Cost |
| --- | --- | --- | --- | --- | --- | --- | --- | --- | --- | --- | --- | --- |
| 766 | 1.5.1.1.6.2.3 | **Flange Laminates Prototype** | 9d | 2011-02-22 | 2011-03-07 |  | 1003d |  |  |  | 44h | 5,100.05 |
| 767 | 1.5.1.1.6.2.3.1 | Ply Trim and Kit | 8h | 2011-02-22 | 2011-02-22 | 752, 706 | 1003d | 0d |  | LBL_Mech Tech 4 | 8h | 837.18 |
| 768 | 1.5.1.1.6.2.3.2 | Flange | 4d | 2011-02-23 | 2011-03-01 | 767 | 1003d | 0d |  | LBL_Material [21%]; LBL_Mech Tech 4 [50%] | 16h | 1,918.72 |
| 769 | 1.5.1.1.6.2.3.3 | Flange Base | 4d | 2011-03-02 | 2011-03-07 | 768 | 1003d | 0d |  | LBL_Material [21%]; LBL_Machinist Jr. [12.5%]; LBL_Mech Tech 4 [50%] | 20h | 2,344.15 |
| 770 | 1.5.1.1.6.2.4 | **Flange Laminates 2011 (Initial Install)** | 11d | 2011-03-08 | 2011-03-22 |  | 1003d |  |  |  | 70.08h | 10,105.29 |
| 771 | 1.5.1.1.6.2.4.1 | Ply Trim and Kit | 8h | 2011-03-08 | 2011-03-08 | 769 | 1003d | 0d |  | LBL_Mech Tech 4; LBL_Mech Eng Sr. [25%] | 10h | 1,127.11 |
| 772 | 1.5.1.1.6.2.4.2 | Flange | 4d | 2011-03-09 | 2011-03-14 | 771 | 1003d | 0d |  | LBL_Material [21%]; LBL_Mech Tech 4 [50%]; LBL_Mech Eng Sr. [6.5%] | 18.08h | 2,220.24 |
| 773 | 1.5.1.1.6.2.4.3 | Flange Base | 4d | 2011-03-15 | 2011-03-18 | 772 | 1003d | 0d |  | LBL_Material [21%]; LBL_Machinist Jr. [12.5%]; LBL_Mech Tech 4 [50%] | 20h | 2,344.15 |
| 774 | 1.5.1.1.6.2.4.4 | **Interface Parts** | 10d | 2011-03-09 | 2011-03-22 |  | 1138d |  |  |  | 22h | 4,413.79 |
| 775 | 1.5.1.1.6.2.4.4.1 | Hardware | 5d | 2011-03-09 | 2011-03-15 | 756, 771 | 1138d | 0d | start no earlier than 2011-01-11 | LBL_Material [150%]; LBL_Mech Tech 4 [30%] | 12h | 3,001.14 |
| 776 | 1.5.1.1.6.2.4.4.2 | Threaded Inserts | 5d | 2011-03-16 | 2011-03-22 | 775 | 1138d |  |  | LBL_Material [30%]; LBL_Machinist Jr. [25%] | 10h | 1,412.65 |
| 777 | 1.5.1.1.6.2.5 | Termination Flange Assembly | 5d | 2011-03-21 | 2011-03-25 | 758, 773 | 1135d |  |  | LBL_Mech Tech 4 [120%] | 48h | 5,023.1 |
| 778 | 1.5.1.1.6.2.6 | Bonded Assembly 2011 | 5d | 2011-03-21 | 2011-03-25 | 773 | 1003d | 0d |  | LBL_Mech Tech 4; LBL_Material [50%] | 40h | 4,767.71 |
| 779 | 1.5.1.1.6.2.7 | Termination Flange Assembly | 5d | 2011-03-28 | 2011-04-01 | 778 | 1130d |  |  | LBL_Mech Tech 4 [120%] | 48h | 5,023.1 |
| 780 | 1.5.1.1.6.2.8 | OSC Assembly and Survey | 5d | 2011-03-28 | 2011-04-01 | 778 | 1003d | 0d |  | LBL_Mech Tech 4 [60%]; LBL_CMM [60%] | 48h | 5,034.48 |
| 781 | 1.5.1.1.6.2.9 | **Shipping (OSC 2011)** | 15d | 2011-04-04 | 2011-04-22 |  | 1037d |  |  |  | 24h | 4,729.18 |
| 782 | 1.5.1.1.6.2.9.1 | Box Fab -- Carpenters not MT but cost scaled | 5d | 2011-04-04 | 2011-04-08 | 780 | 1037d | 0d |  | LBL_Mech Tech 4 [30%]; LBL_Material [40%]; LBL_Machinist Jr. | 16h | 2,146.64 |
| 783 | 1.5.1.1.6.2.9.2 | Packing | 5d | 2011-04-11 | 2011-04-15 | 782 | 1037d | 0d |  | LBL_Mech Tech 4 [20%] | 8h | 837.18 |
| 784 | 1.5.1.1.6.2.9.3 | Shipping Cost | 5d | 2011-04-18 | 2011-04-22 | 783 | 1037d | 0d |  | LBL_Material [150%] |  | 1,745.36 |
| 785 | 1.5.1.1.6.3 | **OSC Assembly 2013** | 40d | 2011-10-04 | 2011-11-30 |  | 883d |  |  |  | 387.6h | 51,109.67 |
| 786 | 1.5.1.1.6.3.1 | **Shell Laminate 2012 for SSD** | 6d | 2011-10-04 | 2011-10-11 |  | 883d |  |  |  | 159.6h | 20,924.45 |
| 787 | 1.5.1.1.6.3.1.1 | Ply Trim and Kit | 1d | 2011-10-04 | 2011-10-04 |  | 883d | 0d | start no earlier than 2011-10-04 | LBL_Mech Tech 4 [200%]; LBL_Mech Eng Sr. | 24h | 2,919.09 |
| 788 | 1.5.1.1.6.3.1.2 | Shell Lamination | 5d | 2011-10-05 | 2011-10-11 | 787 | 883d | 0d |  | LBL_Material [231%]; LBL_Mech Tech 4 [300%]; LBL_Mech Eng Sr. [39%] | 135.6h | 18,005.36 |
| 789 | 1.5.1.1.6.3.2 | **Flange Laminates 2012 for SSD** | 9d | 2011-10-12 | 2011-10-24 |  | 883d |  |  |  | 46h | 5,546.79 |
| 790 | 1.5.1.1.6.3.2.1 | Ply Trim and Kit | 8h | 2011-10-12 | 2011-10-12 | 788 | 883d | 0d |  | LBL_Mech Tech 4; LBL_Mech Eng Sr. [25%] | 10h | 1,160.92 |
| 791 | 1.5.1.1.6.3.2.2 | Flange | 4d | 2011-10-13 | 2011-10-18 | 790 | 883d | 0d |  | LBL_Material [21%]; LBL_Mech Tech 4 [50%] | 16h | 1,973.84 |
| 792 | 1.5.1.1.6.3.2.3 | Flange Base | 4d | 2011-10-19 | 2011-10-24 | 791 | 883d | 0d |  | LBL_Material [21%]; LBL_Machinist Jr. [12.5%]; LBL_Mech Tech 4 [50%] | 20h | 2,412.03 |
| 793 | 1.5.1.1.6.3.3 | Bonded Assembly 2013 | 5d | 2011-10-25 | 2011-10-31 | 792 | 883d | 0d |  | LBL_Mech Tech 4; LBL_Material [50%] | 40h | 4,904.92 |
| 794 | 1.5.1.1.6.3.4 | Termination Flange Assembly | 5d | 2011-11-01 | 2011-11-07 | 793 | 977d |  |  | LBL_Mech Tech 4 [120%] | 48h | 5,173.8 |
| 795 | 1.5.1.1.6.3.5 | OSC Assembly and Survey | 5d | 2011-11-01 | 2011-11-07 | 793 | 883d | 0d |  | LBL_Mech Tech 4 [60%]; LBL_CMM [60%] | 48h | 5,185.51 |
| 796 | 1.5.1.1.6.3.6 | Hardware (MSC) | 5d | 2011-10-13 | 2011-10-19 | 790 | 985d | 0d |  | LBL_Material [150%]; LBL_Mech Tech 4 [30%] | 12h | 3,073.72 |
| 797 | 1.5.1.1.6.3.7 | Threaded Inserts (MSC) | 5d | 2011-10-20 | 2011-10-26 | 796 | 985d |  |  | LBL_Material [30%]; LBL_Machinist Jr. [25%] | 10h | 1,451.54 |

| ID | WBS | Task | Duration | Start | Finish | Predecessors | Total slack | Free slack | Constraint | Resources | Work | Cost |
| --- | --- | --- | --- | --- | --- | --- | --- | --- | --- | --- | --- | --- |
| 798 | 1.5.1.1.6.3.8 | **Shipping (OSC 2013)** | 15d | 2011-11-08 | 2011-11-30 |  | 962d |  |  |  | 24h | 4,848.95 |
| 799 | 1.5.1.1.6.3.8.1 | Box Fab -- Carpenters not MT but cost scaled | 5d | 2011-11-08 | 2011-11-14 | 795 | 962d | 0d |  | LBL_Mech Tech 4 [30%]; LBL_Material [40%]; LBL_Machinist Jr. | 16h | 2,206.38 |
| 800 | 1.5.1.1.6.3.8.2 | Packing | 5d | 2011-11-15 | 2011-11-21 | 799 | 962d | 0d |  | LBL_Mech Tech 4 [20%] | 8h | 862.3 |
| 801 | 1.5.1.1.6.3.8.3 | Shipping Cost | 5d | 2011-11-22 | 2011-11-30 | 800 | 962d |  |  | LBL_Material [150%] |  | 1,780.27 |
| 802 | 1.5.1.1.7 | E-Field Shroud (EFS) | 1d | 2009-10-01 | 2009-10-01 |  | 1515d |  |  |  |  |  |
| 803 | 1.5.1.2 | **Middle Support Cylinder (MSC)** | 241d | 2011-06-10 | 2012-05-21 |  | 841d |  |  |  | 2130h | 242,868.88 |
| 804 | 1.5.1.2.1 | **Pixel Insertion Tube** | 173d | 2011-06-10 | 2012-02-14 |  | 909d |  |  |  | 956h | 108,357.96 |
| 805 | 1.5.1.2.1.1 | **PIT Engineering Run** | 24d | 2011-06-10 | 2011-07-14 |  | 1003d |  |  |  | 300h | 35,047.93 |
| 806 | 1.5.1.2.1.1.1 | **Shell Laminate 2011 PIT (Engineering Run)** | 6d | 2011-06-10 | 2011-06-17 |  | 1003d |  |  |  | 136h | 14,930.27 |
| 807 | 1.5.1.2.1.1.1.1 | Ply Trim and Kit | 1d | 2011-06-10 | 2011-06-10 | 780, 741 | 1003d | 0d |  | LBL_Mech Tech 4 [200%] | 16h | 1,674.37 |
| 808 | 1.5.1.2.1.1.1.2 | Shell Lamination | 5d | 2011-06-13 | 2011-06-17 | 807 | 1003d | 0d |  | LBL_Material [60%]; LBL_Mech Tech 4 [300%] | 120h | 13,255.9 |
| 809 | 1.5.1.2.1.1.2 | **Flange Laminates Prototype** | 9d | 2011-06-20 | 2011-06-30 |  | 1003d |  |  |  | 44h | 5,100.05 |
| 810 | 1.5.1.2.1.1.2.1 | Ply Trim and Kit | 1d | 2011-06-20 | 2011-06-20 | 808 | 1003d | 0d |  | LBL_Mech Tech 4 | 8h | 837.18 |
| 811 | 1.5.1.2.1.1.2.2 | Flange | 4d | 2011-06-21 | 2011-06-24 | 810 | 1003d | 0d |  | LBL_Material [21%]; LBL_Mech Tech 4 [50%] | 16h | 1,918.72 |
| 812 | 1.5.1.2.1.1.2.3 | Flange Base | 4d | 2011-06-27 | 2011-06-30 | 811 | 1003d | 0d |  | LBL_Material [21%]; LBL_Machinist Jr. [12.5%]; LBL_Mech Tech 4 [50%] | 20h | 2,344.15 |
| 813 | 1.5.1.2.1.1.3 | **Flange Laminates 2011 (Initial Install)** | 9d | 2011-07-01 | 2011-07-14 |  | 1003d |  |  |  | 44h | 5,100.05 |
| 814 | 1.5.1.2.1.1.3.1 | Ply Trim and Kit | 1d | 2011-07-01 | 2011-07-01 | 812 | 1003d | 0d |  | LBL_Mech Tech 4 | 8h | 837.18 |
| 815 | 1.5.1.2.1.1.3.2 | Flange | 4d | 2011-07-05 | 2011-07-08 | 814 | 1003d | 0d |  | LBL_Material [21%]; LBL_Mech Tech 4 [50%] | 16h | 1,918.72 |
| 816 | 1.5.1.2.1.1.3.3 | Flange Base | 4d | 2011-07-11 | 2011-07-14 | 815 | 1003d | 0d |  | LBL_Material [21%]; LBL_Machinist Jr. [12.5%]; LBL_Mech Tech 4 [50%] | 20h | 2,344.15 |
| 817 | 1.5.1.2.1.1.4 | Transition Plate 2011 Install | 10d | 2011-06-20 | 2011-07-01 | 808 | 1016d | 13d |  | LBL_Material [160%]; LBL_Machinist Jr. [75%]; LBL_Mech Tech 4 | 76h | 9,917.55 |
| 818 | 1.5.1.2.1.2 | **PIT 2013** | 16d | 2012-01-09 | 2012-01-31 |  | 841d |  |  |  | 256h | 30,815.83 |
| 819 | 1.5.1.2.1.2.1 | **Shell Laminate 2012 for IST** | 6d | 2012-01-09 | 2012-01-17 |  | 841d |  |  |  | 136h | 15,371.2 |
| 820 | 1.5.1.2.1.2.1.1 | Ply Trim and Kit | 1d | 2012-01-09 | 2012-01-09 | 795 | 841d | 0d | start no earlier than 2012-01-09 | LBL_Mech Tech 4 [200%] | 16h | 1,724.6 |
| 821 | 1.5.1.2.1.2.1.2 | Shell Lamination | 5d | 2012-01-10 | 2012-01-17 | 820 | 841d | 0d |  | LBL_Material [60%]; LBL_Mech Tech 4 [300%] | 120h | 13,646.6 |

| ID | WBS | Task | Duration | Start | Finish | Predecessors | Total slack | Free slack | Resources | Work | Cost |
| --- | --- | --- | --- | --- | --- | --- | --- | --- | --- | --- | --- |
| 822 | 1.5.1.2.1.2.2 | **Flange Laminates 2012 for SSD** | 9d | 2012-01-18 | 2012-01-30 |  | 920d |  |  | 44h | 5,248.17 |
| 823 | 1.5.1.2.1.2.2.1 | Ply Trim and Kit | 1d | 2012-01-18 | 2012-01-18 | 821 | 920d | 0d | LBL_Mech Tech 4 | 8h | 862.3 |
| 824 | 1.5.1.2.1.2.2.2 | Flange | 4d | 2012-01-19 | 2012-01-24 | 823 | 920d | 0d | LBL_Material [21%]; LBL_Mech Tech 4 [50%] | 16h | 1,973.84 |
| 825 | 1.5.1.2.1.2.2.3 | Flange Base | 4d | 2012-01-25 | 2012-01-30 | 824 | 920d |  | LBL_Material [21%]; LBL_Machinist Jr. [12.5%]; LBL_Mech Tech 4 [50%] | 20h | 2,412.03 |
| 826 | 1.5.1.2.1.2.3 | Transition Plate 2012 Install | 10d | 2012-01-18 | 2012-01-31 | 821 | 841d | 0d | LBL_Material [160%]; LBL_Machinist Jr. [75%]; LBL_Mech Tech 4 | 76h | 10,196.46 |
| 827 | 1.5.1.2.1.3 | **MSC Assembly 2011** | 10d | 2011-07-15 | 2011-07-28 |  | 1003d |  |  | 200h | 20,933.1 |
| 828 | 1.5.1.2.1.3.1 | Termination Flange Assembly | 5d | 2011-07-15 | 2011-07-21 | 816 | 1003d | 0d | LBL_Mech Tech 4 [60%] | 24h | 2,511.55 |
| 829 | 1.5.1.2.1.3.2 | Flange Bonded Assembly | 5d | 2011-07-15 | 2011-07-21 | 816 | 1003d | 0d | LBL_Mech Tech 4 [120%] | 48h | 5,023.1 |
| 830 | 1.5.1.2.1.3.3 | PIT Bonded Assembly and Survey | 5d | 2011-07-22 | 2011-07-28 | 828, 829, 808, 817 | 1003d | 0d | LBL_CMM [33%]; LBL_Mech Tech 4 [300%] | 128h | 13,398.45 |
| 831 | 1.5.1.2.1.4 | **MSC Assembly 2012** | 10d | 2012-02-01 | 2012-02-14 |  | 841d |  |  | 200h | 21,561.09 |
| 832 | 1.5.1.2.1.4.1 | Termination Flange Assembly | 5d | 2012-02-01 | 2012-02-07 | 826 | 841d | 0d | LBL_Mech Tech 4 [60%] | 24h | 2,586.9 |
| 833 | 1.5.1.2.1.4.2 | Flange Bonded Assembly | 5d | 2012-02-01 | 2012-02-07 | 826 | 841d | 0d | LBL_Mech Tech 4 [120%] | 48h | 5,173.8 |
| 834 | 1.5.1.2.1.4.3 | PIT Bonded Assembly and Survey | 5d | 2012-02-08 | 2012-02-14 | 832, 833 | 841d | 0d | LBL_CMM [33%]; LBL_Mech Tech 4 [300%] | 128h | 13,800.4 |
| 835 | 1.5.1.2.2 | **Pixel Support Tube** | 192d | 2011-07-29 | 2012-04-30 |  | 856d |  |  | 1158h | 131,117.7 |
| 836 | 1.5.1.2.2.1 | **Tooling PST (PIT shared w/OSC)** | 28d | 2011-07-29 | 2011-09-07 |  | 1005d |  |  | 202h | 24,597.12 |
| 837 | 1.5.1.2.2.1.1 | **Shell Prototype Tool** | 26d | 2011-07-29 | 2011-09-02 |  | 1005d |  |  | 98h | 10,381.74 |
| 838 | 1.5.1.2.2.1.1.1 | Tool Material CTE Study | 5d | 2011-07-29 | 2011-08-04 | 830 | 1005d | 0d | LBL_Machinist Jr. [5%]; LBL_Mech Tech 4 [20%] | 10h | 1,049.9 |
| 839 | 1.5.1.2.2.1.1.2 | Tool Fabrication | 10d | 2011-08-05 | 2011-08-18 | 838 | 1005d | 0d | LBL_Machinist Jr. [60%]; LBL_Mech Tech 4 [33%] | 56h | 5,942.07 |
| 840 | 1.5.1.2.2.1.1.3 | Re-Machine | 5d | 2011-08-29 | 2011-09-02 | 839, 847 | 1017d | 0d | LBL_Machinist Jr. [60%]; LBL_Mech Tech 4 [50%] | 32h | 3,389.77 |
| 841 | 1.5.1.2.2.1.2 | **Flange Tooling** | 13d | 2011-08-19 | 2011-09-07 |  | 1005d |  |  | 104h | 14,215.38 |
| 842 | 1.5.1.2.2.1.2.1 | Lamination Tool | 8d | 2011-08-19 | 2011-08-30 | 839 | 1005d | 0d | LBL_Material; LBL_Machinist Jr. [50%]; LBL_Mech Tech 3 [33%] | 40h | 5,136.05 |
| 843 | 1.5.1.2.2.1.2.2 | Bond Tool | 5d | 2011-08-31 | 2011-09-07 | 842 | 1005d | 0d | LBL_Material; LBL_Machinist Jr. [40%]; LBL_Mech Tech 4 [40%] | 32h | 4,539.67 |
| 844 | 1.5.1.2.2.1.2.3 | Trim Tool | 5d | 2011-08-31 | 2011-09-07 | 842 | 1020d |  | LBL_Material; LBL_Machinist Jr. [40%]; LBL_Mech Tech 4 [40%] | 32h | 4,539.67 |
| 845 | 1.5.1.2.2.2 | **Shell Laminate Prototype PST** | 6d | 2011-08-19 | 2011-08-26 |  | 1017d |  |  | 136h | 14,813.92 |
| 846 | 1.5.1.2.2.2.1 | Ply Trim and Kit | 1d | 2011-08-19 | 2011-08-19 | 839 | 1017d | 0d | LBL_Mech Tech 4 [200%] | 16h | 1,674.37 |
| 847 | 1.5.1.2.2.2.2 | Shell Lamination | 5d | 2011-08-22 | 2011-08-26 | 846 | 1017d | 0d | LBL_Material [50%]; LBL_Mech Tech 4 [300%] | 120h | 13,139.55 |

| ID | WBS | Task | Duration | Start | Finish | Predecessors | Total slack | Free slack | Resources | Work | Cost |
| --- | --- | --- | --- | --- | --- | --- | --- | --- | --- | --- | --- |
| 848 | 1.5.1.2.2.3 | **Shell Laminate 2011 PST (Engineering Run)** | 8d | 2011-08-31 | 2011-09-12 |  | 1017d |  |  | 136h | 14,813.92 |
| 849 | 1.5.1.2.2.3.1 | Ply Trim and Kit | 1d | 2011-08-31 | 2011-08-31 | 842 | 1019d | 2d | LBL_Mech Tech 4 [200%] | 16h | 1,674.37 |
| 850 | 1.5.1.2.2.3.2 | Shell Lamination | 5d | 2011-09-06 | 2011-09-12 | 849, 840 | 1017d |  | LBL_Material [50%]; LBL_Mech Tech 4 [300%] | 120h | 13,139.55 |
| 851 | 1.5.1.2.2.4 | **Shell Laminate 2012 for IST** | 15d | 2012-02-01 | 2012-02-21 |  | 841d |  |  | 136h | 15,252.51 |
| 852 | 1.5.1.2.2.4.1 | Ply Trim and Kit | 1d | 2012-02-01 | 2012-02-01 | 826 | 850d | 9d | LBL_Mech Tech 4 [200%] | 16h | 1,724.6 |
| 853 | 1.5.1.2.2.4.2 | Shell Lamination | 5d | 2012-02-15 | 2012-02-21 | 852, 834 | 841d | 0d | LBL_Material [50%]; LBL_Mech Tech 4 [300%] | 120h | 13,527.92 |
| 854 | 1.5.1.2.2.5 | **Flange Laminates Prototype** | 11d | 2012-02-22 | 2012-03-08 |  | 841d |  |  | 60h | 6,972.77 |
| 855 | 1.5.1.2.2.5.1 | Ply Trim and Kit | 1d | 2012-02-22 | 2012-02-22 | 853 | 841d | 0d | LBL_Mech Tech 4 | 8h | 862.3 |
| 856 | 1.5.1.2.2.5.2 | Flange | 6d | 2012-02-23 | 2012-03-02 | 855 | 841d | 0d | LBL_Material [21%]; LBL_Mech Tech 4 [66.7%] | 32h | 3,698.44 |
| 857 | 1.5.1.2.2.5.3 | Flange Base | 4d | 2012-03-05 | 2012-03-08 | 856 | 841d | 0d | LBL_Material [21%]; LBL_Machinist Jr. [12.5%]; LBL_Mech Tech 4 [50%] | 20h | 2,412.03 |
| 858 | 1.5.1.2.2.6 | **Flange Laminates 2011 (Initial Install)** | 11d | 2012-03-09 | 2012-03-23 |  | 841d |  |  | 60h | 6,972.77 |
| 859 | 1.5.1.2.2.6.1 | Ply Trim and Kit | 1d | 2012-03-09 | 2012-03-09 | 857 | 841d | 0d | LBL_Mech Tech 4 | 8h | 862.3 |
| 860 | 1.5.1.2.2.6.2 | Flange | 6d | 2012-03-12 | 2012-03-19 | 859 | 841d | 0d | LBL_Material [21%]; LBL_Mech Tech 4 [66.7%] | 32h | 3,698.44 |
| 861 | 1.5.1.2.2.6.3 | Flange Base | 4d | 2012-03-20 | 2012-03-23 | 860 | 841d | 0d | LBL_Material [21%]; LBL_Machinist Jr. [12.5%]; LBL_Mech Tech 4 [50%] | 20h | 2,412.03 |
| 862 | 1.5.1.2.2.7 | **PST Assembly 2011** | 15d | 2011-09-08 | 2011-09-28 |  | 1005d |  |  | 176h | 18,429.42 |
| 863 | 1.5.1.2.2.7.1 | Flange Bonded Assembly | 5d | 2011-09-08 | 2011-09-14 | 843 | 1005d | 0d | LBL_Mech Tech 4 [200%]; LBL_CMM [40%] | 96h | 10,053.79 |
| 864 | 1.5.1.2.2.7.2 | PIT Bonded Assembly | 5d | 2011-09-15 | 2011-09-21 | 863 | 1005d | 0d | LBL_CMM; LBL_Mech Tech 4 [60%] | 32h | 3,352.53 |
| 865 | 1.5.1.2.2.7.3 | Pixel Mount Assembly | 5d | 2011-09-22 | 2011-09-28 | 864 | 1005d |  | LBL_Mech Tech 4 [120%] | 48h | 5,023.1 |
| 866 | 1.5.1.2.2.8 | **Shipping (MSC 2011)** | 15d | 2011-07-29 | 2011-08-18 | 830 | 1033d |  |  | 16h | 3,310.21 |
| 867 | 1.5.1.2.2.8.1 | Box Fab -- Carpenters not MT but cost scaled | 5d | 2011-07-29 | 2011-08-04 |  | 1033d | 0d | LBL_Mech Tech 4 [20%]; LBL_Material [40%]; LBL_Machinist Jr. | 12h | 1,728.04 |
| 868 | 1.5.1.2.2.8.2 | Packing | 5d | 2011-08-05 | 2011-08-11 | 867 | 1033d | 0d | LBL_Mech Tech 4 [10%] | 4h | 418.59 |
| 869 | 1.5.1.2.2.8.3 | Shipping Cost | 5d | 2011-08-12 | 2011-08-18 | 868 | 1033d |  | LBL_Material |  | 1,163.57 |
| 870 | 1.5.1.2.2.9 | **Flange Laminates 2012 for IST** | 11d | 2012-03-26 | 2012-04-09 |  | 841d |  |  | 60h | 6,972.77 |
| 871 | 1.5.1.2.2.9.1 | Ply Trim and Kit | 1d | 2012-03-26 | 2012-03-26 | 861 | 841d | 0d | LBL_Mech Tech 4 | 8h | 862.3 |
| 872 | 1.5.1.2.2.9.2 | Flange | 6d | 2012-03-27 | 2012-04-03 | 871 | 841d | 0d | LBL_Material [21%]; LBL_Mech Tech 4 [66.7%] | 32h | 3,698.44 |
| 873 | 1.5.1.2.2.9.3 | Flange Base | 4d | 2012-04-04 | 2012-04-09 | 872 | 841d | 0d | LBL_Material [21%]; LBL_Machinist Jr. [12.5%]; LBL_Mech Tech 4 [50%] | 20h | 2,412.03 |

| ID | WBS | Task | Duration | Start | Finish | Predecessors | Total slack | Free slack | Constraint | Resources | Work | Cost |
| --- | --- | --- | --- | --- | --- | --- | --- | --- | --- | --- | --- | --- |
| 874 | 1.5.1.2.2.10 | **PST Assembly 2012** | 15d | 2012-04-10 | 2012-04-30 |  | 841d | 0d |  |  | 176h | 18,982.3 |
| 875 | 1.5.1.2.2.10.1 | Flange Bonded Assembly | 5d | 2012-04-10 | 2012-04-16 | 873 | 841d | 0d |  | LBL_Mech Tech 4 [200%]; LBL_CMM [40%] | 96h | 10,355.4 |
| 876 | 1.5.1.2.2.10.2 | PIT Bonded Assembly | 5d | 2012-04-17 | 2012-04-23 | 875 | 841d | 0d |  | LBL_CMM; LBL_Mech Tech 4 [60%] | 32h | 3,453.1 |
| 877 | 1.5.1.2.2.10.3 | Pixel Mount Assembly | 5d | 2012-04-24 | 2012-04-30 | 876 | 841d |  |  | LBL_Mech Tech 4 [120%] | 48h | 5,173.8 |
| 878 | 1.5.1.2.3 | **Shipping (MSC 2012)** | 15d | 2012-05-01 | 2012-05-21 | 874 | 841d |  |  |  | 16h | 3,393.23 |
| 879 | 1.5.1.2.3.1 | Box Fab -- Carpenters not MT but cost scaled | 5d | 2012-05-01 | 2012-05-07 |  | 841d | 0d |  | LBL_Mech Tech 4 [20%]; LBL_Material [40%]; LBL_Machinist Jr. | 12h | 1,775.23 |
| 880 | 1.5.1.2.3.2 | Packing | 5d | 2012-05-08 | 2012-05-14 | 879 | 841d | 0d |  | LBL_Mech Tech 4 [10%] | 4h | 431.15 |
| 881 | 1.5.1.2.3.3 | Shipping Cost | 5d | 2012-05-15 | 2012-05-21 | 880 | 841d |  |  | LBL_Material |  | 1,186.85 |
| 882 | 1.5.1.3 | **Beam Pipe Mechanics** | 191.5d | 2010-12-01 | 2011-09-02 |  | 1022.5d |  |  |  | 1324h | 136,953.47 |
| 883 | 1.5.1.3.1 | **Internal Support (Low Mass)** | 49d | 2010-12-01 | 2011-02-10 |  | 1165d |  |  |  | 268h | 37,255.09 |
| 884 | 1.5.1.3.1.1 | Integration into STAR | 10d | 2010-12-01 | 2010-12-14 |  | 1165d | 0d | start no earlier than 2010-12-01 | BNL Mech. Sr. Designer (Redirect) [40%] | 32h | 4,093.96 |
| 885 | 1.5.1.3.1.2 | Collar Prototypes | 5d | 2010-12-15 | 2010-12-21 | 884 | 1165d | 0d |  | LBL_Material [240%]; LBL_Machinist Jr. [50%]; LBL_Mech Tech 4 [50%] | 40h | 7,012.69 |
| 886 | 1.5.1.3.1.3 | Collar Production | 15d | 2010-12-22 | 2011-01-13 | 885 | 1165d | 0d |  | LBL_Material [360%]; LBL_Machinist Jr. [66.7%] | 80h | 12,697.49 |
| 887 | 1.5.1.3.1.4 | Sliding Support Prototypes | 2d | 2011-01-14 | 2011-01-18 | 886 | 1165d | 0d |  | LBL_Material [12%]; LBL_Machinist Jr. [50%]; LBL_Mech Tech 4 [50%]; LBL_Mech Eng Sr. [25%] | 20h | 2,407.52 |
| 888 | 1.5.1.3.1.5 | Sliding Support Production | 5d | 2011-01-19 | 2011-01-25 | 887 | 1165d | 0d |  | LBL_Material [20%] |  | 232.71 |
| 889 | 1.5.1.3.1.6 | Fixed Support Tool | 6d | 2011-01-26 | 2011-02-02 | 888 | 1165d | 0d |  | LBL_Material [40%]; LBL_Machinist Jr. [66.7%]; LBL_Mech Tech 4 [66.7%] | 64h | 7,217.62 |
| 890 | 1.5.1.3.1.7 | Fixed Support Production | 6d | 2011-02-03 | 2011-02-10 | 889 | 1165d |  |  | LBL_Material [21%]; LBL_Mech Tech 4 [66.7%] | 32h | 3,593.09 |
| 891 | 1.5.1.3.2 | **Alternate Beam Pipe Support** | 35d | 2011-04-04 | 2011-05-20 |  | 1095d |  |  |  | 224h | 27,129.18 |
| 892 | 1.5.1.3.2.1 | Design Engineering | 10d | 2011-04-04 | 2011-04-15 |  | 1095d | 0d | start no earlier than 2011-04-04 | BNL Mech. Sr. Designer (Redirect) [50%] | 40h | 5,117.45 |
| 893 | 1.5.1.3.2.2 | Part Fabrication | 4w | 2011-04-18 | 2011-05-13 | 892 | 1095d | 0d |  | LBL_Material [200%]; LBL_Machinist Jr. [25%]; LBL_Mech Tech 4 | 120h | 14,953.3 |
| 894 | 1.5.1.3.2.3 | Hardware | 5d | 2011-04-18 | 2011-04-22 | 892 | 1110d | 15d |  | LBL_Material [50%] |  | 581.79 |
| 895 | 1.5.1.3.2.4 | Installation | 5d | 2011-05-16 | 2011-05-20 | 894, 893 | 1095d |  |  | LBL_Mech Tech 4 [80%]; BNL Mech Tech (Redirect) [80%] | 64h | 6,476.64 |
| 896 | 1.5.1.3.3 | **External Beam Pipe Support** | 25.5d | 2011-07-05 | 2011-08-09 |  | 1022.5d |  |  |  | 152h | 18,779.98 |
| 897 | 1.5.1.3.3.1 | Integration into STAR | 60h | 2011-07-05 | 2011-07-14 |  | 1022.5d | 0d | start no earlier than 2011-07-05 | BNL Mech. Sr. Designer (Redirect) | 60h | 7,676.18 |
| 898 | 1.5.1.3.3.2 | I-Beam Modification | 2w | 2011-07-14 | 2011-07-28 | 897 | 1022.5d | 0d |  | BNL M_Tech Redirected [50%]; BNL Mech. Sr. Designer (Redirect) [25%] | 60h | 6,463.25 |
| 899 | 1.5.1.3.3.3 | Part Fabrication (Temp Supports) | 5d | 2011-07-14 | 2011-07-21 | 897 | 1053.5d |  |  | LBL_Material [80%] |  | 930.86 |
| 900 | 1.5.1.3.3.4 | Hardware | 5d | 2011-07-14 | 2011-07-21 | 897 | 1027.5d | 5d |  | LBL_Material [50%] |  | 581.79 |
| 901 | 1.5.1.3.3.5 | Installation | 8d | 2011-07-28 | 2011-08-09 | 900, 898 | 1022.5d | 0d |  | BNL Mech Tech (Redirect) [50%] | 32h | 3,127.9 |

| ID | WBS | Task | Type | Duration | Start | Finish | Predecessors | Total slack | Free slack | Constraint | Resources | Work | Cost |
| --- | --- | --- | --- | --- | --- | --- | --- | --- | --- | --- | --- | --- | --- |
| 902 | 1.5.1.3.4 | **Assembly Tool (Beam Pipe Support during Assembly)** |  | 18d | 2011-08-09 | 2011-09-02 |  | 1022.5d |  |  |  | 224h | 23,874.64 |
| 903 | 1.5.1.3.4.1 | Support Beams |  | 8d | 2011-08-09 | 2011-08-19 | 901 | 1022.5d | 0d |  | LBL_Material [80%]; LBL_Machinist Jr. [50%]; LBL_Mech Tech 4 [50%] | 64h | 7,683.04 |
| 904 | 1.5.1.3.4.2 | Tool Assembly 2012 |  | 5d | 2011-08-19 | 2011-08-26 | 903 | 1022.5d | 0d |  | LBL_Mech Tech 4; BNL Mech Tech (Redirect) | 80h | 8,095.8 |
| 905 | 1.5.1.3.4.3 | Tool Assembly 2013 |  | 5d | 2011-08-26 | 2011-09-02 | 904 | 1022.5d |  |  | LBL_Mech Tech 4; BNL Mech Tech (Redirect) | 80h | 8,095.8 |
| 906 | 1.5.1.3.5 | **Bake Out Equipment** |  | 41d | 2011-01-04 | 2011-03-03 |  | 1151d |  |  |  | 456h | 29,914.58 |
| 907 | 1.5.1.3.5.1 | **Insertable Bake Out Jacket** |  | 20d | 2011-01-04 | 2011-02-01 |  | 1151d |  |  |  | 176h | 20,931.25 |
| 908 | 1.5.1.3.5.1.1 | Bake Out Jacket Design |  | 120h | 2011-01-04 | 2011-01-25 |  | 1151d | 0d | start no earlier than 2011-01-04 | BNL Mech. Sr. Designer (Redirect) | 120h | 15,352.36 |
| 909 | 1.5.1.3.5.1.2 | Carriage Assembly |  | 40h | 2011-01-26 | 2011-02-01 | 908 | 1172d |  |  | BNL M_Tech Redirected; LBL_Mech Tech 4 [40%] | 56h | 5,578.89 |
| 910 | 1.5.1.3.5.2 | **Integrated Bake Out Jacket** |  | 15d | 2011-01-26 | 2011-02-15 |  | 1151d |  |  |  | 200h |  |
| 911 | 1.5.1.3.5.2.1 | Mid Section Design |  | 80h | 2011-01-26 | 2011-02-08 | 908 | 1151d | 0d |  |  | 80h |  |
| 912 | 1.5.1.3.5.2.2 | Extension Jacket Design |  | 120h | 2011-01-26 | 2011-02-15 | 911SS | 1151d | 0d |  |  | 120h |  |
| 913 | 1.5.1.3.5.3 | **Bake Out Test** |  | 11d | 2011-02-16 | 2011-03-03 |  | 1151d |  |  |  | 80h | 8,983.33 |
| 914 | 1.5.1.3.5.3.1 | Technical Support |  | 80h | 2011-02-16 | 2011-03-02 | 912 | 1151d | 0d |  | BNL Mech Tech (Redirect) | 80h | 7,819.76 |
| 915 | 1.5.1.3.5.3.2 | Hardware |  | 1d | 2011-03-03 | 2011-03-03 | 908, 914 | 1151d |  |  | LBL_Material |  | 1,163.57 |
| 916 | 1.5.2 | **Electronics** |  | 1d? | 2009-10-01 | 2009-10-01 |  | 1515d |  |  |  |  |  |
| 917 | 1.5.2.1 | Detector Grounding/EMI Control |  | 1d? | 2009-10-01 | 2009-10-01 |  | 1515d |  |  |  |  |  |
| 918 | 1.5.2.2 | Environmental Control |  | 1d? | 2009-10-01 | 2009-10-01 |  | 1515d |  |  |  |  |  |
| 919 | 1.5.2.3 | Shroud Bias |  | 1d? | 2009-10-01 | 2009-10-01 |  | 1515d |  |  |  |  |  |
| 920 | 1.5.3 | **Assembly** |  | 568d | 2011-04-25 | 2013-07-24 |  | 547d |  |  |  | 1224h | 162,673.96 |
| 921 | 1.5.3.1 | **MSC Assembly** |  | 45d | 2011-07-29 | 2011-09-30 |  | 1003d |  |  |  | 272h | 34,594.71 |
| 922 | 1.5.3.1.1 | MSC Assembly (LBL) 2011 |  | 4w | 2011-07-29 | 2011-08-25 | 830 | 1003d | 0d |  | LBL_Mech Tech 4; LBL_Material [200%] | 160h | 19,070.83 |
| 923 | 1.5.3.1.2 | MSC Tooling Assembly (BNL w/LBL Labor) |  | 2w | 2011-09-19 | 2011-09-30 | 922, 928 | 1003d | 0d |  | LBL_Mech Tech 4 [50%]; BNL Mech Tech (Redirect) [50%] | 80h | 8,095.8 |
| 924 | 1.5.3.1.3 | MSC Assembled and Ready for Installation | milestone | 0d | 2011-09-30 | 2011-09-30 | 923 | 1003d |  |  |  |  |  |
| 925 | 1.5.3.1.4 | **Shipping (MSC Tooling 2011)** |  | 15d | 2011-08-26 | 2011-09-16 | 922 | 1003d |  |  |  | 32h | 7,428.08 |
| 926 | 1.5.3.1.4.1 | Box Fab -- Carpenters not MT but cost scaled |  | 5d | 2011-08-26 | 2011-09-01 |  | 1003d | 0d |  | LBL_Mech Tech 4 [30%]; LBL_Material [50%]; LBL_Machinist Jr. | 16h | 2,262.99 |
| 927 | 1.5.3.1.4.2 | Packing |  | 5d | 2011-09-02 | 2011-09-09 | 926 | 1003d | 0d |  | LBL_Mech Tech 4 [40%] | 16h | 1,674.37 |
| 928 | 1.5.3.1.4.3 | Shipping Cost |  | 5d | 2011-09-12 | 2011-09-16 | 927 | 1003d | 0d |  | LBL_Material [300%] |  | 3,490.72 |

| ID | WBS | Task | Type | Duration | Start | Finish | Predecessors | Total slack | Free slack | Constraint | Resources | Work | Cost |
| --- | --- | --- | --- | --- | --- | --- | --- | --- | --- | --- | --- | --- | --- |
| 929 | 1.5.3.2 | **IDS Assembly** |  | 568d | 2011-04-25 | 2013-07-24 |  | 547d |  |  |  | 952h | 128,079.25 |
| 930 | 1.5.3.2.1 | Integration into STAR Assembly Hall |  | 32h | 2011-04-25 | 2011-04-28 | 784 | 1037d | 0d |  | BNL Mech. Sr. Designer (Redirect) | 32h | 4,093.96 |
| 931 | 1.5.3.2.2 | IDS Tooling Fabrication |  | 160h | 2011-04-29 | 2011-05-26 | 930 | 1037d | 0d |  | LBL_Material [1200%]; LBL_Machinist Jr.; LBL_Mech Tech 4 [50%] | 240h | 39,351.98 |
| 932 | 1.5.3.2.3 | IDS Tooling Assembly (LBL) |  | 120h | 2011-05-27 | 2011-06-24 | 931 | 1037d | 0d |  | LBL_Material [500%]; LBL_Mech Tech 4 | 120h | 18,375.63 |
| 933 | 1.5.3.2.4 | **Shipping (IDS Tooling)** |  | 17d | 2011-06-27 | 2011-07-20 |  | 1037d |  |  |  | 64h | 13,110.81 |
| 934 | 1.5.3.2.4.1 | Box Fab -- Carpenters not MT but cost scaled |  | 32h | 2011-06-27 | 2011-06-30 | 932 | 1037d | 0d |  | LBL_Mech Tech 4; LBL_Material; LBL_Machinist Jr. | 40h | 5,363.17 |
| 935 | 1.5.3.2.4.2 | Packing |  | 24h | 2011-07-01 | 2011-07-06 | 934 | 1037d | 0d |  | LBL_Mech Tech 4 | 24h | 2,511.55 |
| 936 | 1.5.3.2.4.3 | Shipping |  | 2w | 2011-07-07 | 2011-07-20 | 935 | 1037d | 0d |  | LBL_Material [450%] |  | 5,236.08 |
| 937 | 1.5.3.2.5 | IDS Tooling Assembly At BNL |  | 136h | 2011-07-21 | 2011-08-12 | 936 | 1037d | 0d |  | LBL_Mech Tech 4; BNL Mech Tech (Redirect) | 272h | 27,525.72 |
| 938 | 1.5.3.2.6 | IDS Assembly 2013 |  | 80h | 2013-07-01 | 2013-07-24 |  | 547d |  | start no earlier than 2013-07-01 | LBL_Mech Tech 4; BNL Mech Tech (Redirect); BNL Material [200%] | 160h | 19,177.67 |
| 939 | 1.5.3.2.7 | **Service Termination and Testing** |  | 12d | 2011-10-04 | 2011-10-19 |  | 990d |  |  |  | 64h | 6,443.48 |
| 940 | 1.5.3.2.7.1 | IFC Gas Service termination |  | 5d | 2011-10-04 | 2011-10-10 |  | 990d | 0d | start no earlier than 2011-10-04 | BNL Mech Tech (Redirect) | 40h | 4,027.18 |
| 941 | 1.5.3.2.7.2 | Shroud Bias Termination/Test |  | 3d | 2011-10-11 | 2011-10-13 | 940 | 990d | 0d |  | BNL Mech Tech (Redirect) | 24h | 2,416.31 |
| 942 | 1.5.3.2.7.3 | Beam Pipe Load Transfer/Survey |  | 4d | 2011-10-14 | 2011-10-19 | 941 | 990d |  |  |  |  |  |
| 943 | 1.5.4 | **Integration Infrastructure** |  | 572d? | 2009-10-01 | 2011-12-26 |  | 944d |  |  |  | 547.5h | 94,426 |
| 944 | 1.5.4.1 | Production OSC/MSC at BNL for Integration | milestone | 0d | 2011-09-30 | 2011-09-30 | 923 | 1003d |  |  |  |  |  |
| 945 | 1.5.4.2 | **Cables** |  | 572d | 2009-10-01 | 2011-12-26 |  | 944d |  |  |  | 239.5h | 27,628.02 |
| 946 | 1.5.4.2.1 | Shroud Bias Cable |  | 9d | 2009-10-01 | 2009-10-13 |  | 1507d |  |  | LBL_Material [170%]; LBL_Machinist Sr. [1.4%]; LBL_Mech Tech 4 [47.2%]; LBL_Postdoc Contributed [38.9%]; LBL_Elec Eng Sr [95.1%] | 131.5h | 14,596.76 |
| 947 | 1.5.4.2.2 | Environmental and Rad Monitor Cables |  | 8d | 2011-12-15 | 2011-12-26 |  | 944d |  | start no earlier than 2011-12-15 | LBL_Material [90%]; LBL_Mech Tech 4; LBL_Postdoc Contributed [12.5%]; LBL_Elec Eng Sr [56.2%] | 108h | 13,031.25 |
| 948 | 1.5.4.3 | **Dry Gas Services** |  | 10.11d? | 2009-10-01 | 2009-10-15 |  | 1505.89d |  |  |  | 96h | 11,048.7 |
| 949 | 1.5.4.3.1 | Interface Ducting |  | 10.11d | 2009-10-01 | 2009-10-15 |  | 1505.89d |  |  | LBL_Material [95%]; LBL_Machinist Sr. [18.8%]; LBL_Mech Tech 4 | 96h | 11,048.7 |
| 950 | 1.5.4.3.2 | External Ducting |  | 1d? | 2009-10-01 | 2009-10-01 |  | 1515d |  |  |  |  |  |
| 951 | 1.5.4.4 | **Hall Modifications and Safety** |  | 22d? | 2009-10-01 | 2009-10-30 |  | 1494d |  |  |  | 212h | 55,749.28 |
| 952 | 1.5.4.4.1 | Clean Room Modifications |  | 10d | 2009-10-01 | 2009-10-14 |  | 1494d | 0d |  | LBL_Material [1000%]; LBL_Mech Tech 4; LBL_Elec Eng Sr [30%] | 104h | 22,740.64 |
| 953 | 1.5.4.4.2 | External Clean Tent |  | 11d | 2009-10-15 | 2009-10-29 | 952 | 1494d | 0d |  | LBL_Material [1700%]; LBL_Mech Tech 4 [27.3%]; LBL_Elec Eng Sr [95.5%] | 108h | 33,008.64 |
| 954 | 1.5.4.4.3 | Shield Wall Pass Thru |  | 1d? | 2009-10-30 | 2009-10-30 | 953 | 1494d |  |  |  |  |  |

| ID | WBS | Task | Type | Duration | Start | Finish | Predecessors | Total slack | Free slack | Constraint | Resources | Work | Cost |
| --- | --- | --- | --- | --- | --- | --- | --- | --- | --- | --- | --- | --- | --- |
| 955 | 1.5.5 | **Installation** |  | 669d | 2011-03-02 | 2013-10-22 |  | 484d |  |  |  | 1000h | 131,922.47 |
| 956 | 1.5.5.1 | **Insertion into STAR of IDS** |  | 669d | 2011-03-02 | 2013-10-22 |  | 484d |  |  |  | 1000h | 131,922.47 |
| 957 | 1.5.5.1.1 | Lift Fixture modification design |  | 40h | 2011-03-02 | 2011-03-08 |  | 998d | 0d | start no earlier than 2011-03-02 | BNL Mech. Sr. Designer (Redirect) | 40h | 5,117.45 |
| 958 | 1.5.5.1.2 | Cradle Modification design |  | 40h | 2011-03-02 | 2011-03-08 | 957SS | 998d | 124d |  | LBL_Engineer Redirected | 40h | 4,659.01 |
| 959 | 1.5.5.1.3 | Technical Support LBNL 2012 |  | 8w | 2011-09-01 | 2011-10-27 | 957, 958 | 874d | 0d | start no earlier than 2011-09-01 | LBL_Mech Tech 4 [50%]; LBL_Travel [1000%] | 160h | 29,584.73 |
| 960 | 1.5.5.1.4 | Technical Support STAR 2012 |  | 8w | 2011-09-01 | 2011-10-27 | 959SS | 984d |  |  | BNL M_Tech Redirected [37.5%] | 120h | 11,880.49 |
| 961 | 1.5.5.1.5 | Technical Support LBNL 2013 |  | 11w | 2012-08-01 | 2012-10-17 | 959 | 682d | 0d | start no earlier than 2012-08-01 | LBL_Mech Tech 4 [36.4%]; LBL_Travel [1000%] | 160h | 30,165.02 |
| 962 | 1.5.5.1.6 | Technical Support STAR 2013 |  | 10.5w | 2012-08-01 | 2012-10-15 | 961SS | 739.5d |  |  | BNL M_Tech Redirected [38.1%] | 160h | 16,183.16 |
| 963 | 1.5.5.1.7 | Technical Support LBNL 2014 |  | 11w | 2013-08-06 | 2013-10-22 | 961 | 484d | 0d | start no earlier than 2013-08-06 | LBL_Mech Tech 4 [36.4%] | 160h | 17,763.37 |
| 964 | 1.5.5.1.8 | Technical Support STAR 2014 |  | 10.5w | 2013-08-06 | 2013-10-18 | 963SS | 486.5d |  |  | BNL M_Tech Redirected [38.1%] | 160h | 16,569.24 |
| 965 | 1.5.6 | Integration Engineering Support (post CD-1) |  | 143d | 2010-08-31 | 2011-03-25 | 29 | 344d | 0d |  | LBL_Mech Eng Sr. [49.7%] | 568h | 81,952.8 |
| 966 | 1.5.7 | Integration Engineering Support (post CD-2/3) |  | 791d | 2011-03-28 | 2014-05-16 | 965, 20 | 344d |  |  | LBL_Mech Eng Sr. [50%] | 3164h | 477,398.45 |
| 967 | 1.6 | **Software** |  | 759d | 2010-03-01 | 2013-02-28 |  | 650d |  |  |  |  |  |
| 968 | 1.6.1 | Calibration Model Developed | milestone | 0d | 2010-03-01 | 2010-03-01 |  | 1409d |  | start no earlier than 2010-03-01 |  |  |  |
| 969 | 1.6.2 | Tracker/Vertex Finders Functional | milestone | 0d | 2011-08-01 | 2011-08-01 |  | 1047d |  | start no earlier than 2011-08-01 |  |  |  |
| 970 | 1.6.3 | Reconstruction Software Finalized | milestone | 0d | 2012-07-02 | 2012-07-02 |  | 813d |  | start no earlier than 2012-07-02 |  |  |  |
| 971 | 1.6.4 | IST Online and Calibration Software Commissioned | milestone | 0d | 2013-02-28 | 2013-02-28 |  | 650d |  | start no earlier than 2013-02-28 |  |  |  |
